# 3GPP_Work Plan

Schedule from MS Project, 2000-01-01 to 2004-01-27, A marks actual dates.

## Calendars

- Standard: Mon-Fri 08:00-12:00, 13:00-17:00; Sat-Sun off.

## Resources

| Resource |
| --- |
| NP |
| N1 |
| N2 |
| N3 |
| N4 |
| N5 |
| TP |
| T1 |
| T2 |
| T3 |
| RP |
| R1 |
| R2 |
| R3 |
| R4 |
| SP |
| S1 |
| S2 |
| S3 |
| S4 |
| S5 |
| PCG |
| GP |
| No |
| CN4 |
| ? |
| WG G2 |
| G2 |
| G1 |
| G4 |
| G3 |
| All |
| Generic |
| MLST |
| G5 |
| WG SA2 |

## Schedule

| ID | WBS | Task | Duration | Start | Finish | Complete | Remaining | Baseline start | Baseline finish | Baseline duration | Total slack | Constraint | Resources | Work | Actual work | Text6 | Text9 | Text1 | Text4 | Text7 | Text8 | Text2 | Text5 |
| --- | --- | --- | --- | --- | --- | --- | --- | --- | --- | --- | --- | --- | --- | --- | --- | --- | --- | --- | --- | --- | --- | --- | --- |
| 1 | 1 | VERSION 2003 January 15th | 1d | 2000-01-03 | 2000-01-03 |  |  | 2000-01-03 | 2000-01-03 | 1d | 1034d |  |  |  |  | Rel | 2044 |  |  |  |  |  |  |
| 2 | 2 | "CTRL + a" to display all the 3GPP fields | 1d | 2000-01-03 | 2000-01-03 |  |  | 2000-01-03 | 2000-01-03 | 1d | 976d |  |  |  |  |  | 1462 |  |  |  |  |  |  |
| 3 | 3 | Content of Rel4 and Rel5 frozen. Rel6 and after not frozen. | 1d | 2000-01-03 | 2000-01-03 |  |  | 2000-01-03 | 2000-01-03 | 1d | 976d |  |  |  |  | Rel | 2058 |  |  |  |  |  |  |
| 6 | 6 | Evolutions of the transport in the UTRAN | 445d | 2000-07-17 A | 2002-03-29 A | 100% |  | 2000-07-17 | 2002-03-29 | 445d |  |  | RP | 3560h | 3560h | NA |  | ETRAN | Francois Courau | TSG | Carolyn |  |  |
| 7 | 7 | **Evolutions of the transport in the CN** | 261d | 2002-06-07 A | 2003-06-06 | 50% | 130.5d | 2001-03-12 | 2001-12-21 | 205d | 167d |  | N4 | 3136h | 2088h | NA |  | CNTRSP |  |  | Kimmo | BaAS |  |
| 8 | 7.1 | Preferred Framing Protocol for bearer independent CS architecture | 261d | 2002-06-07 A | 2003-06-06 | 50% | 130.5d |  |  |  | 167d | finish no earlier than 2003-06-06 | N4 | 2088h | 1044h | Rel6 |  | PFP | Phli Hodges, Ericsson | TSG |  |  | philip.hodges@ericsson.com.au |
| 9 | 8 | **Improvements of Radio Interface** | 791d | 2000-06-19 A | 2003-06-30 | 26% | 586.26d | 2000-06-19 | 2003-06-30 | 791d | 151d |  | RP | 61424h | 18750.7h | NA |  | RInImp |  | TSG | Shinobu |  |  |
| 10 | 8.1 | Improvement of inter-frequency and inter-system measurement | 502d | 2001-01-01 | 2002-12-03 |  |  | 2001-01-01 | 2002-12-03 | 502d | 215d | finish no earlier than 2002-12-03 | R1 | 4016h |  | Rel6 | 1470 | RInImp-IfIsM | Nokia (Antti Toskala) | TSG |  | BaAS |  |
| 11 | 8.2 | **Base station classification** | 603d | 2000-08-14 A | 2002-12-04 | 85% | 90.45d |  |  |  | 299d |  | R4 | 9648h | 8200.8h | Rel6 |  | RInImp-BSClass |  | TSG |  |  |  |
| 12 | 8.2.1 | FDD Base station classification | 603d | 2000-08-14 A | 2002-12-04 | 85% | 90.45d | 2000-08-14 | 2002-12-20 | 615d | 214d | finish no earlier than 2002-12-04 | R4 | 4824h | 4100.4h | Rel6 | 1476 | RInImp-BSClass-FDD | A. Toskala, Nokia | TSG |  | BaAs |  |
| 13 | 8.3 | Improved usage of downlink resource in FDD for CCTrCHs of dedicated type | 580d | 2000-10-09 | 2002-12-27 |  |  | 2000-10-09 | 2002-12-27 | 580d | 197d | finish no earlier than 2002-12-27 | R2 | 4640h |  | Rel6 | 1218 | RInImp-CCTrCH | N. Pereira, C. Mihailescu, Nortel Networks | TSG |  | BaAS |  |
| 14 | 8.4 | Terminal Power Saving features | 791d | 2000-06-19 | 2003-06-30 |  |  | 2000-06-19 | 2003-06-30 | 791d | 66d | finish no earlier than 2003-06-30 | R2 | 6328h |  | Rel6 | 1507 | RInImp-TPS | M. Park, Samsung | TSG |  | BaAS |  |
| 15 | 8.5 | Multiple Input Multiple Output antennas (MIMO) | 518d | 2001-03-16 A | 2003-03-11 | 35% | 336.7d | 2001-03-16 | 2003-03-11 | 518d | 145d | finish no earlier than 2003-03-11 | R1 | 4144h | 1450.4h | Rel6 | 2468 | RInImp-MIMO | Howard Huang, Lucent | TSG |  |  |  |
| 16 | 8.6 | Improving Receiver Performance Requirements for the FDD UE | 196d | 2002-03-08 A | 2002-12-06 | 60% | 78.4d | 2002-03-08 | 2002-12-06 | 196d | 212d | finish no earlier than 2002-12-06 | R4 | 1568h | 940.8h | Rel6 |  | RInImp-UERecPerf | Shimon Moshavi, Intel | TSG |  |  |  |
| 17 | 8.7 | FS for the viable deployment of UTRA in additional and diverse spectrum arrangements | 314d | 2001-09-21 A | 2002-12-04 | 70% | 94.2d | 2001-09-21 | 2002-06-21 | 196d | 214d | finish no earlier than 2002-12-04 | R4 | 2512h | 1758.4h | Rel6 |  | RInImp-UMTSBands | Peter Ståhlfjäll, Ericsson | TSG | Cesar |  |  |
| 18 | 8.8 | FS on UE antenna efficiency test methods performance requirements (2) | 131d | 2002-03-08 A | 2002-09-06 A | 100% |  | 2002-03-08 | 2002-12-06 | 196d |  | finish no earlier than 2002-09-06 | R4 | 1048h | 1048h | Rel6 |  | RInImp-UEAnTM2 | Alf Ahlström, Allgon | TSG |  |  |  |
| 19 | 8.9 | FS on Fast Cell Selection (FCS) for HS-DSCH | 521d | 2001-03-16 | 2003-03-14 |  |  | 2001-03-16 | 2002-12-03 | 448d | 142d | finish no earlier than 2003-03-14 | R1 | 4168h |  | Rel6 | 2471 | RInImp-FCS | Rizwan Hassan, Lucent | TSG |  |  |  |
| 20 | 8.10 | FS on Radio link performance enhancements | 610d | 2000-08-14 A | 2002-12-13 | 31% | 420.9d | 2000-08-14 | 2002-09-03 | 537d | 207d | finish no earlier than 2002-12-13 | R1 | 4880h | 1512.8h | Rel6 | 1506 | RInImp-Rlperf | Antti Toskala, Nokia Networks | TSG |  |  |  |
| 21 | 8.11 | FS on UTRA WideBand Distribution Systems | 525d | 2001-03-12 A | 2003-03-14 | 40% | 315d | 2001-03-12 | 2003-03-14 | 525d | 142d | finish no earlier than 2003-03-14 | R4 | 4200h | 1680h | Rel6 |  | RInImp-WDS | Andrea Casini, Tekmar Sistemi | TSG |  |  |  |
| 22 | 8.12 | FS on Improvement of inter-frequency and inter-system measurements for 1.28 Mcps TDD | 326d | 2001-12-14 A | 2003-03-14 | 20% | 260.8d | 2001-12-14 | 2002-06-04 | 123d | 142d | finish no earlier than 2003-03-14 | R1 | 2608h | 521.6h | Rel6 |  | RInImp-IfIsMLCR | Li Xiao Qiang, SAMSUNG | TSG |  |  |  |
| 23 | 8.13 | FS for the analysis of OFDM for UTRAN enhancements | 265d | 2002-06-10 | 2003-06-13 |  |  |  |  |  | 77d | finish no earlier than 2003-06-13 | R1 | 2120h |  | Rel6 |  | RInImp-FSOFDM | Sarah Boumendil, Nortel | TSG |  |  |  |
| 24 | 8.14 | FS on Uplink Enhancements for Dedicated Transport Channels | 201d | 2002-09-06 | 2003-06-13 |  |  |  |  |  | 77d | finish no earlier than 2003-06-13 | R1 | 1608h |  | Rel6 |  | RInImp-FSUpDTrCh | Karri Ranta-aho, Nokia | TSG |  |  |  |
| 25 | 8.15 | FS on Analysis on Higher Chip Rates for UTRA TDD evolutions | 201d | 2002-09-06 | 2003-06-13 |  |  |  |  |  | 77d | start no earlier than 2002-09-06 | R1 | 1608h |  | Rel6 |  | Rin-Imp-FSVHCRTDD | Tim Wilkinson, IPWireless | TSG |  |  |  |
| 26 | 9 | **RAN improvements** | 911d? | 2000-01-03 A | 2003-06-30 | 19% | 738.25d? | 2000-08-21 | 2003-06-30 | 746d | 151d |  | RP | 11392h | 2160.24h | NA |  | RANimp |  | TSG | Hans |  |  |
| 27 | 9.1 | Beamforming Enhancements | 321d | 2001-12-14 A | 2003-03-07 | 40% | 192.6d | 2001-12-14 | 2002-12-03 | 253d | 147d | finish no earlier than 2003-03-07 | R1 | 2568h | 1027.2h | Rel6 |  | RANimp-BFE | Jussi Kähtävä, Nokia | TSG |  |  |  |
| 28 | 9.2 | RAB support enhancement | 206d | 2002-09-16 | 2003-06-30 |  |  | 2000-08-21 | 2003-06-30 | 746d | 66d | start no earlier than 2002-09-16 | R2 | 1648h |  | Rel6 | 624 | RANimp-RABSE | M. Israelsson, A. Krishnarajah, Ericsson | TSG |  | BaAS |  |
| 29 | 9.3 | Improvement of RRM across RNS and RNS/BSS | 218d | 2002-03-25 A | 2003-01-22 | 30% | 152.6d | 2002-03-25 | 2003-01-22 | 218d | 179d | finish no earlier than 2003-01-22 | R3 | 1744h | 523.2h | Rel6 |  | RANimp-RRM1 | Woonhee Hwang, Nokia |  |  |  |  |
| 30 | 9.4 | FS on the evolution of the UTRAN architecture | 200d | 2002-09-09 | 2003-06-13 |  |  |  |  |  | 77d | start no earlier than 2002-09-09 | R3 | 1600h |  | Rel6 |  | RANimp-FSEvo | Woonhee Hwang, Nokia | TSG |  |  |  |
| 31 | 9.5 | FS for the Early Mobile Handling in UTRAN | 70d | 2002-09-09 | 2002-12-13 |  |  |  |  |  | 207d | finish no earlier than 2002-12-13 | R2 | 560h |  | Rel6 |  | RANimp-FSEarlyUE | Alan Law, Vodafone Ltd | TSG |  |  |  |
| 32 | 7.6 | S2-030394 | 1d | 2000-01-03 | 2000-01-03 |  |  |  |  |  | 1061d |  | S2 | 8h |  |  |  |  |  |  |  |  |  |
| 33 | 7.7 | SA2 review of the Work Plan, version Jan 15th | 1d | 2000-01-03 | 2000-01-03 |  |  | 2000-01-03 | 2000-01-03 | 1d | 1061d |  | S2 | 8h |  |  |  |  |  |  |  |  |  |
| 34 | 7.8 | Red: big delay | 1d | 2000-01-03 | 2000-01-03 |  |  | 2000-01-03 | 2000-01-03 | 1d | 1061d |  | S2 | 8h |  |  |  |  |  |  |  |  |  |
| 35 | 7.9 | Purple: delay | 1d | 2000-01-03 | 2000-01-03 |  |  | 2000-01-03 | 2000-01-03 | 1d | 1061d |  | S2 | 8h |  |  |  |  |  |  |  |  |  |
| 36 | 7.10 | Green: on time | 1d | 2000-01-03 | 2000-01-03 |  |  | 2000-01-03 | 2000-01-03 | 1d | 1061d |  | S2 | 8h |  |  |  |  |  |  |  |  |  |
| 37 | 7.11 | Maroon : question | 1d? | 2000-01-03 | 2000-01-03 |  |  |  |  |  | 1061d |  | S2 | 8h |  |  |  |  |  |  |  |  |  |

Notes:
- 6: To be deleted at TSG#18 if no input.
- 7: To be deleted at TSG#18 if no input.
- 8: WID approved at CN#16 / 15/11/2003 CN4: target will be Cn#20
- 10: RP-020389
- 13: Ttime line changed after decision in RAN#13
- 14: This is a building block without particular end date
- 15: Status report: RP-020429
- 18: The RInImp-UEAnTM FS was re-opened at TSG RAN#15 upon request from WG4
- 19: RP-020446
- 20: RP-020358
- 22: RP-020374
- 27: RP-020357
- 28: This is a building block without particular end date

| ID | WBS | Task | Duration | Start | Finish | Predecessors | Complete | Remaining | Baseline start | Baseline finish | Baseline duration | Total slack | Constraint | Resources | Work | Actual work | Text1 | Text2 | Text4 | Text5 | Text6 | Text7 | Text8 | Text9 | Text3 |
| --- | --- | --- | --- | --- | --- | --- | --- | --- | --- | --- | --- | --- | --- | --- | --- | --- | --- | --- | --- | --- | --- | --- | --- | --- | --- |
| 39 | 10 | **Emergency call enhancements** | 1062d | 2000-01-03 A | 2004-01-27 |  | 12% | 930.66d | 2000-01-03 | 2003-03-28 | 845d | 0d |  | N1 | 35312h | 4367.11h | EMC1 | CCaR | Mr Rouzbeh, Ericsson | EUSFARO@am1.ericsson.se | Rel6 | WG | Per | 1652 |  |
| 40 | 10.1 | **For IP & PS based calls** | 1062d | 2000-01-03 A | 2004-01-27 |  | 12% | 930.66d | 2000-01-03 | 2003-03-28 | 845d | 0d |  | N1 | 27496h | 3400.49h | EMC1-PS | CCaR | Mr Rouzbeh, Ericsson | EUSFARO@am1.ericsson.se | Rel6 |  |  | 1653 |  |
| 41 | 10.1.1 | Service Requirements for IP-based emergency calls | 205d | 2000-09-18 A | 2001-06-29 |  | 44% | 115d | 2000-09-18 | 2001-06-29 | 205d | 672d | start no earlier than 2000-09-18 | S1 | 1640h | 720h |  | CCaR |  |  |  |  |  | 1314 | 22.976 |
| 42 | 10.1.2 | SIP emergency calls and packet emergency calls signalling flowsl | 756d | 2000-10-17 A | 2003-09-09 |  | 21% | 597.24d | 2000-10-17 | 2003-03-28 | 639d | 100d | finish no earlier than 2003-09-09 | N1 | 6048h | 1270.08h |  | CCaR | Mr Rouzbeh, Ericsson | EUSFARO@am1.ericsson.se |  |  |  | 1315 | TS 24.228 |
| 43 | 10.1.3 | CHECK with CN1 (S2 opinion: PS-domain emergency calls use the IMS) - Stage 2 for emergency calls and packet emergency calls in general | 185d | 2002-08-12 A | 2003-04-25 |  | 35% | 120.25d | 2000-10-02 | 2002-12-06 | 570d | 0d | finish no earlier than 2003-04-25 | S2 | 1480h | 518h |  | CCaR |  |  |  |  |  | 1316 |  |
| 44 | 10.1.4 | Distinction of emergency call types to different emergency services | 197d | 2003-04-28 | 2004-01-27 | 43 |  |  | 2002-12-09 | 2003-03-28 | 80d | 0d | finish no earlier than 2003-09-09 | N1 | 1576h |  |  | CCaR |  |  |  |  |  | 1317 |  |
| 45 | 10.1.5 | Stage 3 for emergency calls and packet emergency calls in general | 802d | 2000-08-14 | 2003-09-09 |  |  |  | 2000-08-14 | 2003-03-28 | 685d | 100d | finish no earlier than 2003-09-09 | N1 | 6416h |  |  | CCaR | Rouzbeh Farhoumand, Ericsson | rouzbeh.farhoumand@ericsson.com |  |  |  | 1646 | TS 24.229 |
| 46 | 10.1.6 | Conformance Test Aspects - Emergency call enhancements | 195d | 2000-01-03 | 2000-09-29 |  |  |  | 2000-01-03 | 2000-09-29 | 195d | 867d |  | T1 | 1560h |  |  |  |  |  |  |  |  | 2224 |  |
| 47 | 10.1.7 | Testing Stage 3 for emergency calls and packet emergency calls in general | 195d | 2002-03-01 | 2002-11-28 |  |  |  | 2002-03-01 | 2002-11-28 | 195d | 303d | finish no earlier than 2002-11-28 | T1 | 1560h |  |  |  |  |  |  |  |  | 2225 |  |
| 48 | 11 | Terminal interfaces | 223d | 2001-05-14 A | 2002-03-20 A |  | 100% |  | 2001-05-14 | 2002-03-20 | 223d |  |  | T2 | 1784h | 1784h | TI | Ter |  |  | NA |  | Friedhelm | 1826 |  |
| 49 | 12 | **Location Services enhancements 2** | 845d | 2000-08-28 A | 2003-11-21 |  | 13% | 735.18d |  |  |  | 47d |  | S2 | 35096h | 5322.77h | LCS2 |  |  |  | Rel6 | TSG |  |  |  |
| 50 | 12.1 | Improvement on Le interface | 130d | 2002-06-21 | 2002-12-19 |  |  |  |  |  |  | 288d | finish no earlier than 2002-12-19 | S2 | 1040h |  |  |  |  |  |  | TSG |  |  |  |
| 51 | 12.2 | Enhanced support for user privacy and subscriber data handling | 405d | 2001-06-04 A | 2002-12-20 |  | 7% | 375d | 2001-06-04 | 2001-12-21 | 145d | 287d | start no earlier than 2001-06-04 | S2 | 3240h | 240h |  |  |  |  |  | TSG |  |  |  |
| 52 | 12.3 | Enhanced inter-GMLC interface | 145d | 2002-06-24 | 2003-01-10 |  |  |  | 2001-06-04 | 2001-12-21 | 145d | 272d | start no earlier than 2002-06-24 | S2 | 1160h |  |  |  |  |  |  | TSG |  |  |  |
| 53 | 12.4 | Support of the Presence Service Architecture | 90d | 2002-06-24 A | 2002-10-25 |  | 28% | 64.8d | 2002-01-14 | 2002-03-15 | 45d | 327d | finish no earlier than 2002-10-25 | S2 | 720h | 201.6h |  |  |  |  |  | TSG |  |  |  |
| 54 | 12.5 | New events for triggered location reports | 131d | 2002-06-21 | 2002-12-20 |  |  |  |  |  |  | 287d | finish no earlier than 2002-12-20 | S2 | 1048h |  |  |  |  |  |  | TSG |  |  |  |
| 55 | 12.6 | FS on applicability of GALILEO for LCS | 135d | 2002-09-16 | 2003-03-21 |  |  |  |  |  |  | 222d | finish no earlier than 2003-03-21 | S2 | 1080h |  |  |  |  |  |  |  |  |  |  |
| 56 | 12.7 | **UE positionning** | 741d | 2000-08-28 A | 2003-06-30 |  | 17% | 614.54d |  |  |  | 151d |  | RP | 13424h | 2290.95h | LCS2-UEpos |  |  |  | Rel6 | TSG |  |  |  |
| 57 | 12.7.1 | UE positioning enhancements - other methods | 741d | 2000-08-28 A | 2003-06-30 |  | 11% | 659.49d | 2000-08-28 | 2003-06-30 | 741d | 151d | finish no earlier than 2003-06-30 | R2 | 5928h | 652.08h | LCS2-UEpos-enh |  | M. Beckmann, Siemens |  |  | TSG |  | 2457 |  |
| 58 | 12.7.2 | FS on Enhancements to OTDOA Positioning using advanced blanking methods | 196d | 2002-07-01 A | 2003-03-31 |  | 40% | 117.6d |  |  |  | 216d | finish no earlier than 2003-03-31 | R2 | 1568h | 627.2h | LCS2-UEpos-FSBlank |  | David Bartlett, Cambridge Positioning Systems |  |  | TSG |  |  |  |
| 59 | 10.8 | **Uplink TDOA location determination for GSM/GPRS** | 266d | 2002-11-15 | 2003-11-21 |  |  |  |  |  |  | 47d |  | GP | 5104h |  | UTDOA |  | Gross/Robinson, TruePosition, Inc. |  | Rel6 | TSG | Paolo |  |  |
| 60 | 10.8.1 | Addition of U-TDOA in the CS domain | 106d | 2002-11-15 | 2003-04-11 |  |  |  |  |  |  | 207d | finish no earlier than 2003-04-11 | GP | 848h |  | UTDOA-CS |  |  |  | Rel6 |  |  |  |  |
| 61 | 10.8.2 | Addition of U-TDOA in the CS domain | 266d | 2002-11-15 | 2003-11-21 |  |  |  |  |  |  | 47d | finish no earlier than 2003-11-21 | GP | 2128h |  | UTDOA-PS |  |  |  | Rel6 |  |  |  |  |
| 62 | 12.8 | **CLARIFY (Stage 3: 0%) - Open SMLC-SRNC Interface within the UTRAN to support UTRAN Rel4 positioning methods** | 195d | 2001-01-15 A | 2001-10-12 |  | 59% | 80d | 2001-01-15 | 2001-10-12 | 195d | 597d |  | R2 | 3120h | 1919.6h | LCS-Rel4Pos |  | Antti Toskala, Nokia |  | Rel6 | TSG |  | 2475 |  |
| 63 | 12.8.1 | Stage 2 | 195d | 2001-01-15 A | 2001-10-12 |  | 59% | 80d | 2001-01-15 | 2001-10-12 | 195d | 597d | start no earlier than 2001-01-15 | S2 | 1560h | 920h |  |  | Kirk Burroughs, Qualcomm |  |  | WG |  | 2127 |  |

Notes:
- 42: No new spec will be presented, will be covered in CN1 spec24.228.
- 43: covered by TS 23.228
- 45: Potentially sub contracted to IETF / covered by TS 24.229
- 47: This task required more supporting companies
- 57: This is a building block without particular end date

| ID | WBS | Task | Duration | Start | Finish | Complete | Remaining | Baseline start | Baseline finish | Baseline duration | Total slack | Constraint | Resources | Work | Actual work | Text1 | Text2 | Text6 | Text8 | Text9 | Text4 | Text5 | Text7 | Text3 |
| --- | --- | --- | --- | --- | --- | --- | --- | --- | --- | --- | --- | --- | --- | --- | --- | --- | --- | --- | --- | --- | --- | --- | --- | --- |
| 64 | 13 | **(U)SIM toolkit enhancements** | 391d | 2002-03-20 A | 2003-09-17 | 25% | 292.05d | 2000-06-05 | 2003-09-26 | 865d | 94d |  | T3 | 10040h | 2540.78h | USAT1 | Ter | NA | MichaelS | 1800 |  |  |  |  |
| 65 | 13.1 | **UICC API** | 391d | 2002-03-20 A | 2003-09-17 | 25% | 292.05d | 2000-09-25 | 2002-09-27 | 525d | 94d |  | T3 | 6912h | 1749.19h | USAT1-API | Ter | NA |  | 1802 |  |  |  |  |
| 66 | 13.1.1 | Java API Test specification | 133d | 2002-03-20 A | 2002-09-20 | 90% | 13.3d | 2002-03-20 | 2002-09-20 | 133d | 352d | finish no earlier than 2002-09-20 | T3 | 1064h | 957.6h |  |  |  |  |  | Mario Pérez (Microelectrónica Española) |  |  |  |
| 67 | 13.1.2 | Java API Test specification (TS 43.019 Rel-5) | 340d | 2002-05-30 | 2003-09-17 |  |  |  |  |  | 94d | finish no earlier than 2003-09-17 | T3 | 2720h |  |  |  | Rel5 |  |  | Mario Pérez (Microelectrónica Española) |  |  |  |
| 68 | 14 | **Security enhancements** | 935d | 2000-02-21 A | 2003-09-19 | 32% | 637.44d | 2000-01-03 | 2002-12-06 | 765d | 92d |  | S3 | 31664h | 10907.8h | SEC1 |  | NA | Maurice |  | Peter Howard, Vodafone | Peter.Howard@vodafone.com | TSG |  |
| 69 | 14.1 | **Enhanced HE control of security (including positive authentication reporting)** | 573d | 2001-01-03 A | 2003-03-14 | 24% | 434.2d | 2001-01-03 | 2002-06-14 | 378d | 227d |  | S3 | 11296h | 3606.41h |  |  | Rel6 |  | 2026 | Peter Howard, Vodafone | Peter.Howard@vodafone.com |  |  |
| 70 | 14.1.1 | Stage 2 | 378d | 2001-01-03 | 2002-06-14 |  |  | 2001-01-03 | 2002-06-14 | 378d | 422d | finish no earlier than 2002-06-14 | S3 | 3024h |  |  |  |  |  | 2027 |  |  |  |  |
| 71 | 14.1.2 | FS on Network impacts | 71d | 2002-12-06 | 2003-03-14 |  |  | 2002-04-08 | 2002-06-07 | 45d | 227d | finish no earlier than 2003-03-14 | N4 | 568h |  |  |  |  |  | 2028 |  |  |  |  |
| 72 | 14.1.3 | **Network domain security** | 195d | 2002-06-17 A | 2003-03-14 | 80% | 39d |  |  |  | 227d |  | S3 | 3120h | 2496h | SEC1-NDS | Sec | Rel6 |  |  | Geir M. Køien, Telenor | Geir-myrdahl.koien@telenor.com | TSG |  |
| 73 | 14.1.3.1 | IP network layer security (NDS/IP) | 195d | 2002-06-17 A | 2003-03-14 | 80% | 39d |  |  |  | 227d | finish no earlier than 2003-03-14 | S3 | 1560h | 1248h | SEC1-NDS-IP |  | Rel6 |  |  |  |  | WG | TS 33.210 |
| 74 | 14.2 | **Rel-6 MAP application layer security** | 935d | 2000-02-21 A | 2003-09-19 | 38% | 578d | 2000-02-21 | 2002-12-06 | 730d | 92d |  | S3 | 12888h | 4920.87h | SEC1-MAPAL | Sec | Rel6 |  |  |  |  | TSG |  |
| 75 | 14.2.1 | Main aspects | 510d | 2000-02-21 A | 2002-06-07 | 50% | 255d | 2000-02-21 | 2002-06-07 | 510d | 427d | start no earlier than 2000-02-21 | S3 | 4080h | 2040h | SEC1-MAPAL | Sec |  |  | 1584 |  |  | WG |  |
| 76 | 14.2.2 | Security signalling flows for the Ze interface | 260d | 2002-09-23 A | 2003-09-19 | 15% | 221d | 2000-02-22 | 2002-12-06 | 729d | 92d | finish no earlier than 2002-12-06 | N4 | 2080h | 312h | SEC1-MAPAL | Sec |  |  | 2025 |  |  | TSG |  |
| 77 | 16 | **IMS Phase 2** | 1034d? | 2000-01-03 A | 2003-12-18 | 44% | 580.57d? | 2000-08-28 | 2003-03-28 | 675d | 28d |  | S1 | 116448h | 48625.9h | IMS2 |  | Rel6 |  |  |  |  |  |  |
| 78 | 16.1 | Stage 2 of IMS Phase 2 | 205d | 2002-09-02 A | 2003-06-13 | 46% | 110d |  |  |  | 162d | finish no earlier than 2003-06-13 | S2 | 1640h | 760h |  |  | Rel6 |  |  |  |  |  |  |
| 79 | 13.2 | Add the Stage 2 for each individual enhancement + EMERGENCY CALL | 1d? | 2000-01-03 | 2000-01-03 |  |  |  |  |  | 1061d |  | S2 | 8h |  |  |  |  |  |  |  |  |  |  |
| 80 | 16.2 | IMS Stage-3 Enhancements | 261d | 2002-09-20 A | 2003-09-19 | 2% | 255.78d |  |  |  | 92d | finish no earlier than 2003-09-19 | N1 | 2088h | 41.76h | IMS-CCR-E |  | Rel6 |  |  | Keith Drage, Lucent | drage@lucent.com |  |  |
| 81 | 13.4 | **Identity portability in IMS** | 885d? | 2000-01-03 | 2003-05-23 |  |  |  |  |  | 177d |  | N1 | 7776h |  |  |  |  |  |  |  |  |  |  |
| 82 | 13.4.1 | Stage 1 | 1d? | 2000-01-03 | 2000-01-03 |  |  |  |  |  | 1061d |  |  |  |  |  |  |  |  |  |  |  |  |  |
| 83 | 13.4.2 | Stage 2 | 87d? | 2003-01-23 | 2003-05-23 |  |  |  |  |  | 177d | finish no earlier than 2003-05-23 | S2 | 696h |  |  |  |  |  |  |  |  |  |  |
| 84 | 13.4.3 | Stage 3 | 1d? | 2000-01-03 | 2000-01-03 |  |  |  |  |  | 1061d |  |  |  |  |  |  |  |  |  |  |  |  |  |
| 85 | 13.5 | **IMS Local services** | 780d? | 2000-01-03 A | 2002-12-27 | 99% | 9.63d? |  |  |  | 282d |  | N1 | 6240h | 6162.96h |  |  |  |  |  |  |  |  |  |
| 86 | 13.5.1 | Stage 2 | 80d? | 2002-09-09 A | 2002-12-27 A | 100% |  |  |  |  |  | finish no earlier than 2002-12-27 |  |  |  |  |  |  |  |  |  |  |  |  |
| 87 | 13.5.2 | Stage 3 | 1d? | 2000-01-03 | 2000-01-03 |  |  |  |  |  | 1061d |  |  |  |  |  |  |  |  |  |  |  |  |  |

Notes:
- 65: 8/3/2001: test spec is based on R99 core spec, so deleted from Workplan
- 68: Added BB UE authentication and rapporteur added.
- 69: Added by P-000575 without any dates. 18/10/00: Change of WI title, added hyperlink rapporteur new end date 03/01. New end date and correct Release to be decided S3#18
- 70: New end date and correct Release to be decided S3#18
- 71: 15/11/2002 CN4: Waiting for input from SA3!
- 72: WID approved for Rel-6 at SA#17
- 73: Should be complete after SA3#27
- 74: TO DELETE: REPLACED BY NDS-MAP and NDS-IP. TO BE DELETED, but replacement NDS-MAP was missing
- 75: ??
- 76: 17 May Requirements under analysis in CN4. End date not yet determined. / 02/08/2002 CN4: CN4 is waiting WID in CN4#17. Revised version of N4-020624 / 15/11/2003 CN4: The first draft will be present in C4#18 target CN#21
- 77: Not yet available: verbally approved at SA15, actual WID to be provided at SA16 by Lucent

| ID | WBS | Task | Duration | Start | Finish | Complete | Remaining | Baseline start | Baseline finish | Baseline duration | Total slack | Constraint | Resources | Work | Actual work | Text1 | Text2 | Text3 | Text4 | Text5 | Text6 | Text7 | Text9 |
| --- | --- | --- | --- | --- | --- | --- | --- | --- | --- | --- | --- | --- | --- | --- | --- | --- | --- | --- | --- | --- | --- | --- | --- |
| 88 | 13.6 | **IMS Group management (e.g. chat)** | 885d? | 2000-01-03 A | 2003-05-23 | 25% | 665.38d? |  |  |  | 177d |  | N1 | 7080h | 1756.98h |  |  |  |  |  |  |  |  |
| 89 | 13.6.1 | Stage 2 | 135d? | 2002-11-18 A | 2003-05-23 | 25% | 101.25d? |  |  |  | 177d | finish no earlier than 2003-05-23 |  |  |  |  |  |  |  |  |  |  |  |
| 90 | 13.6.2 | Stage 3 | 1d? | 2000-01-03 | 2000-01-03 |  |  |  |  |  | 1061d |  |  |  |  |  |  |  |  |  |  |  |  |
| 91 | 13.7 | **IMS Conferencing** | 885d? | 2000-01-03 A | 2003-05-23 | 25% | 665.38d? |  |  |  | 177d |  | N1 | 7080h | 1756.98h |  |  |  |  |  |  |  |  |
| 92 | 13.7.1 | Stage 2 | 135d? | 2002-11-18 A | 2003-05-23 | 25% | 101.25d? |  |  |  | 177d | start no earlier than 2002-11-18 |  |  |  |  |  |  |  |  |  |  |  |
| 93 | 13.7.2 | Stage 3 | 1d? | 2000-01-03 | 2000-01-03 |  |  |  |  |  | 1061d |  |  |  |  |  |  |  |  |  |  |  |  |
| 94 | 13.8 | **PSS alignment to IMS** | 970d? | 2000-01-03 A | 2003-09-19 | 5% | 921.78d? |  |  |  | 92d |  | N1 | 7760h | 385.8h |  |  |  |  |  |  |  |  |
| 95 | 13.8.1 | Stage 2 | 175d? | 2002-01-14 A | 2003-09-19 | 5% | 166.25d? |  |  |  | 92d | finish no earlier than 2003-09-19 |  |  |  |  |  |  |  |  |  |  |  |
| 96 | 13.8.2 | Stage 3 | 1d? | 2000-01-03 | 2000-01-03 |  |  |  |  |  | 1061d |  |  |  |  |  |  |  |  |  |  |  |  |
| 97 | 13.9 | **IMS Messaging** | 885d? | 2000-01-03 A | 2003-05-23 | 60% | 357.3d? |  |  |  | 177d |  | N1 | 7080h | 4221.61h |  |  |  |  |  |  |  |  |
| 98 | 13.9.1 | Stage 2 | 160d? | 2002-10-14 A | 2003-05-23 | 60% | 64d? |  |  |  | 177d | finish no earlier than 2003-05-23 |  |  |  |  |  |  |  |  |  |  |  |
| 99 | 13.9.2 | Stage 3 | 1d? | 2000-01-03 | 2000-01-03 |  |  |  |  |  | 1061d |  |  |  |  |  |  |  |  |  |  |  |  |
| 100 | 13.10 | Additional SIP Capabilities support not covered by Rel-5 | 261d? | 2002-09-20 | 2003-09-19 |  |  |  |  |  | 92d | finish no earlier than 2003-09-19 | N1 | 2088h |  |  |  |  |  |  |  |  |  |
| 101 | 13.11 | Review additional SIP Capabilities against IMS | 261d? | 2002-09-20 | 2003-09-19 |  |  |  |  |  | 92d | finish no earlier than 2003-09-19 | N1 | 2088h |  |  |  |  |  |  |  |  |  |
| 102 | 16.5 | **Interworking between IMS and IP networks** | 675d | 2000-08-28 A | 2003-03-28 | 35% | 442.12d | 2000-08-28 | 2003-03-28 | 675d | 217d |  | N3 | 16200h | 5846h | IMS-CCR-IWIP | BaAS | 23.821, 29.061, 29.162 | Nigel Holland, BT | nigel.holland@bt.com | Rel6 | TSG | 2048 |
| 103 | 16.5.1 | Interworking for 3GPP_SIP and IETF_SIP | 675d | 2000-08-28 A | 2003-03-28 | 59% | 276.75d | 2000-08-28 | 2003-03-28 | 675d | 217d | finish no earlier than 2003-03-28 | N3 | 5400h | 3186h |  |  | New TR 2x.abc | Thomas Belling, Siemens |  |  |  |  |
| 104 | 16.5.2 | Interworking for IPv6 to IPv4 | 675d | 2000-08-28 A | 2003-03-28 | 10% | 607.5d | 2000-08-28 | 2003-03-28 | 675d | 217d | finish no earlier than 2003-03-28 | N3 | 5400h | 540h |  |  | 29.163 |  |  |  |  |  |
| 105 | 16.6 | **Interworking between IMS and CS networks** | 595d | 2000-08-28 A | 2002-12-06 | 60% | 238d | 2000-08-28 | 2002-12-06 | 595d | 297d |  | N3 | 11456h | 6873.6h | IMS-CCR-IWCS | CCaR | 29.163, 29.061, 24.228, and new CN4 specification | David Sanders, Vodafone | dave.sanders@vf.vodafone.co.uk | Rel6 | TSG | 1305 |
| 106 | 16.6.1 | ITU-T Q.1912.SIP (SIP to BICC / ISUP interworking) | 595d | 2000-08-28 A | 2002-12-06 | 60% | 238d | 2000-08-28 | 2002-12-06 | 595d | 297d | finish no earlier than 2002-12-06 | N3 | 4760h | 2856h |  |  |  |  |  |  |  |  |
| 107 | 16.6.2 | ITU-T dependency on Q.2150.3 (SCTP) | 595d | 2000-08-28 A | 2002-12-06 | 60% | 238d | 2000-08-28 | 2002-12-06 | 595d | 297d | finish no earlier than 2002-12-06 | N3 | 4760h | 2856h |  |  |  |  |  |  |  |  |
| 108 | 16.7 | **To be deleted (duplicated) IMS Local services** | 325d | 2001-01-01 A | 2002-03-29 A | 100% |  | 2001-01-01 | 2002-03-29 | 325d |  |  | S2 | 5200h | 5200h |  |  | 23.228 |  |  | Rel6 |  |  |
| 109 | 16.7.1 | Stage 2 | 325d | 2001-01-01 A | 2002-03-29 A | 100% |  | 2001-01-01 | 2002-03-29 | 325d |  | start no earlier than 2001-01-01 | S2 | 2600h | 2600h |  |  |  |  |  |  |  |  |
| 110 | 16.8 | **Mm interface (CSCF to external IP multimedia network)** | 389d | 2001-03-14 A | 2002-09-09 | 71% | 112.81d | 2001-03-14 | 2003-03-21 | 528d | 361d |  | N3 | 6224h | 2209.52h |  |  |  |  |  | Rel6 |  |  |
| 111 | 16.8.1 | CN1 part | 389d | 2001-03-14 A | 2002-09-09 | 71% | 112.81d | 2001-03-14 | 2002-06-07 | 323d | 361d | finish no earlier than 2002-09-09 | N1 | 3112h | 2209.52h |  |  |  |  |  |  |  |  |

Notes:
- 102: [DAB 14.02.02] - end date pushed back to March 2003
- 103: [DAB - 14.02.02] - Need for new TR underinvestigation by CN3
- 104: [DAB - 14.02.02] - Requirements still not clear from SA2
- 106: [DAB - 17.05.02] - estimated ITU delivery date pushed to Dec. 2002
- 107: [DAB - 17.05.02] - estimated ITU delivery date pushed to Dec. 2002

| ID | WBS | Task | Duration | Start | Finish | Complete | Remaining | Baseline start | Baseline finish | Baseline duration | Total slack | Constraint | Resources | Work | Actual work | Text6 | Text1 | Text4 | Text5 | Text7 | Text3 | Text2 | Text8 | Text9 |
| --- | --- | --- | --- | --- | --- | --- | --- | --- | --- | --- | --- | --- | --- | --- | --- | --- | --- | --- | --- | --- | --- | --- | --- | --- |
| 112 | 16.9 | **Mg interface (BGCF to MGCF - interworking with CS)** | 371d | 2001-04-09 A | 2002-09-09 A | 100% |  | 2001-04-09 | 2002-12-20 | 445d |  |  | N3 | 5936h | 5936h | Rel6 |  |  |  |  |  |  |  |  |
| 113 | 16.9.1 | Mg interface (BGCF to MGCF - interworking with CS) | 371d | 2001-04-09 A | 2002-09-09 A | 100% |  | 2001-04-09 | 2002-06-07 | 305d |  | finish no earlier than 2002-06-07 | N1 | 2968h | 2968h | Rel6 |  |  |  |  |  |  |  |  |
| 114 | 16.10 | Mn interface (IM-MGW to MGCF) enhancements | 200d | 2002-09-02 A | 2003-06-06 | 30% | 140d | 2002-06-03 | 2002-12-27 | 150d | 167d | finish no earlier than 2003-06-06 | N4 | 1600h | 480h | Rel6 | IMS-CCR-Mn | Peter Schmitt, Siemens |  |  |  |  |  |  |
| 115 | 13.18 | Mp (MRFC - MRFP) interface protocol definitions | 175d? | 2002-10-07 A | 2003-06-06 | 17% | 145.25d? |  |  |  | 167d | finish no earlier than 2003-06-06 | N4 | 1400h | 238h | Rel6 | IMS-CCR-Mp | David Sanders, Vodafone |  |  |  |  |  |  |
| 116 | 16.11 | **IMS Messaging** | 267d? | 2002-03-14 A | 2003-03-21 | 42% | 155.36d? | 2002-03-14 | 2003-03-17 | 263d | 222d |  | S1 | 9392h | 3131.41h | Rel6 | IMSM | Juha Kalliokulju (Nokia) | juha.kalliokulju@nokia.com | TSG |  |  |  |  |
| 117 | 16.11.1 | TR on support of messaging in the IMS | 193d | 2002-03-14 A | 2002-12-09 | 90% | 19.3d | 2002-03-14 | 2002-12-09 | 193d | 296d | finish no earlier than 2002-12-09 | S1 | 1544h | 1389.6h |  | IMSM-TR | Juha Kalliokulju (Nokia) | juha.kalliokulju@nokia.com | TSG |  |  |  |  |
| 118 | 13.19.2 | Stage 1 22.340 | 23d? | 2002-11-11 A | 2002-12-11 | 90% | 2.3d? |  |  |  | 294d | finish no earlier than 2002-12-11 | S1 | 184h | 165.6h |  | IMSM-TS | Juha Kalliokulju (Nokia) | juha.kalliokulju@nokia.com | TSG | 22.340 |  |  |  |
| 119 | 16.11.2 | **CRs to existing 22-series specifications** | 263d? | 2002-03-14 A | 2003-03-17 | 4% | 252.48d? | 2002-03-14 | 2003-03-17 | 263d | 226d |  | S1 | 4208h | 168.31h |  | IMSM-CR | Juha Kalliokulju (Nokia) | juha.kalliokulju@nokia.com | TSG |  |  |  |  |
| 120 | 13.19.3.1 | CRs to 22.140 & 22.228 | 263d? | 2002-03-14 A | 2003-03-17 | 4% | 252.48d? |  |  |  | 226d | finish no earlier than 2003-03-17 | S1 | 2104h | 84.16h |  | IMSM-CR | Juha Kalliokulju (Nokia) | juha.kalliokulju@nokia.com | TSG | 22.140,22.228 |  |  |  |
| 121 | 16.11.3 | To be deleted (duplicated) - Stage 2 | 165d | 2002-08-05 A | 2003-03-21 | 39% | 100.65d |  |  |  | 222d | finish no earlier than 2003-03-21 | S2 | 1320h | 514.8h |  |  |  |  |  |  |  |  |  |
| 122 | 16.12 | **IMS Group Management** | 193d | 2002-03-14 A | 2002-12-09 | 75% | 48.25d | 2002-03-14 | 2002-12-09 | 193d | 296d |  | S1 | 3088h | 2316h | Rel6 | IMSGM | Juha Kalliokulju (Nokia) | juha.kalliokulju@nokia.com | TSG |  |  |  |  |
| 123 | 16.12.1 | TS on IMS group management | 193d | 2002-03-14 A | 2002-12-09 | 75% | 48.25d | 2002-03-14 | 2002-12-09 | 193d | 296d | finish no earlier than 2002-12-09 | S1 | 1544h | 1158h |  |  | Juha Kalliokulju (Nokia) | juha.kalliokulju@nokia.com | TSG |  |  |  |  |
| 124 | 13.21 | Study of subscriber and operators relationship in IMS and related ISIM requirements for Rel 6” | 20d? | 2002-11-15 A | 2002-12-12 | 75% | 5d? |  |  |  | 293d | finish no earlier than 2002-12-12 | S1 | 160h | 120h | Rel6 |  | Juha Kalliokulju (Nokia) | juha.kalliokulju@nokia.com |  |  |  |  |  |
| 125 | 13.22 | Lawful Interception in the 3GPP Rel-6 architecture | 269d? | 2002-12-09 | 2003-12-18 |  |  |  |  |  | 28d | finish no earlier than 2003-12-18 | S3 | 2152h |  |  |  | Berthold Wilhelm |  |  |  |  |  |  |
| 126 | 16.4 | Radio optimisation impacts on PS domain architecture | 380d | 2001-12-10 A | 2003-05-23 | 66% | 130d | 2001-12-10 | 2002-06-14 | 135d | 177d | finish no earlier than 2003-05-23 | S2 | 3040h | 2000h | Rel6 |  |  |  | TSG |  |  |  |  |
| 127 | 16.3 | **Interoperability and Commonality between IMS using different "IP-connectivity Networks"** | 257d | 2002-09-16 A | 2003-09-09 | 20% | 204.61d |  |  |  | 100d |  | N1 | 5392h | 1099.09h | Rel6 | IMSCOOP | Keith Drage, Lucent | drage@lucent.com |  |  |  |  |  |
| 128 | 16.3.1 | Stage 2 | 180d | 2002-09-16 A | 2003-05-23 | 47% | 95d |  |  |  | 177d | finish no earlier than 2003-05-23 | S2 | 1440h | 680h |  |  |  |  |  |  |  |  |  |
| 129 | 16.3.2 | Stage 3 | 237d | 2002-10-14 | 2003-09-09 |  |  |  |  |  | 100d | finish no earlier than 2003-09-09 | N1 | 1896h |  |  |  |  |  |  |  |  |  |  |
| 130 | 17 | **Support of Push Services** | 623d? | 2001-01-03 A | 2003-05-23 | 41% | 365.77d? | 2001-01-03 | 2002-06-14 | 378d | 177d |  | S1 | 10734.6h | 2761.44h | Rel6 | PUSH | Yoshinori Kitada, NTT Comware |  | TSG |  | CCaR | Alain | 1365 |
| 131 | 17.1 | Stage 1 | 378d | 2001-01-03 A | 2002-06-14 | 31% | 260.82d | 2001-01-03 | 2002-06-14 | 378d | 422d | finish no earlier than 2002-06-14 | S1 | 3024h | 937.44h |  |  |  |  |  |  |  |  |  |
| 132 | 17.2 | TR on feasibility study | 178d | 2001-01-03 A | 2001-09-07 A | 100% |  | 2001-01-03 | 2001-09-07 | 178d |  | finish no earlier than 2001-09-07 | S2 | 1424h | 1424h |  |  |  |  |  |  |  |  |  |
| 133 | 16.3 | TR on Stage 2 | 140d? | 2002-11-11 A | 2003-05-23 | 36% | 90d? |  |  |  | 177d | start no earlier than 2002-11-11 | S2 | 1120h | 400h |  |  |  |  |  |  |  |  |  |
| 134 | 17.3 | Stage 2 | 140d | 2002-11-11 | 2003-05-23 |  |  |  |  |  | 177d | finish no earlier than 2003-05-23 | S2 | 1120h |  |  |  |  |  |  |  |  |  |  |
| 135 | 18 | **Multimedia Messaging (MMS) enhancements** | 217d? | 2002-08-15 A | 2003-06-13 | 11% | 193.64d? |  |  |  | 162d |  | T2 | 9360h | 1481.71h | Rel6 | MMS6 | Josef Laumen, Siemens | Josef.Laumen@SAL.SIEMENS.DE | TSG |  | Mes |  |  |
| 136 | 18.1 | **Definition of service requirements** | 151d? | 2002-11-15 A | 2003-06-13 | 50% | 75.5d? |  |  |  | 162d |  | S1 | 2416h | 1208h |  |  | Josef Laumen, Siemens | Josef.Laumen@SAL.SIEMENS.DE |  | 22.140 |  |  |  |
| 137 | 17.1.1 | Definition of service requirements charging | 151d? | 2002-11-15 A | 2003-06-13 | 50% | 75.5d? |  |  |  | 162d | finish no earlier than 2003-06-13 | S1 | 1208h | 604h |  |  | Josef Laumen, Siemens | Josef.Laumen@SAL.SIEMENS.DE |  | 22.140 |  |  |  |
| 138 | 18.2 | Technical realization | 217d | 2002-08-15 A | 2003-06-13 | 5% | 206.15d |  |  |  | 162d | finish no earlier than 2003-06-13 | T2 | 1736h | 86.8h |  |  | Josef Laumen, Siemens | Josef.Laumen@SAL.SIEMENS.DE |  | 23.140 |  |  |  |
| 139 | 18.3 | OMA dependencies | 217d | 2002-08-15 | 2003-06-13 |  |  |  |  |  | 162d | finish no earlier than 2003-06-13 | T2 | 1736h |  |  |  |  |  |  |  |  |  |  |
| 140 | 18.4 | MMS formats and codecs | 217d | 2002-08-15 | 2003-06-13 |  |  |  |  |  | 162d | finish no earlier than 2003-06-13 | S4 | 1736h |  |  |  |  |  |  | 26.140 |  |  |  |

Notes:
- 114: 17th May 2002, CN4; Will be handled in Rel-6 / 02/08/2002 CN4: WID approved at CN4#15 (N4-020997) / 01/09/2002 KK: WID approved at CN#17 (NP-020494) / 15/11/2002CN4: Target will be CN#20 (NP-020600)
- 115: 27/11/2002 KK: WID approved at CN#18 (NP-020601) / 27/11/2002CN4: Target will be CN#20
- 130: AS: Changed from FS to actual support of Push
- 132: Stage 2 on hold, waiting for requirements.

| ID | WBS | Task | Duration | Start | Finish | Complete | Remaining | Baseline start | Baseline finish | Baseline duration | Total slack | Constraint | Resources | Work | Actual work | Text1 | Text2 | Text6 | Text7 | Text3 | Text4 | Text5 | Text8 | Text9 |
| --- | --- | --- | --- | --- | --- | --- | --- | --- | --- | --- | --- | --- | --- | --- | --- | --- | --- | --- | --- | --- | --- | --- | --- | --- |
| 141 | 19 | **Rel-6 MExE enhancements** | 331d | 2002-03-08 A | 2003-06-13 | 95% | 16.68d | 2002-03-08 | 2003-07-07 | 347d | 162d |  | T2 | 7904h | 7505.79h | MEXE6 | Ter | Rel6 | TSG |  |  |  |  |  |
| 142 | 19.1 | MExE Rel-6 Improvements and Investigations | 331d | 2002-03-08 A | 2003-06-13 | 90% | 33.1d | 2002-03-08 | 2003-07-07 | 347d | 162d | finish no earlier than 2003-06-13 | T2 | 2648h | 2383.2h | MEXE6-ENHANC | Ter |  | TSG | 22.057, 23.057 | Lars Brenk (TTPCom) | lsb_ttpcom@HOTMAIL.COM |  |  |
| 143 | 19.2 | MExE Run-Time Independent Framework Feasibility Study | 326d | 2002-03-08 A | 2003-06-06 A | 100% |  | 2002-03-08 | 2003-06-06 | 326d |  | finish no earlier than 2003-06-06 | T2 | 2608h | 2608h | MEXE6-RTIF | Ter |  | TSG | 22.857 | Aaron Cohen (Intel) | Aaron.Cohen@intel.com |  |  |
| 144 | 21 | Subscription Management | 715d | 2000-12-29 A | 2003-09-25 | 30% | 500.5d | 2000-12-29 | 2002-12-20 | 516d | 88d | finish no earlier than 2003-09-25 | S5 | 5720h | 1716h | SM |  | Rel6 | TSG | 32.140, 32.141 | Michael Eder (Nokia) | michael.eder@nokia.com | Adrian |  |
| 145 | 22 | **Support of Presence Capability** | 578d | 2001-03-19 A | 2003-06-04 | 55% | 262.81d | 2001-03-19 | 2002-12-12 | 454d | 169d |  | S1 | 11792h | 6430.32h | PRESNC |  | Rel6 | TSG |  | Mark Cataldo, Motorola |  | Micheal C | 11004 |
| 146 | 22.1 | Stage 1 | 88d | 2001-03-19 A | 2001-07-18 | 95% | 4.4d | 2001-03-19 | 2001-07-18 | 88d | 659d | finish no earlier than 2001-07-18 | S1 | 704h | 668.8h |  |  |  |  |  |  |  |  | 11005 |
| 147 | 22.2 | Stage 2 | 268d | 2001-09-12 A | 2002-09-20 A | 100% |  | 2001-09-12 | 2002-09-20 | 268d |  | finish no earlier than 2002-09-20 | S2 | 2144h | 2144h |  |  |  | TSG |  |  |  |  |  |
| 148 | 22.3 | Stage 3 | 303d | 2002-04-08 A | 2003-06-04 | 40% | 181.8d | 2002-04-08 | 2002-09-20 | 120d | 169d | finish no earlier than 2003-06-04 | N1 | 2424h | 969.6h |  |  |  |  |  | Keith Drage, Lucent | drage@lucent.com |  |  |
| 149 | 22.4 | Security issues | 79d | 2002-08-26 A | 2002-12-12 | 20% | 63.2d | 2002-08-26 | 2002-12-12 | 79d | 293d | finish no earlier than 2002-12-12 | S3 | 632h | 126.4h |  |  |  |  |  |  |  |  |  |
| 150 | 22.5 | USIM issues | 79d | 2002-03-04 | 2002-06-20 |  |  | 2002-03-04 | 2002-06-20 | 79d | 418d | start no earlier than 2002-03-04 | T3 | 632h |  |  |  |  |  |  |  |  |  |  |
| 151 | 22.6 | UE issues | 79d | 2002-03-04 | 2002-06-20 |  |  | 2002-03-04 | 2002-06-20 | 79d | 418d | start no earlier than 2002-03-04 | T2 | 632h |  |  |  |  |  |  |  |  |  |  |
| 152 | 23 | Presence Service Enhancements | 263d | 2002-03-14 | 2003-03-17 |  |  | 2002-03-14 | 2003-03-17 | 263d | 226d | finish no earlier than 2003-03-17 | S1 | 2104h |  | PRES1 |  | Rel6 | TSG | 22.141 | Mark Cataldo (Openwave Systems) | mark.cataldo@openwave.com |  |  |
| 153 | 24 | **To be ordered (to be put under Emergency call for IMS) - Emergency calls without UICC/SIM in netw. with IMS** | 292d | 2002-07-29 A | 2003-09-09 | 17% | 241.89d | 2002-03-18 | 2003-03-14 | 260d | 100d |  | S2 | 5096h | 874.6h |  |  | Rel6 |  |  |  |  | Alain |  |
| 154 | 24.1 | Stage 2 | 145d | 2002-10-07 A | 2003-04-25 | 52% | 70d | 2002-03-18 | 2002-06-28 | 75d | 197d | finish no earlier than 2003-04-25 | S2 | 1160h | 600h |  |  |  |  |  |  |  |  |  |
| 155 | 24.2 | Stage 3 work for CN1 | 292d | 2002-07-29 | 2003-09-09 |  |  | 2002-07-29 | 2003-03-14 | 165d | 100d | finish no earlier than 2003-09-09 | N1 | 2336h |  | EMC-NOSIM |  |  |  |  |  |  |  |  |
| 156 | 25 | **Enhanced A/Gb feasibility study** | 51d? | 2002-08-30 A | 2002-11-08 | 56% | 22.31d? | 2002-04-19 | 2002-06-28 | 51d | 317d |  | GP | 4080h | 2473.5h | AGbEnFS |  | TBD | TSG |  | J-L Carrizo, Vodafone | jose-luis.carrizo@vodafone.co.uk |  |  |
| 157 | 25.1 | **Feasibility study on A/Gb enhancements** | 51d? | 2002-08-30 A | 2002-11-08 | 56% | 22.31d? | 2002-04-19 | 2002-06-28 | 51d | 317d |  | G2 | 3672h | 2244h | AGbEnFS-FS |  |  | TSG |  |  |  |  |  |
| 158 | 25.1.1 | Requirements for the support of conversational services | 51d | 2002-08-30 A | 2002-11-08 | 75% | 12.75d |  |  |  | 317d | finish no earlier than 2002-11-08 | GP | 408h | 306h |  |  |  |  |  |  |  |  |  |
| 159 | 23.1.2 | Identification of the different building blocks for the provision of conversational services on the existing A/Gb protocol stack | 51d? | 2002-08-30 A | 2002-11-08 | 75% | 12.75d? |  |  |  | 317d | finish no earlier than 2002-11-08 | GP | 408h | 306h |  |  |  |  |  |  |  |  |  |
| 160 | 23.1.3 | Outline of impact and feasibility of these building blocks and their different solutions | 51d? | 2002-08-30 A | 2002-11-08 | 75% | 12.75d? |  |  |  | 317d | finish no earlier than 2002-11-08 | GP | 408h | 306h |  |  |  |  |  |  |  |  |  |
| 161 | 25.1.2 | Identification of the different building blocks for the provision of conversational services on the existing A/Gb protocol stack | 51d | 2002-08-30 | 2002-11-08 |  |  |  |  |  | 317d | finish no earlier than 2002-11-08 | G2 | 408h |  |  |  |  |  |  |  |  |  |  |
| 162 | 25.1.3 | Outline of impact and feasibility of these building blocks and their different solutions | 51d | 2002-08-30 | 2002-11-08 |  |  |  |  |  | 317d | finish no earlier than 2002-11-08 | G2 | 408h |  |  |  |  |  |  |  |  |  |  |
| 163 | 25.1.4 | Impact on 3GPP architecture and requirement to co-ordinatge with other TSGs (CN, SA) | 51d | 2002-08-30 A | 2002-11-08 | 75% | 12.75d |  |  |  | 317d | finish no earlier than 2002-11-08 | GP | 408h | 306h |  |  |  |  |  |  |  |  |  |
| 164 | 25.1.5 | Standardisation effort | 51d | 2002-08-30 A | 2002-11-08 | 75% | 12.75d |  |  |  | 317d | finish no earlier than 2002-11-08 | GP | 408h | 306h |  |  |  |  |  |  |  |  |  |
| 165 | 25.1.6 | Dependency to other features | 51d | 2002-08-30 A | 2002-11-08 | 75% | 12.75d |  |  |  | 317d | finish no earlier than 2002-11-08 | GP | 408h | 306h |  |  |  |  |  |  |  |  |  |

Notes:
- 149: LSs handled in SA3. WID approved SA#17 Contribution at S3#25 & following e-mail discussion.
- 152: SA1 to clarify why Presence and Presence enhancements are both be in same release
- 153: Per 30/5: This WID was approved in SA#11 as a feature. SA2 work on 23.221, 23.060 and 23.228 is targeted for TSG#13. The stage 3 work (mostly CN1?) is targeted for TSG#15 (March 2002)

| ID | WBS | Task | Duration | Start | Finish | Complete | Remaining | Baseline start | Baseline finish | Baseline duration | Total slack | Constraint | Resources | Work | Actual work | Text1 | Text4 | Text5 | Text6 | Text3 | Text8 | Text9 | Text7 |
| --- | --- | --- | --- | --- | --- | --- | --- | --- | --- | --- | --- | --- | --- | --- | --- | --- | --- | --- | --- | --- | --- | --- | --- |
| 166 | 26 | **Flexible Layer One for GERAN** | 910d | 2000-01-03 A | 2003-06-27 | 3% | 884.81d | 2000-01-03 | 2002-06-28 | 650d | 152d |  | GP | 48240h | 1204.03h | FLOGER | Benoist Sébire | benoist.sebire@nokia.com | TBD |  |  |  |  |
| 167 | 26.1 | **Realisation of a Flexible Layer One** | 805d | 2000-01-03 A | 2003-01-31 | 3% | 780.62d | 2000-01-03 | 2002-06-28 | 650d | 257d |  | GP | 22768h | 689.4h | FLOGER-Real | Benoist Sébire | benoist.sebire@nokia.com |  |  |  |  |  |
| 168 | 26.1.1 | Technical Report | 206d | 2002-04-19 A | 2003-01-31 | 30% | 144.2d | 2002-04-19 | 2002-06-28 | 51d | 257d | finish no earlier than 2003-01-31 | GP | 1648h | 494.4h |  |  |  |  |  |  |  |  |
| 169 | 26.1.2 | Architecture in 45.001 and 43.051 | 206d | 2002-04-19 | 2003-01-31 |  |  | 2002-04-19 | 2002-06-28 | 51d | 257d | finish no earlier than 2003-01-31 | G1 | 1648h |  |  |  |  |  |  |  |  |  |
| 170 | 26.1.3 | Multiplexing in 45.002 | 206d | 2002-04-19 | 2003-01-31 |  |  | 2002-04-19 | 2002-06-28 | 51d | 257d | finish no earlier than 2003-01-31 | G1 | 1648h |  |  |  |  |  |  |  |  |  |
| 171 | 26.1.4 | Channel Coding in 45.003 | 206d | 2002-04-19 | 2003-01-31 |  |  | 2002-04-19 | 2002-06-28 | 51d | 257d | finish no earlier than 2003-01-31 | G1 | 1648h |  |  |  |  |  |  |  |  |  |
| 172 | 26.1.5 | Performance Requirements in 45.005 | 805d | 2000-01-03 | 2003-01-31 |  |  | 2000-01-03 | 2002-06-28 | 650d | 257d | finish no earlier than 2003-01-31 | G1 | 6440h |  |  |  |  |  |  |  |  |  |
| 173 | 26.1.6 | Radio subsystem link control in 45.008 | 206d | 2002-04-19 | 2003-01-31 |  |  | 2002-04-19 | 2002-06-28 | 51d | 257d | finish no earlier than 2003-01-31 | G1 | 1648h |  |  |  |  |  |  |  |  |  |
| 174 | 26.1.7 | Requirements in 44.004 | 206d | 2002-04-19 | 2003-01-31 |  |  | 2002-04-19 | 2002-06-28 | 51d | 257d | finish no earlier than 2003-01-31 | G2 | 1648h |  |  |  |  |  |  |  |  |  |
| 175 | 26.2 | **Signalling and protocol support for a Flexible Layer One** | 206d | 2002-04-19 A | 2003-01-31 | 5% | 195.7d | 2002-04-19 | 2002-06-28 | 51d | 257d |  | G2 | 4944h | 247.2h | FLOGER-SigPro | Benoist Sébire | benoist.sebire@nokia.com |  |  |  |  |  |
| 176 | 26.2.1 | Modifications to RLC/MAC in 44.060 and 44.160 | 206d | 2002-04-19 A | 2003-01-31 | 10% | 185.4d | 2002-04-19 | 2002-06-28 | 51d | 257d | finish no earlier than 2003-01-31 | G2 | 1648h | 164.8h |  |  |  |  |  |  |  |  |
| 177 | 26.2.2 | Modifications to RRC in 44.118 and 44.018 | 206d | 2002-04-19 | 2003-01-31 |  |  | 2002-04-19 | 2002-06-28 | 51d | 257d | finish no earlier than 2003-01-31 | G2 | 1648h |  |  |  |  |  |  |  |  |  |
| 178 | 26.3 | **Security for a Flexible Layer One** | 206d | 2002-04-19 A | 2003-01-31 | 2% | 201.88d | 2002-04-19 | 2002-06-28 | 51d | 257d |  | G2 | 3296h | 65.91h | FLOGER-SecFLO | Benoist Sébire | benoist.sebire@nokia.com |  |  |  |  |  |
| 179 | 26.3.1 | Ciphering in 44.160,44.118, 44.060 and 44.018 | 206d | 2002-04-19 A | 2003-01-31 | 2% | 201.88d | 2002-04-19 | 2002-06-28 | 51d | 257d | finish no earlier than 2003-01-31 | G2 | 1648h | 32.96h |  |  |  |  |  |  |  |  |
| 180 | 26.4 | **GERAN MS Conformance test for the Flexible Layer One** | 155.5d | 2002-11-22 | 2003-06-27 |  |  | 2002-04-19 | 2002-06-28 | 51d | 152d |  | G4; G5 | 4976h |  | FLOGER-Msconf | Benoist Sébire | benoist.sebire@nokia.com |  |  |  |  |  |
| 181 | 26.4.1 | MS Test in 51.010 | 155.5d | 2002-11-22 | 2003-06-27 |  |  | 2002-04-19 | 2002-06-28 | 51d | 152d | finish no earlier than 2003-06-27 | G4; G5 | 2488h |  |  |  |  |  |  |  |  |  |
| 182 | 26.5 | **GERAN BTS Conformance test for the Flexible Layer One** | 311d | 2002-04-19 | 2003-06-27 |  |  | 2002-04-19 | 2002-06-28 | 51d | 152d |  | G3 | 4976h |  | FLOGER-BTSconf | Benoist Sébire | benoist.sebire@nokia.com |  |  |  |  |  |
| 183 | 26.5.1 | BTS Test in 51.021 | 311d | 2002-04-19 | 2003-06-27 |  |  |  |  |  | 152d | finish no earlier than 2003-06-27 | G3 | 2488h |  |  |  |  |  |  |  |  |  |
| 184 | 27 | Uplink TDOA feasibility study | 151d | 2001-11-30 A | 2002-06-28 A | 100% |  | 2001-11-30 | 2002-06-28 | 151d |  | finish no earlier than 2002-06-28 | GP | 1208h | 1208h | TDOAF | Bob Gross, TruePosition, Inc. | rlgross@trueposition.com | Rel6 | 45.811 | Paolo |  |  |
| 185 | 28 | **Multimedia Broadcast and Multicast Service** | 608d | 2001-05-11 A | 2003-09-09 | 16% | 513.68d | 2001-05-11 | 2003-09-30 | 623d | 100d |  | S1 | 41337.6h | 6206h | MBMS |  |  | Rel6 |  | Michael C. |  |  |
| 186 | 28.1 | Stage 1 | 232d | 2001-05-11 A | 2002-04-01 | 85% | 34.8d | 2001-05-11 | 2002-04-01 | 232d | 476d | finish no earlier than 2002-04-01 | S1 | 1856h | 1577.6h |  |  |  |  | 22.101 | Micheal C | 11003 |  |
| 187 | 28.2 | **Stage 2** | 445d | 2001-09-24 A | 2003-06-06 | 77% | 103.83d | 2001-08-31 | 2002-09-20 | 276d | 167d |  | S2 | 7160h | 4084.8h |  |  |  |  |  |  |  | TSG |
| 188 | 28.2.1 | TR on Architectural Study | 240d | 2001-09-24 A | 2002-08-23 A | 100% |  |  |  |  |  | finish no earlier than 2002-08-23 | S2 | 1920h | 1920h |  |  |  |  |  |  |  |  |
| 189 | 28.2.2 | Stage 2 Specification Work | 210d | 2002-08-19 A | 2003-06-06 | 50% | 105d |  |  |  | 167d | finish no earlier than 2003-06-06 | S2 | 1680h | 840h |  |  |  |  |  |  |  |  |
| 190 | 28.3 | Introduction of MBMS in RAN | 379d | 2002-01-01 A | 2003-06-13 | 7% | 352.47d | 2002-01-01 | 2003-09-30 | 456d | 162d | finish no earlier than 2003-06-13 | R2 | 3032h | 212.24h |  | Dimitris Koulakiotis, Nokia |  |  |  |  | 2481 | TSG |
| 191 | 28.4 | Support of the MBMS in CN protocols | 321d | 2002-06-18 A | 2003-09-09 | 2% | 314.58d |  |  |  | 100d | finish no earlier than 2003-09-09 | N1 | 2568h | 51.36h |  |  |  |  |  |  |  | TSG |
| 192 | 28.5 | Security Aspects of Multimedia Broadcast/Multicast Service (MBMS) | 175d | 2002-07-01 A | 2003-02-28 | 20% | 140d |  |  |  | 237d | finish no earlier than 2003-02-28 | S3 | 1400h | 280h | MBMS | Escott, Adrian, Hutchison 3G UK | adrian.escott@hutchison3g.com |  |  |  |  | TSG |

Notes:
- 166: Nokia, Ericsson, Siemens, Telia
- 185: Title renamed at SA#13
- 186: This may or may not be a separate stage 1. In the meantime, CRs are proposed for 22.101
- 192: WID approved SA#17

| ID | WBS | Task | Duration | Start | Finish | Complete | Remaining | Baseline start | Baseline finish | Baseline duration | Total slack | Constraint | Resources | Work | Actual work | Text1 | Text6 | Text7 | Text8 | Text3 | Text4 | Text5 |
| --- | --- | --- | --- | --- | --- | --- | --- | --- | --- | --- | --- | --- | --- | --- | --- | --- | --- | --- | --- | --- | --- | --- |
| 193 | 28.6 | **Support of MBMS in GERAN** | 216d | 2002-08-30 | 2003-06-27 |  |  |  |  |  | 152d |  | GP | 20736h |  | MBMS-GERAN | Rel6 | TSG |  |  |  |  |
| 194 | 28.6.1 | Impact on the logical and physical channels | 216d | 2002-08-30 | 2003-06-27 |  |  |  |  |  | 152d | finish no earlier than 2003-06-27 | GP | 1728h |  |  |  |  |  |  |  |  |
| 195 | 28.6.2 | Simultaneous support of MBMS services | 216d | 2002-08-30 | 2003-06-27 |  |  |  |  |  | 152d | finish no earlier than 2003-06-27 | G1 | 1728h |  |  |  |  |  |  |  |  |
| 196 | 28.6.3 | Simultaneous support of MBMS and non-MBMS services | 216d | 2002-08-30 | 2003-06-27 |  |  |  |  |  | 152d | finish no earlier than 2003-06-27 | G1 | 1728h |  |  |  |  |  |  |  |  |
| 197 | 28.6.4 | Re-synchronisation at cell change | 216d | 2002-08-30 | 2003-06-27 |  |  |  |  |  | 152d | finish no earlier than 2003-06-27 | G2 | 1728h |  |  |  |  |  |  |  |  |
| 198 | 28.6.5 | Decision making process between point-to-point or pont-to-multipoint configurations | 216d | 2002-08-30 | 2003-06-27 |  |  |  |  |  | 152d | finish no earlier than 2003-06-27 | GP | 1728h |  |  |  |  |  |  |  |  |
| 199 | 28.6.6 | MBMS channel allocations procedures to multiple MSs | 216d | 2002-08-30 | 2003-06-27 |  |  |  |  |  | 152d | finish no earlier than 2003-06-27 | GP | 1728h |  |  |  |  |  |  |  |  |
| 200 | 28.6.7 | Changes to the Gb interface | 216d | 2002-08-30 | 2003-06-27 |  |  |  |  |  | 152d | finish no earlier than 2003-06-27 | GP | 1728h |  |  |  |  |  |  |  |  |
| 201 | 28.6.8 | GERAN specific changes to the Iu-ps interface | 216d | 2002-08-30 | 2003-06-27 |  |  |  |  |  | 152d | finish no earlier than 2003-06-27 | GP | 1728h |  |  |  |  |  |  |  |  |
| 202 | 28.6.9 | Interaction between MBMS and Iu-flex | 216d | 2002-08-30 | 2003-06-27 |  |  |  |  |  | 152d | finish no earlier than 2003-06-27 | GP | 1728h |  |  |  |  |  |  |  |  |
| 203 | 28.6.10 | Security aspects | 216d | 2002-08-30 | 2003-06-27 |  |  |  |  |  | 152d | finish no earlier than 2003-06-27 | GP | 1728h |  |  |  |  |  |  |  |  |
| 204 | 28.6.11 | MS conformance tests | 216d | 2002-08-30 | 2003-06-27 |  |  |  |  |  | 152d | finish no earlier than 2003-06-27 | G5 | 1728h |  |  |  |  |  |  |  |  |
| 205 | 29 | **Speech Recognition and Speech Enabled Services** | 497d? | 2001-10-08 A | 2003-09-02 | 15% | 423.72d? | 2001-10-08 | 2003-03-14 | 375d | 105d |  | S1 | 8968h | 1322.2h | SRSES | Rel6 | TSG | Michael C |  |  |  |
| 206 | 29.1 | Speech Enabled Services Based on Distributed Speech Recognition (DSR) | 115d | 2001-10-08 A | 2002-03-15 | 80% | 23d | 2001-10-08 | 2002-03-15 | 115d | 487d | finish no earlier than 2002-03-15 | S1 | 920h | 736h | DSR |  | TSG |  | 22.941, 23.207 | D Williams, QUALCOMM, Inc. | Dwilliams@qualcomm.com |
| 207 | 29.2 | Stage 2 of DSR (To be renamed in Stage 2 of Speech enabled services) | 152d | 2003-02-03 | 2003-09-02 |  |  | 2002-04-22 | 2002-11-19 | 152d | 105d | start no earlier than 2003-02-03 | S2 | 1216h |  |  |  |  |  |  |  |  |
| 208 | 29.3 | SDP protocols extension to include DSR | 183d | 2002-09-23 | 2003-06-04 |  |  | 2002-09-23 | 2003-03-14 | 125d | 169d | finish no earlier than 2003-06-04 | N1 | 1464h |  |  |  |  |  |  |  |  |
| 209 | 27.4 | Codec Work to Support Speech Recognition Framework for Automated Voice Services | 174d? | 2002-10-15 | 2003-06-13 |  |  |  |  |  | 162d | finish no earlier than 2003-06-13 | S4 | 1392h |  | SRSES-Codec |  | WG |  |  | David Pearce, Motorola |  |
| 210 | 30 | **Generic User Profile** | 437d | 2001-10-08 A | 2003-06-10 | 35% | 282.83d | 2001-10-08 | 2003-06-10 | 437d | 165d |  | S1 | 18143.8h | 6400.95h | GUP | Rel6 | TSG | Michael C |  |  |  |
| 211 | 30.1 | Stage 1 - Requirements | 306d | 2001-10-08 A | 2002-12-09 | 65% | 107.1d | 2001-10-08 | 2002-12-09 | 306d | 296d | finish no earlier than 2002-12-09 | S1 | 2448h | 1591.2h |  |  |  |  | 22.240 | Paul Amery (Orange) | paul.amery@orange.co.uk |
| 212 | 30.2 | Stage 2 - Data description framework | 372d | 2001-10-08 A | 2003-03-11 | 40% | 223.2d | 2001-10-08 | 2003-03-11 | 372d | 230d | finish no earlier than 2003-03-11 | T2 | 2976h | 1190.4h |  |  | WG |  | 23.241 |  |  |
| 213 | 30.3 | Stage 2 - Architecture | 355d | 2002-01-28 A | 2003-06-06 | 72% | 100d | 2002-01-28 | 2003-01-03 | 245d | 167d | finish no earlier than 2003-06-06 | S2 | 2840h | 2040h |  |  |  |  | 23.240 | Nacho Uzquiano (Telefonica) | uzquiano_ji@tsm.es |
| 214 | 30.4 | Stage 3 - Common objects | 437d | 2001-10-08 A | 2003-06-10 | 5% | 415.15d | 2001-10-08 | 2003-06-10 | 437d | 165d | finish no earlier than 2003-06-10 | T2 | 3496h | 174.8h |  |  | WG |  | 24.241 |  |  |
| 215 | 30.5 | Stage 3 - Network | 146.98d | 2002-11-18 | 2003-06-10 |  |  | 2002-05-06 | 2002-12-30 | 170d | 165d | finish no earlier than 2003-06-10 | N4 | 1175.84h |  |  |  |  |  | 29.240 |  |  |
| 216 | 30.6 | Security Aspects | 214d | 2002-07-16 A | 2003-05-09 | 10% | 192.6d |  |  |  | 187d | finish no earlier than 2003-05-09 | S3 | 1712h | 171.2h |  |  | WG |  | 33.102, 33.203, 33.210 | Owen, Bradley | bvowen@lucent.com |

Notes:
- 215: 17 May no activity in CN4 / 02/08/2002 CN4: No activity in CN4
- 216: WID approved SA#17. SA WG3 progress slow, depends on progress in other groups.

| ID | WBS | Task | Duration | Start | Finish | Complete | Remaining | Baseline start | Baseline finish | Baseline duration | Total slack | Constraint | Resources | Work | Actual work | Text1 | Text6 | Text7 | Text8 | Text4 | Text5 | Text3 |
| --- | --- | --- | --- | --- | --- | --- | --- | --- | --- | --- | --- | --- | --- | --- | --- | --- | --- | --- | --- | --- | --- | --- |
| 217 | 31 | **Digital Rights Management** | 380d? | 2001-10-08 A | 2003-03-21 | 30% | 267.7d? | 2001-10-08 | 2003-03-03 | 366d | 222d |  | S1 | 8688h | 2567.64h | DRM | Rel6 | TSG | Michael C |  |  |  |
| 218 | 31.1 | Requirements | 179d | 2001-10-08 A | 2002-06-13 | 75% | 44.75d | 2001-10-08 | 2002-06-13 | 179d | 423d | finish no earlier than 2002-06-13 | S1 | 1432h | 1074h |  |  |  |  | Nicholas Wood, Openwave Systems | nicholas.wood@openwave.com |  |
| 219 | 29.2 | Monitoring of Stages 2 and 3 progress (actual work to be done by OMA) | 155d? | 2002-08-19 | 2003-03-21 |  |  |  |  |  | 222d | start no earlier than 2002-08-19 | S1 | 1240h |  |  |  |  |  |  |  |  |
| 220 | 31.3 | Security | 186d | 2002-06-17 A | 2003-03-03 | 40% | 111.6d | 2002-06-17 | 2003-03-03 | 186d | 236d | finish no earlier than 2003-03-03 | S3 | 1488h | 595.2h |  |  |  |  |  |  |  |
| 221 | 31.4 | Codec Aspects | 186d | 2002-06-17 | 2003-03-03 |  |  | 2002-06-17 | 2003-03-03 | 186d | 236d | finish no earlier than 2003-03-03 | S4 | 1488h |  |  |  |  |  |  |  |  |
| 222 | 32 | **FS on WLAN-UMTS Interworking** | 840d? | 2000-01-03 A | 2003-03-21 | 41% | 498.88d? | 2000-01-03 | 2002-12-25 | 778d | 222d |  | S1 | 19656h | 8937.75h | WLAN | Rel6 | TSG | Michael C | Fredric Paint, Telenor | frederic.paint@telenor.com |  |
| 223 | 32.1 | **Technical Report** | 616d? | 2000-01-03 A | 2002-05-13 | 25% | 462d? | 2000-01-03 | 2002-05-13 | 616d | 446d |  | S1 | 9856h | 4188.8h | WLAN-TR |  |  |  | Fredric Paint, Telenor | frederic.paint@telenor.com | 22.934, 22.101, 22.105 |
| 224 | 30.1.1 | CRs to implement WLAN | 616d? | 2000-01-03 A | 2002-05-13 | 25% | 462d? |  |  |  | 446d | finish no earlier than 2002-05-13 | S1 | 4928h | 1232h | WLAN-CR |  |  |  | Fredric Paint, Telenor | frederic.paint@telenor.com | 22.934, 22.101, 22.105 |
| 225 | 32.2 | WLAN Interworking – Architecture Definition | 260d | 2002-03-25 A | 2003-03-21 | 83% | 45d | 2002-03-25 | 2002-12-25 | 198d | 222d | finish no earlier than 2003-03-21 | S2 | 2080h | 1720h |  |  | TSG |  |  |  |  |
| 226 | 32.3 | Security | 125d | 2002-09-30 A | 2003-03-21 | 30% | 87.5d |  |  |  | 222d | finish no earlier than 2003-03-21 | S3 | 1000h | 300h |  |  | TSG |  | Lopez-Soria, Luis, Ericsson | luis.lopez-soria@ece.ericsson.se | 21.133, 33.106, 33.107, 33.108, 33.200, 33.203, 33.210 |
| 227 | 33 | **Priority Service** | 208d | 2002-05-30 A | 2003-03-17 | 80% | 41.45d | 2002-05-30 | 2002-06-14 | 12d | 226d |  | S1 | 3248h | 2600.73h | PRIOR | Rel6 |  |  |  |  |  |
| 228 | 33.1 | Feasibility Study | 1d | 2002-06-14 A | 2002-06-14 | 95% | 0.05d | 2002-06-14 | 2002-06-14 | 1d | 422d | finish no earlier than 2002-06-14 | S1 | 8h | 7.6h | PRIOR-FS |  |  | Michael C | Biplab K. Pramanik, Telcordia Technologies | bpramani@telcordia.com | 22.950 |
| 229 | 33.2 | Stage 1 - Requirements | 208d | 2002-05-30 A | 2003-03-17 | 80% | 41.6d | 2002-05-30 | 2002-05-30 | 1d | 226d | finish no earlier than 2003-03-17 | S1 | 1664h | 1331.2h | PRIOR-SR |  |  | Michael C | James J. Garrahan, Telcordia Technologies | bpramani@telcordia.com |  |
| 230 | 34 | **Network Sharing** | 153d | 2001-11-14 A | 2002-06-14 | 75% | 38.25d | 2001-11-14 | 2002-06-14 | 153d | 422d |  | S1 | 2432h | 1824h | NTShar | Rel6 |  | Michael C |  |  |  |
| 231 | 34.1 | Technical Report | 153d | 2001-11-14 A | 2002-06-14 | 75% | 38.25d | 2001-11-14 | 2002-06-14 | 153d | 422d | start no earlier than 2001-11-14 | S1 | 1224h | 918h | NTShar-TR |  |  | Michael C |  |  | 22.951 |
| 232 | 35 | **QoS Improvements** | 245d? | 2002-07-15 A | 2003-06-20 | 56% | 107.19d? | 2002-04-22 | 2002-08-19 | 86d | 157d |  | S2 | 5800h | 3262.5h | QoS1 | NA | TSG |  |  |  |  |
| 233 | 35.1 | FS on Dynamic Policy control enhancements for end-to-end QoS | 245d | 2002-07-15 A | 2003-06-20 | 57% | 105d | 2002-04-22 | 2002-08-19 | 86d | 157d | finish no earlier than 2003-06-20 | S2 | 1960h | 1120h | QoS1 | Rel6 | TSG |  |  |  |  |
| 234 | 33.2 | Policy based control of Diffserv Edge Functions | 235d? | 2002-07-15 A | 2003-06-06 | 55% | 105d? |  |  |  | 167d | start no earlier than 2002-07-15 | S2 | 1880h | 1040h |  | Rel6 |  |  |  |  |  |
| 235 | 36 | **Support for subscriber certificates** | 189d | 2002-02-25 A | 2002-11-14 | 49% | 97.2d | 2002-02-25 | 2002-09-12 | 144d | 313d |  | S3 | 2856h | 1387.2h | SEC1-SC | Rel6 | TSG | Maurice | Valtteri Niemi, Nokia | valtteri.niemi@nokia.com | 33.102 |
| 236 | 36.1 | Stage 1 | 144d | 2002-02-25 A | 2002-09-12 | 40% | 86.4d |  |  |  | 358d | finish no earlier than 2002-09-12 | S3 | 1152h | 460.8h |  |  |  |  |  |  |  |
| 237 | 36.2 | Architecture review (name changed from "Stage2") | 24d | 2002-10-14 A | 2002-11-14 A | 100% |  |  |  |  |  | finish no earlier than 2002-11-14 | S2 | 192h | 192h |  |  |  |  |  |  |  |
| 238 | 37 | **OSA enhancements - To be merged with next one** | 145d | 2001-06-01 A | 2001-12-20 | 93% | 9.67d | 2000-07-11 | 2002-12-13 | 634d | 548d |  | S1 | 5800h | 5490.67h | OSA1 | NA | TSG | Adrian Z | Jörg Swetina, SIEMENS AG |  | 22.127, 23.127, 29.198-x, 29.998-x |
| 239 | 37.1 | **Interaction with other features** | 145d | 2001-06-01 A | 2001-12-20 | 93% | 9.67d | 2001-06-01 | 2001-12-20 | 145d | 548d |  | S1 | 4640h | 4330.67h |  | NA | TSG |  |  |  |  |
| 240 | 37.1.1 | Access to Presence information | 145d | 2001-06-01 A | 2001-12-20 A | 100% |  | 2001-06-01 | 2001-12-20 | 145d |  | finish no earlier than 2001-12-20 | S1 | 1160h | 1160h | OSA1-PI | Rel6 | TSG |  |  |  |  |
| 241 | 37.1.2 | Access to User Profile | 145d | 2001-06-01 A | 2001-12-20 | 90% | 14.5d | 2001-06-01 | 2001-12-20 | 145d | 548d | finish no earlier than 2001-12-20 | S1 | 1160h | 1044h | OSA1-UP | Rel6 | TSG |  |  |  |  |
| 242 | 37.1.3 | Policy Management | 145d | 2001-06-01 A | 2001-12-20 | 90% | 14.5d | 2001-06-01 | 2001-12-20 | 145d | 548d | finish no earlier than 2001-12-20 | S1 | 1160h | 1044h | OSA1-PM | Rel6 | TSG |  |  |  |  |

Notes:
- 217: Foreseen start and completion dates introduced by MCC (no indication at all on the WID)
- 220: SA3 acknowledge role in WI at SA3#20. Active contribution S3#24, S3#25. S3 WID approved SA#17
- 226: Active contribution S3#24, S3#25. WID approved SA#17
- 235: Approved at SA#14. This may require BBs from CN1, CN4, SA5 and T3
- 236: Contribution received S3#24, S3#25

| ID | WBS | Task | Duration | Start | Finish | Predecessors | Complete | Remaining | Baseline start | Baseline finish | Baseline duration | Total slack | Constraint | Resources | Work | Actual work | Text1 | Text3 | Text4 | Text6 | Text7 | Text8 | Text5 | Text2 | Text9 |
| --- | --- | --- | --- | --- | --- | --- | --- | --- | --- | --- | --- | --- | --- | --- | --- | --- | --- | --- | --- | --- | --- | --- | --- | --- | --- |
| 243 | 38 | **Rel-6 OSA enhancements** | 834d? | 2000-07-11 A | 2003-09-19 |  | 19% | 678.52d? | 2002-03-14 | 2002-12-20 | 202d | 92d |  | S1 | 38033.6h | 9153.09h | OSA3 | 22.127, 29.198, 29.998 | Jörg Swetina, SIEMENS AG | Rel6 | TSG | Adrian Z |  |  |  |
| 244 | 38.1 | Support of a Generic Network Interface Function (Stage 1) | 212.1d | 2002-02-27 | 2003-01-06 |  |  |  | 2002-03-14 | 2002-12-20 | 202d | 276.4d | finish no earlier than 2003-01-06 | S1 | 1696.79h |  |  |  |  |  | TSG |  |  |  |  |
| 245 | 38.2 | Support of a Generic Network Interface Function (Stage 3) | 397d | 2002-02-14 | 2003-09-19 |  |  |  | 2002-03-14 | 2002-12-20 | 202d | 92d | finish no earlier than 2003-09-19 | N5 | 3176h |  |  | 29.198, 29.998 | Ard-Jan MOERDIJK (Ericsson) |  | TSG |  | Ard.Jan.Moerdijk@eln.ericsson.se |  |  |
| 246 | 38.11 | User Data Management / User data security management (Stage 3) | 212.1d | 2002-02-27 | 2003-01-06 |  |  |  | 2002-03-14 | 2002-12-20 | 202d | 276.4d | finish no earlier than 2003-01-06 | S1 | 1696.79h |  |  |  |  |  | TSG |  |  |  |  |
| 247 | 38.12 | User Data Management / User data security management (Stage 3) | 397d | 2002-03-14 A | 2003-09-19 |  | 15% | 337.45d |  |  |  | 92d | finish no earlier than 2003-09-19 | N5 | 3176h | 476.4h |  | 29.198, 29.998 | Ard-Jan MOERDIJK (Ericsson) |  | TSG |  | Ard.Jan.Moerdijk@eln.ericsson.se |  |  |
| 248 | 36.5 | Retrieval of Visited Network capabilities | 232d? | 2002-10-31 A | 2003-09-19 |  | 5% | 220.4d? |  |  |  | 92d | finish no earlier than 2003-09-19 | N5 | 1856h | 92.8h |  | 29.198, 29.998 | Ard-Jan MOERDIJK (Ericsson) |  | WG |  | Ard.Jan.Moerdijk@eln.ericsson.se |  |  |
| 249 | 36.6 | Access to IP Session information | 232d? | 2002-10-31 A | 2003-09-19 |  | 5% | 220.4d? |  |  |  | 92d | finish no earlier than 2003-09-19 | N5 | 1856h | 92.8h |  | 29.198, 29.998 | Ard-Jan MOERDIJK (Ericsson) |  | WG |  | Ard.Jan.Moerdijk@eln.ericsson.se |  |  |
| 250 | 36.7 | Multi Media Messaging function | 232d? | 2002-10-31 A | 2003-09-19 |  | 5% | 220.4d? |  |  |  | 92d | finish no earlier than 2003-09-19 | N5 | 1856h | 92.8h |  | 29.198, 29.998 | Ard-Jan MOERDIJK (Ericsson) |  | WG |  | Ard.Jan.Moerdijk@eln.ericsson.se |  |  |
| 251 | 36.8 | Enhanced user privacy in LCS | 232d? | 2002-10-31 A | 2003-09-19 |  | 5% | 220.4d? |  |  |  | 92d | finish no earlier than 2003-09-19 | N5 | 1856h | 92.8h |  | 29.198, 29.998 | Ard-Jan MOERDIJK (Ericsson) |  | WG |  | Ard.Jan.Moerdijk@eln.ericsson.se |  |  |
| 252 | 36.9 | Policy management extensions | 232d? | 2002-10-31 A | 2003-09-19 |  | 5% | 220.4d? |  |  |  | 92d | finish no earlier than 2003-09-19 | N5 | 1856h | 92.8h |  | 29.198, 29.998 | Ard-Jan MOERDIJK (Ericsson) |  | WG |  | Ard.Jan.Moerdijk@eln.ericsson.se |  |  |
| 253 | 36.10 | Presence and Availability Management (from the PRESNC WI) | 232d? | 2002-10-31 A | 2003-09-19 |  | 5% | 220.4d? |  |  |  | 92d | finish no earlier than 2003-09-19 | N5 | 1856h | 92.8h |  | 29.198, 29.998 | Ard-Jan MOERDIJK (Ericsson) |  | WG |  | Ard.Jan.Moerdijk@eln.ericsson.se |  |  |
| 254 | 36.11 | Information Services | 232d? | 2002-10-31 A | 2003-09-19 |  | 5% | 220.4d? |  |  |  | 92d | finish no earlier than 2003-09-19 | N5 | 1856h | 92.8h |  | 29.198, 29.998 | Ard-Jan MOERDIJK (Ericsson) |  | WG |  | Ard.Jan.Moerdijk@eln.ericsson.se |  |  |
| 255 | 36.12 | Information Transfer | 232d? | 2002-10-31 A | 2003-09-19 |  | 5% | 220.4d? |  |  |  | 92d | finish no earlier than 2003-09-19 | N5 | 1856h | 92.8h |  | 29.198, 29.998 | Ard-Jan MOERDIJK (Ericsson) |  | WG |  | Ard.Jan.Moerdijk@eln.ericsson.se |  |  |
| 256 | 38.13 | Security | 202d | 2002-03-14 A | 2002-12-20 |  | 50% | 101d | 2002-03-14 | 2002-12-20 | 202d | 287d | finish no earlier than 2002-12-20 | S3 | 1616h | 808h |  |  |  |  |  |  |  |  |  |
| 257 | 38.14 | **Retrieval of Terminal capabilities** | 634d | 2000-07-11 A | 2002-12-13 |  | 76% | 154.97d | 2000-07-11 | 2002-12-13 | 634d | 292d |  | S2 | 8648h | 6534.2h | OSA1-TC |  |  | Rel6 | TSG |  |  | Ser | 1433 |
| 258 | 38.14.1 | Stage 1 | 132d | 2000-07-11 A | 2001-01-10 |  | 50% | 66d | 2000-07-11 | 2001-01-10 | 132d | 794d | finish no earlier than 2001-01-10 | S1 | 1056h | 528h |  | 22.127 | Jörg Swetina, SIEMENS AG |  | TSG |  |  | Ser | 1434 |
| 259 | 38.14.2 | Stages 2 and 3 | 321d | 2001-09-21 A | 2002-12-13 A | 258 | 100% |  | 2001-09-21 | 2002-12-13 | 321d |  | finish no earlier than 2002-12-13 | N5 | 2568h | 2568h |  | 29.198, 29.998 | Ard-Jan MOERDIJK (Ericsson) |  | TSG |  | Ard.Jan.Moerdijk@eln.ericsson.se | Ser | 1436 |
| 260 | 38.14.3 | Provisionning of the terminal capabilities | 175d | 2001-04-02 A | 2001-11-30 |  | 50% | 87.5d | 2001-04-02 | 2001-11-30 | 175d | 562d | finish no earlier than 2001-11-30 | T2 | 1400h | 700h |  | 23.057 |  |  | TSG |  |  |  | 2122 |
| 261 | 37 | **Handling of early UEs** | 165d? | 2002-10-07 A | 2003-05-23 |  | 12% | 145.87d? |  |  |  | 177d |  | S2 | 4080h | 473.04h | LATE_UE |  |  | Rel6 | WG |  |  |  |  |
| 262 | 37.1 | Feasibility Study | 50d? | 2002-10-07 A | 2002-12-13 |  | 60% | 20d? |  |  |  | 292d | finish no earlier than 2002-12-13 | S2 | 400h | 240h |  |  |  |  | WG |  |  |  |  |
| 263 | 37.2 | Stage 2 | 100d? | 2003-01-06 A | 2003-05-23 |  | 10% | 90d? |  |  |  | 177d | finish no earlier than 2003-03-14 | S2 | 800h | 80h |  |  |  |  | WG |  |  |  |  |
| 264 | 37.3 | Stage 3 | 100d? | 2003-01-06 | 2003-05-23 |  |  |  |  |  |  | 177d | start no earlier than 2003-01-06 | N1 | 800h |  |  |  |  |  |  |  |  |  |  |
| 265 | 37.4 | Stage 3 by N4 | 95d? | 2003-01-06 | 2003-05-16 |  |  |  |  |  |  | 182d | start no earlier than 2003-01-06 | N4 | 760h |  |  |  |  |  |  |  |  |  |  |
| 266 | 39 | **Addition of frequency bands to GSM** | 306d | 2002-06-28 A | 2003-08-29 |  | 7% | 285.12d |  |  |  | 107d |  | GP | 7760h | 529.62h | TAPS |  | Torben Themsen | Rel6 |  |  |  |  |  |
| 267 | 39.1 | **Single Antenna Receiver Interference Cancellation (SAIC)** | 206d | 2002-11-15 A | 2003-08-29 |  | 11% | 183.34d |  |  |  | 107d |  | G1 | 3296h | 362.55h | SAIC |  | Marc Grant, Cingular Wireless | Rel6 | TSG |  |  |  |  |
| 268 | 39.1.1 | Changes to core specs | 206d | 2002-11-15 A | 2003-08-29 |  | 11% | 183.34d |  |  |  | 107d | finish no earlier than 2003-04-11 | G1 | 1648h | 181.28h |  |  |  |  |  |  |  |  |  |

Notes:
- 243: .
- 246: Changed WI Title.
- 247: Changed WI Title.
- 248: WID submitted to CN#18
- 249: WID submitted to CN#18
- 250: WID submitted to CN#18
- 251: WID submitted to CN#18
- 252: WID submitted to CN#18
- 253: WID submitted to CN#18
- 254: WID submitted to CN#18
- 255: WID submitted to CN#18
- 256: Contribution at S3#25
- 260: According to T2 SWG1 M. Cataldo this is automatically supported by the MExE support of UAProf therefore 100% complete

| ID | WBS | Task | Duration | Start | Finish | Complete | Remaining | Total slack | Constraint | Resources | Work | Actual work | Text1 | Text4 | Text6 | Text5 | Text3 | Text7 | Text8 | Text2 |
| --- | --- | --- | --- | --- | --- | --- | --- | --- | --- | --- | --- | --- | --- | --- | --- | --- | --- | --- | --- | --- |
| 269 | 39.2 | **Addition of frequency bands to GSM – Changes for conformance tests** | 126d | 2002-06-28 | 2002-12-20 |  |  | 287d |  | G4 | 2016h |  | TAPS-Conf | Torben Themsen |  |  |  |  |  |  |
| 270 | 39.2.1 | 51.010-1 Add testing | 126d | 2002-06-28 | 2002-12-20 |  |  | 287d | finish no earlier than 2002-12-20 | G4 | 1008h |  |  |  |  |  |  |  |  |  |
| 271 | 40 | **Seamless support of streaming services in A/Gb mode** | 341d? | 2002-08-30 A | 2003-12-19 | 4% | 326.62d? | 27d |  | GP | 9328h | 393.47h | SSStrea | José Luis Carrizo Martínez, Vodafone | Rel6 |  |  |  |  |  |
| 272 | 40.1 | Identification of requirements for streaming | 116d | 2002-08-30 A | 2003-02-07 | 20% | 92.8d | 252d | finish no earlier than 2003-02-07 | G1 | 928h | 185.6h |  |  |  |  |  |  |  |  |
| 273 | 40.2 | Performance study of cell change mechnisms | 116d | 2002-08-30 A | 2003-02-07 | 10% | 104.4d | 252d | finish no earlier than 2003-02-07 | G1 | 928h | 92.8h |  |  |  |  |  |  |  |  |
| 274 | 40.3 | Reduction of service interruption times and packet loss during mobility procedures | 216d | 2002-08-30 | 2003-06-27 |  |  | 152d | finish no earlier than 2003-06-27 | G2 | 1728h |  |  |  |  |  |  |  |  |  |
| 275 | 40.5 | MS conformance testing | 116d | 2003-07-11 | 2003-12-19 |  |  | 27d | finish no earlier than 2003-12-19 | G4 | 928h |  |  |  |  |  |  |  |  |  |
| 276 | 39.5 | GERAN A/Gb mode security enhancements | 261d? | 2002-12-09 | 2003-12-08 |  |  | 36d | finish no earlier than 2003-12-08 | S3 | 2088h |  |  | Peter Howard, Vodafone |  | peter.howard@vodafone.com |  |  |  |  |
| 277 | 41 | Performance characterisation of default codecs for PS conversational multimedia application | 203d | 2002-09-11 A | 2003-06-20 | 5% | 192.85d | 157d | finish no earlier than 2003-06-20 | S4 | 1624h | 81.2h | CODCAR | Pasi Ojala (Nokia) | Rel6 |  | TR 26.9yz | TSG |  |  |
| 278 | 42 | Study of Feature Interactions Requirements | 82d | 2002-11-08 A | 2003-03-03 | 15% | 69.7d | 236d | start no earlier than 2002-11-08 | S1 | 656h | 98.4h | FINTER |  | Rel6 |  | TR 21.xyz |  | Michael C |  |
| 279 | 43 | Study on Privacy Capability | 82d | 2002-11-08 A | 2003-03-03 | 15% | 69.7d | 236d | start no earlier than 2002-11-08 | S1 | 656h | 98.4h | PrivCap | Liz Daniel, Lucent | Rel6 |  | TR 21.xyz |  | Michael C |  |
| 280 | 44 | **Rel-6 OAM&P** | 337d? | 2002-06-12 A | 2003-09-25 | 8% | 308.75d? | 88d |  | S5 | 20808h | 1670.77h | OAM | Michael TRUSS (Motorola) | Rel6 | Michael.Truss@MOTOROLA.COM | 32-series | TSG |  |  |
| 281 | 44.1 | Rel6 Principles, high level Requirements and Architecture | 271d | 2002-09-12 A | 2003-09-25 | 5% | 257.45d | 88d | finish no earlier than 2003-09-25 | S5 | 2168h | 108.4h | OAM-AR | Michael TRUSS (Motorola) |  | Michael.Truss@MOTOROLA.COM | 32.101, 32.102 | TSG |  | BCaM |
| 282 | 44.2 | Rel6 Performance Management | 271d | 2002-09-12 A | 2003-09-25 | 5% | 257.45d | 88d | finish no earlier than 2003-09-25 | S5 | 2168h | 108.4h | OAM-PM | Christian TOCHE (Nortel Networks) |  | toche@NORTELNETWORKS.COM | 32.41x, 52.402 | TSG |  | BCaM |
| 283 | 44.3 | **Rel6 User Equipment Management** | 301d? | 2002-08-01 A | 2003-09-25 | 5% | 285.95d? | 88d |  | S5 | 8912h | 445.6h | OAM-UEM | John Mudge (Vodafone) |  | john.mudge@vf.vodafone.co.uk | 32.150, 27.150 (T2), 32.802 | TSG |  |  |
| 284 | 43.3.1 | UEM requirements and architecture; Stages 1 and 2 | 271d? | 2002-09-12 A | 2003-09-25 | 5% | 257.45d? | 88d | finish no earlier than 2003-09-25 | S5 | 2168h | 108.4h |  | John Mudge (Vodafone) |  | john.mudge@vf.vodafone.co.uk | 32.150 (SA5) | TSG |  |  |
| 285 | 43.3.2 | UEM protocol specification; Stage 3 | 271d? | 2002-09-12 A | 2003-09-25 | 5% | 257.45d? | 88d | finish no earlier than 2003-09-25 | T2 | 2168h | 108.4h |  |  |  |  | 27.150 (T2) | TSG |  |  |
| 286 | 43.3.3 | Release 6 User Equipment Management: Security aspects | 301d? | 2002-08-01 A | 2003-09-25 | 5% | 285.95d? | 88d | finish no earlier than 2003-09-25 | S3 | 2408h | 120.4h | OAM-UEM-SEC | Peter Howard (Vodafone) |  | peter.howard@vodafone.com |  | TSG |  |  |
| 287 | 44.4 | Rel6 Network Infrastructure Management | 271d | 2002-09-12 A | 2003-09-25 | 5% | 257.45d | 88d | finish no earlier than 2003-09-25 | S5 | 2168h | 108.4h | OAM-NIM | Thomas TOVINGER (Ericsson) |  | Thomas.Tovinger@emw.ericsson.se | 32.6xy, 32.3xy | TSG |  |  |
| 288 | 44.5 | Rel6 Trace Management | 337d | 2002-06-12 A | 2003-09-25 | 25% | 252.75d | 88d | finish no earlier than 2003-09-25 | S5 | 2696h | 674h | OEM-Trace | Christian TOCHE (Nortel Networks) |  | toche@NORTELNETWORKS.COM | 32.42x, 52.008 | TSG |  |  |
| 289 | 44 | **Charging Management** | 226d? | 2002-11-14 A | 2003-09-25 | 5% | 214.01d? | 88d |  | S5 | 8144h | 431.88h | CH | Karl-Heinz NENNER (T-Mobile) | Rel6 | karl-heinz.nenner@t-mobile.de | 32.2xy | WG |  |  |
| 290 | 44.1 | Charging Management for Bearer level | 220d? | 2002-11-22 | 2003-09-25 |  |  | 88d | finish no earlier than 2003-09-25 | S5 | 1760h |  | CH-BC | Benni ALEXANDER (Nokia) |  |  |  | WG |  |  |
| 291 | 44.2 | Charging Management for the IMS | 220d? | 2002-11-22 | 2003-09-25 |  |  | 88d | finish no earlier than 2003-09-25 | S5 | 1760h |  | CH-IC | Ariel SHARON (Lucent) |  |  |  | WG |  |  |
| 292 | 44.3 | Charging Management for the Service domain | 220d? | 2002-11-22 | 2003-09-25 |  |  | 88d | finish no earlier than 2003-09-25 | S5 | 1760h |  | CH-SC | Gerald GÖRMER (Siemens) |  |  |  | WG |  |  |
| 293 | 44.4 | Overall architectural aspects of IP flow based bearer level charging | 132d? | 2002-11-14 A | 2003-06-20 | 32% | 90d? | 157d | finish no earlier than 2003-06-20 | S2 | 1056h | 336h |  |  |  |  |  |  |  |  |

Notes:
- 284: created 25/11/02
- 285: created 25/11/02
- 286: created 15/01/03
- 289: post SA5#32 created 25/11/02

| ID | WBS | Task | Duration | Start | Finish | Predecessors | Complete | Remaining | Baseline start | Baseline finish | Baseline duration | Total slack | Constraint | Resources | Work | Actual work | Text6 | Text1 | Text2 | Text7 | Text9 | Text4 | Text8 | Text3 | Text5 |
| --- | --- | --- | --- | --- | --- | --- | --- | --- | --- | --- | --- | --- | --- | --- | --- | --- | --- | --- | --- | --- | --- | --- | --- | --- | --- |
| 294 | 45 | **Rel-6 USIM toolkit enhancements** | 525d | 2000-09-25 A | 2002-09-27 |  | 80% | 106.64d |  |  |  | 347d |  | T3 | 14160h | 8886.88h | NA |  |  |  |  |  |  |  |  |
| 295 | 45.1 | **C SIM API** | 525d | 2000-09-25 A | 2002-09-27 |  | 80% | 106.64d | 2000-09-25 | 2002-09-27 | 525d | 347d |  | T3 | 9960.02h | 7936.88h | Rel6 | USAT1-API-MULTOS | Ter | TSG | 2031 |  |  |  |  |
| 296 | 45.1.1 | Specification | 525d | 2000-09-25 A | 2002-09-27 A |  | 100% |  | 2000-09-25 | 2002-09-27 | 525d |  | finish no earlier than 2002-09-27 | T3 | 4200h | 4200h |  |  | Ter | TSG | 2032 | Neil Livingston – Aspects Software |  |  |  |
| 297 | 45.1.2 | Test specification | 195d | 2001-01-01 A | 2001-09-28 |  | 25% | 146.25d | 2001-01-01 | 2001-09-28 | 195d | 607d | finish no earlier than 2001-09-28 | T3 | 1560h | 390h |  |  | Ter | TSG | 2033 | Neil Livingston – Aspects Software |  |  |  |
| 298 | 45 | ----- Rel-4 features listed below ----- | 1d | 2000-01-03 | 2000-01-03 |  |  |  | 2000-01-03 | 2000-01-03 | 1d | 1061d |  |  |  |  | Rel4 |  |  |  |  |  |  |  |  |
| 299 | 15 | **Miscelleneous UE Conformance Testing Activities** | 501d | 2001-04-02 A | 2003-03-03 |  | 52% | 242.76d | 2001-04-02 | 2003-03-03 | 501d | 236d |  | T1 | 19080h | 9834.7h | NA | MISTST1 |  |  | 1861 |  | Lidia |  |  |
| 300 | 15.1 | Optimisation of Test Time, RF Aspects (FDD) | 376d | 2001-09-24 A | 2003-03-03 |  | 70% | 112.8d | 2001-09-24 | 2003-03-03 | 376d | 236d | finish no earlier than 2003-03-03 | T1 | 3008h | 2105.6h | Rel Indep | MISTST1-OpFDD |  | TSG | 1862 |  |  | 34.121 |  |
| 301 | 15.2 | Optimisation of Test Time, RF Aspects (TDD) | 376d | 2001-09-24 A | 2003-03-03 |  | 70% | 112.8d | 2001-09-24 | 2003-03-03 | 376d | 236d | finish no earlier than 2003-03-03 | T1 | 3008h | 2105.6h | Rel Indep | MISTST1-OpTDD |  | TSG | 1863 |  |  | 34.122 |  |
| 302 | 15.3 | Extensions to R99 Test cases | 87.2w | 2001-04-02 A | 2002-12-02 |  | 60% | 34.88w | 2001-04-02 | 2002-12-02 | 87.2w | 301d | finish no earlier than 2002-12-02 | T1 | 3488h | 2092.8h |  | MISTST1-Ext |  | TSG | 1907 |  |  | 34.123 pts 1,2 |  |
| 303 | 15.4 | Extension to R99 Test cases - TTCN | 177d | 2002-06-28 A | 2003-03-03 |  | 30% | 123.9d | 2002-06-28 | 2003-03-03 | 177d | 236d | finish no earlier than 2003-03-03 | T1 | 1416h | 424.8h |  |  |  | TSG |  |  |  |  |  |
| 304 | 15.5 | Creation of R99 TCs for TDD - prose | 260d | 2001-10-01 A | 2002-09-27 |  | 50% | 130d | 2001-10-01 | 2002-09-27 | 260d | 347d | finish no earlier than 2002-09-27 | T1 | 2080h | 1040h |  | MISTST1-TDD |  | TSG |  |  |  | 34.123-1 |  |
| 305 | 15.6 | Creation of R99 TCs for TDD - TTCN | 130d | 2002-09-03 | 2003-03-03 |  |  |  | 2002-09-03 | 2003-03-03 | 130d | 236d | finish no earlier than 2003-03-03 | T1 | 1040h |  |  |  |  | TSG |  |  |  |  |  |
| 306 | 15.7 | Review all other work items for impact on new or exiting 34 series specs. | 25.8w | 2002-07-02 | 2002-12-27 |  |  |  | 2002-07-02 | 2002-12-27 | 25.8w | 282d | finish no earlier than 2002-12-27 | T1 | 1032h |  |  | MISTST1 |  |  | 1908 |  |  | 34.121,122,123,125 |  |
| 307 | 46 | **Facsimile** | 89d | 2000-02-22 A | 2000-06-23 A |  | 100% |  | 2000-02-22 | 2000-06-23 | 89d |  |  | S1 | 4376h | 4376h | Rel4 | FAX |  | TSG | 1340 |  | Alain |  |  |
| 308 | 46.1 | **Real Time Fax** | 89d | 2000-02-22 A | 2000-06-23 A |  | 100% |  | 2000-02-22 | 2000-06-23 | 89d |  |  | S2 | 3664h | 3664h |  | FAX-RT | CCaR |  | 1341 |  |  |  |  |
| 309 | 46.1.1 | Terminal capabilities, AT commands | 89d | 2000-02-22 A | 2000-06-23 A |  | 100% |  | 2000-02-22 | 2000-06-23 | 89d |  | finish no earlier than 2000-06-23 | T2 | 712h | 712h |  |  | CCaR |  | 1808 |  |  | 21.904, 27.007 |  |
| 310 | 46.1.2 | Signalling aspects (e.g. ICM) | 89d | 2000-02-22 A | 2000-06-23 A |  | 100% |  | 2000-02-22 | 2000-06-23 | 89d |  | start no earlier than 2000-02-22 | N1 | 712h | 712h |  |  | CCaR |  | 1343 |  |  |  |  |
| 311 | 46.1.3 | Service provision | 89d | 2000-02-22 A | 2000-06-23 A |  | 100% |  | 2000-02-22 | 2000-06-23 | 89d |  | finish no earlier than 2000-06-23 | N3 | 712h | 712h |  |  | CCaR |  | 1648 |  |  | 23.146 |  |
| 312 | 46.1.4 | Review whether service/stage 1 aspects need to be aligned | 51d | 2000-04-14 A | 2000-06-23 A |  | 100% |  | 2000-04-14 | 2000-06-23 | 51d |  | finish no earlier than 2000-12-14 | S1 | 408h | 408h |  |  | CCaR |  | 1345 |  |  |  |  |
| 313 | 46.1.5 | Review whether architecture/stage 2 aspects need to be aligned | 51d | 2000-04-14 A | 2000-06-23 A |  | 100% |  | 2000-04-14 | 2000-06-23 | 51d |  | finish no earlier than 2000-12-14 | S2 | 408h | 408h |  |  | CCaR |  | 1346 |  |  |  |  |
| 314 | 47 | Transparent End-to-End PS mobile streaming application | 253d | 2000-04-03 A | 2001-03-21 A |  | 100% |  | 2000-04-03 | 2001-03-21 | 253d |  | finish no earlier than 2000-12-29 | S4 | 2024h | 2024h | Rel4 | PSTREAM |  | TSG | 1539 |  | Paolo | 26.233, 26.234 |  |
| 315 | 48 | **Multimedia Messaging** | 277d | 2000-02-22 A | 2001-03-14 |  | 99% | 0d | 2000-02-22 | 2001-03-14 | 277d | 0d |  | T2 | 12208h | 10661.6h | Rel4 | MMS | Mes | TSG | 1818 | Josef Laumen, Siemens | Friedhelm | 22.140, 23.140 | Josef.Laumen@SAL.SIEMENS.DE |
| 316 | 48.1 | Definition of service requirements | 72d | 2000-02-22 A | 2000-05-31 A |  | 100% |  | 2000-02-22 | 2000-05-31 | 72d |  | start no earlier than 2000-02-22 | S1 | 576h | 576h |  | MMS | Mes |  | 136 |  |  |  |  |
| 317 | 48.2 | Review of definition of service requirements | 205d | 2000-06-01 A | 2001-03-14 A | 316 | 100% |  | 2000-06-01 | 2001-03-14 | 205d |  | finish no earlier than 2000-09-08 | T2 | 1640h | 1640h |  |  | Mes | TSG | 1819 | Josef Laumen, Siemens |  | 22.140, 23.140 |  |

Notes:
- 296: 30/12/2000: completion amount updated
- 300: It is believed that the current R99 test spec. can be optimised for faster overall test times
- 301: It is believed that the current R99 test spec. can be optimised for faster overall test times
- 302: Further test coverage of the R99 specification to cover supplementry services
- 306: Can't start until most core specs are stable
- 308: postponed from R99 to R00, SP-000169

| ID | WBS | Task | Type | Duration | Start | Finish | Complete | Remaining | Baseline start | Baseline finish | Baseline duration | Total slack | Constraint | Resources | Work | Actual work | Text2 | Text3 | Text4 | Text5 | Text7 | Text9 | Text1 | Text6 | Text8 |
| --- | --- | --- | --- | --- | --- | --- | --- | --- | --- | --- | --- | --- | --- | --- | --- | --- | --- | --- | --- | --- | --- | --- | --- | --- | --- |
| 318 | 48.3 | **Technical Realisation** |  | 243d | 2000-04-10 A | 2001-03-14 A | 100% |  | 2000-04-10 | 2001-03-14 | 243d |  |  | T2 | 7776h | 7776h | Mes | 22.140, 23.140 | Josef Laumen, Siemens | Josef.Laumen@SAL.SIEMENS.DE | TSG | 1820 |  |  |  |
| 319 | 48.3.1 | Review of definition of reference Achitecture model |  | 243d | 2000-04-10 A | 2001-03-14 A | 100% |  | 2000-04-10 | 2001-03-14 | 243d |  | finish no earlier than 2001-03-14 | T2 | 1944h | 1944h | Mes | 22.140, 23.140 | Josef Laumen, Siemens | Josef.Laumen@SAL.SIEMENS.DE | TSG | 1821 |  |  |  |
| 320 | 48.3.2 | "Fulfill Requirements of Stage 1" |  | 243d | 2000-04-10 A | 2001-03-14 A | 100% |  | 2000-04-10 | 2001-03-14 | 243d |  | finish no earlier than 2001-03-14 | T2 | 1944h | 1944h | Mes | 22.140, 23.140 | Josef Laumen, Siemens | Josef.Laumen@SAL.SIEMENS.DE | TSG | 1822 |  |  |  |
| 321 | 48.3.3 | Definition of MMS primitives in Stage 2 |  | 243d | 2000-04-10 A | 2001-03-14 A | 100% |  | 2000-04-10 | 2001-03-14 | 243d |  | finish no earlier than 2001-03-14 | T2 | 1944h | 1944h | Mes | 22.140, 23.140 | Josef Laumen, Siemens | Josef.Laumen@SAL.SIEMENS.DE | TSG | 1823 |  |  |  |
| 322 | 49 | **Transcoder-Free Operation** |  | 325d | 2000-01-03 A | 2001-03-30 | 99% | 0d | 2000-01-03 | 2001-03-30 | 325d | 0d |  | N4 | 13040h | 10440h | Cod |  |  |  |  | 1541 | TrFO | Rel4 | Kimmo |
| 323 | 49.1 | **OoBTC solution** |  | 325d | 2000-01-03 A | 2001-03-30 A | 100% |  | 2000-01-03 | 2001-03-30 | 325d |  |  | N4 | 8440h | 8440h | Cod |  | Tosshiyuki Tamura, NEC | tamurato@elsf.ncos.nec.co.jp | WG | 112 | TRFO-OOBTC |  |  |
| 324 | 49.1.1 | implementation in UTRAN |  | 145d | 2000-09-11 A | 2001-03-30 A | 100% |  | 2000-09-11 | 2001-03-30 | 145d |  | finish no earlier than 2001-03-30 | R3 | 1160h | 1160h |  | 25.401, 25.410, 25.413, 25.415, 23.153 | Alexander Vesely, Siemens | alexander.vesely@SIEMENS.AT | TSG | 1512 | TRFO-OOBTC-UTRAN |  |  |
| 325 | 49.1.2 | Impact on architecture, Principles and Terminology |  | 210d | 2000-01-03 A | 2000-10-20 A | 100% |  | 2000-01-03 | 2000-10-20 | 210d |  | finish no earlier than 2000-10-20 | S2 | 1680h | 1680h | Cod |  |  |  |  | 896 |  |  |  |
| 326 | 49.1.3 | Codec Negotiation between UE and MSC |  | 125d | 2000-08-14 A | 2001-02-02 A | 100% |  | 2000-08-14 | 2001-02-02 | 125d |  | finish no earlier than 2001-02-02 | N1 | 1000h | 1000h | Cod | 24.008, 23.009, 23.108, (29.002) | Andrew Howell / Motorola |  | TSG | 1657 |  |  |  |
| 327 | 49.1.4 | Codec Negotiation inter MSC |  | 125d | 2000-07-03 A | 2000-12-22 A | 100% |  | 2000-07-03 | 2000-12-22 | 125d |  | finish no earlier than 2000-12-22 | N4 | 1000h | 1000h | Cod |  |  |  |  | 115 |  |  |  |
| 328 | 49.1.5 | Bearer establishment inter MSC |  | 125d | 2000-07-03 A | 2000-12-22 A | 100% |  | 2000-07-03 | 2000-12-22 | 125d |  | finish no earlier than 2000-12-22 | N4 | 1000h | 1000h | Cod | 23.153 |  |  | TSG | 894 |  |  |  |
| 329 | 49.2 | **Speech Transcoder: Location and Control at the UMTS Core Network Border** |  | 125d | 2000-04-10 A | 2000-09-29 A | 100% |  | 2000-04-10 | 2000-09-29 | 125d |  |  | S2 | 2000h | 2000h | Cod |  |  |  | WG | 905 | TRFO-STLC |  |  |
| 330 | 49.2.1 | Transcoder at Edge |  | 125d | 2000-04-10 A | 2000-09-29 A | 100% |  | 2000-04-10 | 2000-09-29 | 125d |  | finish no earlier than 2000-09-29 | NP | 1000h | 1000h | Cod |  |  |  |  | 124 |  |  |  |
| 331 | 50 | **GERAN improvements 1 (Gb over IP)** |  | 225d | 2000-05-09 A | 2001-03-19 A | 100% |  | 2000-05-09 | 2001-03-19 | 225d |  |  | GP | 6472h | 6472h |  |  |  |  | TSG | 2310 | GEIMP1 | Rel4 | Paolo |
| 332 | 50.1 | **Gb over IP (Ip-fication of Gb)** |  | 225d | 2000-05-09 A | 2001-03-19 A | 100% |  | 2000-05-09 | 2001-03-19 | 225d |  |  | GP | 4672h | 4672h |  |  |  |  | TSG | 2311 | GbIP |  | Paolo |
| 333 | 50.1.1 | Concept |  | 134d | 2000-05-09 A | 2000-11-10 A | 100% |  | 2000-05-09 | 2000-11-10 | 134d |  |  | GP | 1072h | 1072h |  |  |  |  | TSG | 2312 |  |  |  |
| 334 | 50.1.2 | Changes to 08.16, 08.18 |  | 225d | 2000-05-09 A | 2001-03-19 A | 100% |  | 2000-05-09 | 2001-03-19 | 225d |  |  | GP | 1800h | 1800h |  |  |  |  | TSG | 2313 |  |  |  |
| 335 | 51 | **GERAN improvements 2 (NACC)** |  | 555d | 2000-11-06 A | 2002-12-20 | 82% | 101.04d | 2000-11-06 | 2002-06-28 | 430d | 287d |  | GP | 16296h | 8288h |  |  |  |  | TSG | 2314 | GEIMP2 | Rel4 | Paolo |
| 336 | 51.1 | **Gb enhancements** |  | 155d | 2000-11-06 A | 2001-06-08 A | 100% |  | 2000-11-06 | 2001-06-08 | 155d |  |  | GP | 7440h | 7440h |  |  |  |  | TSG | 2315 | Gben |  | Paolo |
| 337 | 51.1.1 | **Intra BSC NACC (Network Assisted Cell Change)** |  | 155d | 2000-11-06 A | 2001-06-08 A | 100% |  | 2000-11-06 | 2001-06-08 | 155d |  |  | GP | 6200h | 6200h |  |  |  |  | TSG | 2316 |  |  |  |
| 338 | 51.1.1.1 | Concept |  | 155d | 2000-11-06 A | 2001-06-08 A | 100% |  | 2000-11-06 | 2001-06-08 | 155d |  | finish no earlier than 2001-06-08 | GP | 1240h | 1240h |  |  |  |  | TSG | 2420 |  |  |  |
| 339 | 51.1.1.2 | Changes in 03.64 |  | 155d | 2000-11-06 A | 2001-06-08 A | 100% |  | 2000-11-06 | 2001-06-08 | 155d |  | finish no earlier than 2001-06-08 | GP | 1240h | 1240h |  |  |  |  | TSG | 2317 |  |  |  |
| 340 | 51.1.1.3 | Changes in 04.60 |  | 155d | 2000-11-06 A | 2001-06-08 A | 100% |  | 2000-11-06 | 2001-06-08 | 155d |  | finish no earlier than 2001-06-08 | GP | 1240h | 1240h |  |  |  |  | TSG | 2318 |  |  |  |
| 341 | 51.1.1.4 | Changes in 44.008 |  | 155d | 2000-11-06 A | 2001-06-08 A | 100% |  | 2000-11-06 | 2001-06-08 | 155d |  | finish no earlier than 2001-06-08 | GP | 1240h | 1240h |  |  |  |  | TSG | 2319 |  |  |  |
| 342 | 51.2 | Start Testing | milestone | 0d | 2001-06-04 | 2001-06-04 |  |  | 2001-06-04 | 2001-06-04 | 0d | 692d | start no earlier than 2001-06-04 |  |  |  |  |  |  |  |  |  |  |  |  |

Notes:
- 320: e.g. minimum set of media formats, media format conversion, personalization of MMS.
- 322: Lead given to CN4 from CN / [DAB 28/11/00]
- 324: moved according to NP-000575
- 325: e.g. study cascading TrFO/TFO/TrFO
- 326: the link to NP-000085has been deleted because refering to a R99 status sheet / One common set of codec negotiation procedures will be specified as in ID1656.
- 327: Bearer establishment inter MSC. TS 23.153 R99 part complete. capabilities moved to annex + list of open issues
- 328: Bearer establishment inter MSC. TS 23.153 R99 part complete. capabilities moved to annex. / See NP-000127 / Open issues: / Handling of Conference Calls; / Handling of Multi Party Supplementary Services; / Handling of Handover UMTS to GSM; / Handling of Sending a ...
- 329: WI description and Tdoc S2-99352 / Speech Transcoder: Location and Control at the UMTS Core Network Border
- 330: WI description and Tdoc S2-99352...

| ID | WBS | Task | Type | Duration | Start | Finish | Predecessors | Complete | Remaining | Baseline start | Baseline finish | Baseline duration | Total slack | Free slack | Constraint | Resources | Work | Actual work | Text1 | Text6 | Text7 | Text8 | Text9 | Text4 | Text2 | Text3 | Text5 |
| --- | --- | --- | --- | --- | --- | --- | --- | --- | --- | --- | --- | --- | --- | --- | --- | --- | --- | --- | --- | --- | --- | --- | --- | --- | --- | --- | --- |
| 343 | 51.3 | **MS conformance test for Intra BSC NACC** |  | 276d | 2001-11-30 A | 2002-12-20 |  |  | 276d | 2001-11-30 | 2002-06-28 | 151d | 287d |  |  | GP | 4416h |  | GEIMP2-Msconf |  |  |  |  |  |  |  |  |
| 344 | 51.3.1 | Changes in 51.010 |  | 138d | 2001-11-30 A | 2002-12-20 |  |  | 138d | 2001-11-30 | 2002-06-28 | 151d | 287d |  | finish no earlier than 2002-12-20 | G5; G4 | 2208h |  |  |  |  |  |  |  |  |  |  |
| 345 | 52 | **GERAN improvements 4 (Delayed TBF)** |  | 105d | 2001-01-15 A | 2001-06-08 A |  | 100% |  | 2001-01-15 | 2001-06-08 | 105d |  |  |  | GP | 3960h | 3960h | GEIMP4 | Rel4 | TSG | Paolo | 2324 |  |  |  |  |
| 346 | 52.1 | **Gb enhancements 2** |  | 105d | 2001-01-15 A | 2001-06-08 A |  | 100% |  | 2001-01-15 | 2001-06-08 | 105d |  |  |  | GP | 3120h | 3120h | GEIMP4-Gben2 |  | TSG |  | 2325 |  |  |  |  |
| 347 | 52.1.1 | stage 2 |  | 105d | 2001-01-15 A | 2001-06-08 A |  | 100% |  | 2001-01-15 | 2001-06-08 | 105d |  |  | finish no earlier than 2001-06-08 | GP | 840h | 840h |  |  |  |  | 2429 |  |  |  |  |
| 348 | 52.1.2 | **Stage 3 (changes in 44.060)** |  | 60d | 2001-01-15 A | 2001-04-06 A |  | 100% |  | 2001-01-15 | 2001-04-06 | 60d |  |  |  | G2 | 1440h | 1440h |  |  | TSG |  | 2421 |  |  |  |  |
| 349 | 52.1.2.1 | Definition of enhanced countdown procedure |  | 60d | 2001-01-15 A | 2001-04-06 A |  | 100% |  | 2001-01-15 | 2001-04-06 | 60d |  |  | finish no earlier than 2001-04-06 | G2 | 480h | 480h |  |  | TSG |  | 2327 |  |  |  |  |
| 350 | 52.1.2.2 | Definition of enhanced TBF release procedure |  | 60d | 2001-01-15 A | 2001-04-06 A |  | 100% |  | 2001-01-15 | 2001-04-06 | 60d |  |  | finish no earlier than 2001-04-06 | G2 | 480h | 480h |  |  | TSG |  | 2328 |  |  |  |  |
| 351 | 52.1.2.3 | Definition of USF=FREE type polling mechanism on PDCH |  | 60d | 2001-01-15 A | 2001-04-06 A |  | 100% |  | 2001-01-15 | 2001-04-06 | 60d |  |  | finish no earlier than 2001-04-06 | G2 | 480h | 480h |  |  | TSG |  | 2329 |  |  |  |  |
| 352 | 53 | **Low Chip Rate TDD option** |  | 832d | 2000-07-19 A | 2003-09-25 |  | 78% | 182d | 2000-07-19 | 2003-12-01 | 879d | 88d |  |  | R1 | 23504h | 18396.9h | LCRTDD | Rel4 | TSG | Shinobu | 1222 | G. Yang, CWTS |  |  |  |
| 353 | 53.1 | Physical layer |  | 183d | 2000-07-19 A | 2001-03-30 A |  | 100% |  | 2000-07-19 | 2001-03-30 | 183d |  |  | finish no earlier than 2001-03-30 | R1 | 1464h | 1464h | LCRTDD-Phys |  | TSG |  | 1223 | G. Yang, CWTS |  |  |  |
| 354 | 53.2 | Layer 2 and layer 3 protocol aspects |  | 183d | 2000-07-19 A | 2001-03-30 A |  | 100% |  | 2000-07-19 | 2001-03-30 | 183d |  |  | finish no earlier than 2001-03-30 | R2 | 1464h | 1464h | LCRTDD-L23 |  | TSG |  | 1224 | Y. Liu, CWTS | BaAS |  |  |
| 355 | 53.3 | RF radio transmission/reception, system performance requirements and conformance testing |  | 165d | 2000-08-14 A | 2001-03-30 A |  | 100% |  | 2000-08-14 | 2001-03-30 | 165d |  |  | finish no earlier than 2001-03-30 | R4 | 1320h | 1320h | LCRTDD-RF |  | TSG |  | 1225 | D. Zhang, CWTS | BaAS |  |  |
| 356 | 53.4 | UE radio access capability |  | 165d | 2000-08-14 A | 2001-03-30 A |  | 100% |  | 2000-08-14 | 2001-03-30 | 165d |  |  | finish no earlier than 2001-03-30 | R2 | 1320h | 1320h | LCRTDD-UErac |  | TSG |  | 1227 | Y. Liu, CWTS | BaAS |  |  |
| 357 | 53.5 | Iub/Iur protocol aspects |  | 165d | 2000-08-14 A | 2001-03-30 A |  | 100% |  | 2000-08-14 | 2001-03-30 | 165d |  |  | finish no earlier than 2001-03-30 | R3 | 1320h | 1320h | LCRTDD-IubIur |  | TSG |  | 1228 | Y. Liu, CWTS | BaAS |  |  |
| 358 | 53.6 | **Low chiprate TDD interworking with GERAN** |  | 101d | 2000-09-01 A | 2001-01-19 A | 357 | 100% |  | 2000-09-01 | 2001-01-19 | 101d |  |  |  |  |  |  |  |  |  | Paolo | 2262 |  |  |  |  |
| 359 | 53.6.1 | Handover and Cell Selection / Reselection to UTRA 1.28 Mcps TDD |  | 101d | 2000-09-01 A | 2001-01-19 A |  | 100% |  | 2000-09-01 | 2001-01-19 | 101d |  |  | finish no earlier than 2001-01-19 |  |  |  |  |  |  |  | 2263 |  |  |  |  |
| 360 | 53.7 | Start Testing | milestone | 0d | 2001-09-03 | 2001-09-03 | 358 |  |  | 2001-09-03 | 2001-09-03 | 0d | 359.62d | 10d | start no earlier than 2001-09-03 | MLST |  |  |  |  |  |  | 1911 |  |  |  |  |
| 361 | 53.8 | **Conformance Test Aspects - Low Chip Rate TDD** |  | 529d | 2001-09-17 A | 2003-09-25 | 360 | 49% | 267.38d | 2001-09-17 | 2003-12-01 | 576d | 88d |  |  | T1 | 10104h | 4996.94h |  |  |  |  | 2103 |  |  | 0% |  |
| 362 | 53.8.1 | Testing Layer 2 and layer 3 protocol aspects |  | 316d | 2001-09-17 A | 2002-12-02 |  | 50% | 158d | 2001-09-17 | 2002-12-02 | 316d | 301d |  | finish no earlier than 2002-12-02 | T1 | 2528h | 1264h |  |  | TSG |  | 2217 |  |  | 34.123-1, 34.123-2 |  |
| 363 | 53.8.2 | Testing Layer 2 and layer 3 protocol aspects - TTCN |  | 213d | 2002-12-03 | 2003-09-25 |  |  |  | 2002-12-03 | 2003-12-01 | 260d | 88d |  | finish no earlier than 2003-09-25 | T1 | 1704h |  |  |  | TSG |  |  |  |  | 34.123-3 |  |
| 364 | 53.8.3 | Testing RF Radio Transmission and Reception |  | 205d | 2001-09-17 A | 2002-06-28 A |  | 100% |  | 2001-09-17 | 2002-06-28 | 205d |  |  | finish no earlier than 2002-06-28 | T1 | 1640h | 1640h |  |  | TSG |  | 2218 |  |  |  |  |
| 365 | 54 | **Enable bearer independent CS architecture** |  | 565d | 2000-01-03 A | 2002-03-01 |  | 80% | 114.5d | 2000-01-03 | 2002-03-01 | 565d | 497d |  |  | S2 | 20176h | 13788h | CSSPLIT | Rel4 | TSG | Kimmo |  | Alexander Milinski, Siemens |  |  |  |
| 366 | 54.1 | **Enable bearer-independent call control** |  | 424d | 2000-01-03 A | 2001-08-16 |  | 99% | 0d | 2000-01-03 | 2001-08-16 | 424d | 0d |  |  | N4 | 12336h | 8944h |  |  | WG |  | 1323 | Heinz-Peter Keutman, Ericsson | CCaR |  | Heinz-Peter.Keutmann@eed.ericsson.se |
| 367 | 54.1.1 | Architecture and Stage 2 description |  | 180d | 2000-01-03 A | 2000-09-08 A |  | 100% |  | 2000-01-03 | 2000-09-08 | 180d |  |  | finish no earlier than 2000-09-08 | S2 | 1440h | 1440h |  |  |  |  | 1516 |  | CCaR | 23.002 |  |
| 368 | 54.1.2 | Standardisation of protocols (control & user planes) over Nb interface |  | 64d | 2001-01-02 A | 2001-03-30 A |  | 100% |  | 2001-01-02 | 2001-03-30 | 64d |  |  | finish no earlier than 2001-03-30 | N3 | 512h | 512h |  |  | TSG |  | 1325 |  | CCaR |  |  |
| 369 | 54.1.3 | Standardisation of protocols over reference points between MSC server and Gateway MSC server |  | 130d | 2000-09-25 A | 2001-03-23 A |  | 100% |  | 2000-09-25 | 2001-03-23 | 130d |  |  | finish no earlier than 2001-03-23 | N4 | 1040h | 1040h |  |  | TSG |  | 1326 |  | CCaR |  |  |
| 370 | 54.1.4 | Standardisation of detailed stage 2 description |  | 180d | 2000-07-17 A | 2001-03-23 A |  | 100% |  | 2000-07-17 | 2001-03-23 | 180d |  |  | finish no earlier than 2001-03-23 | N4 | 1440h | 1440h |  |  | TSG |  | 1616 |  |  |  |  |

Notes:
- 362: duration set to 6 months (was 0)
- 364: duration set to 6 months (was 0), finish date set
- 366: DAB 12.12.01 should be 100% hence closed
- 367: R00 stage 2 at least 80 % complete in TSGS #8 21.-23.6.2000

| ID | WBS | Task | Type | Duration | Start | Finish | Predecessors | Complete | Remaining | Baseline start | Baseline finish | Baseline duration | Total slack | Free slack | Constraint | Resources | Work | Actual work | Text2 | Text7 | Text9 | Text1 | Text3 | Text6 | Text8 | Text4 | Text5 |
| --- | --- | --- | --- | --- | --- | --- | --- | --- | --- | --- | --- | --- | --- | --- | --- | --- | --- | --- | --- | --- | --- | --- | --- | --- | --- | --- | --- |
| 371 | 54.1.5 | **Bearer control between MSC server and MGW** |  | 250d | 2000-09-01 A | 2001-08-16 A |  | 100% |  | 2000-09-01 | 2001-08-16 | 250d |  |  |  | N4 | 4512h | 4512h | CCaR | TSG | 1327 |  |  |  |  |  |  |
| 372 | 54.1.5.1 | stage 3 - protocol issues |  | 250d | 2000-09-01 A | 2001-08-16 A |  | 100% |  | 2000-09-01 | 2001-08-16 | 250d |  |  | finish no earlier than 2001-08-16 | N4 | 2000h | 2000h | CCaR | TSG | 1328 |  |  |  |  |  |  |
| 373 | 54.1.5.2 | stage 3 - parameter value issues |  | 64d | 2001-01-02 A | 2001-03-30 A |  | 100% |  | 2001-01-02 | 2001-03-30 | 64d |  |  | finish no earlier than 2001-03-30 | N3 | 512h | 512h | CCaR |  | 1329 |  |  |  |  |  |  |
| 374 | 54.2 | Lawful interception |  | 155d | 2000-08-21 A | 2001-03-23 A |  | 100% |  | 2000-08-21 | 2001-03-23 | 155d |  |  | finish no earlier than 2001-03-23 | S3 | 1240h | 1240h | CCaR |  | 1331 |  |  |  |  |  |  |
| 375 | 54.3 | Start Testing | milestone | 0d | 2001-03-05 | 2001-03-05 |  |  |  | 2001-03-05 | 2001-03-05 | 0d | 497d | 0d | start no earlier than 2001-03-05 | MLST |  |  |  |  | 1918 |  |  |  |  |  |  |
| 376 | 54.4 | Conformance Test Aspects - Enable bearer independent CS architecture |  | 260d | 2001-03-05 | 2002-03-01 | 375 |  |  | 2001-03-05 | 2002-03-01 | 260d | 497d |  |  | T1 | 2080h |  |  |  |  | CSSPLIT-TEST | 0% |  |  |  |  |
| 377 | 55 | **MExE enhancements Rel-4** |  | 802d | 2000-01-03 A | 2003-01-28 |  | 88% | 96.68d | 2000-01-03 | 2002-05-28 | 627d | 260d |  |  | T2 | 22768h | 20426.6h | Ter | TSG | 1445 | MEXE |  | Rel4 | Friedhelm |  |  |
| 378 | 55.1 | **MExE Security Analysis Activity** |  | 474d | 2000-02-22 A | 2001-12-14 A |  | 100% |  | 2000-02-22 | 2001-12-14 | 474d |  |  |  | S3 | 8464h | 8464h | Ter | TSG | 1447 | MEXE-SEC |  |  |  | Colin Blanchard, BT | colin.blanchard@bt.com |
| 379 | 55.1.1 | Stage 3 |  | 370d | 2000-07-17 A | 2001-12-14 A |  | 100% |  | 2000-07-17 | 2001-12-14 | 370d |  |  | finish no earlier than 2001-12-14 | S3 | 2960h | 2960h | Ter |  | 2045 | MEXE1-SEC |  |  |  |  |  |
| 380 | 55.1.2 | Terminal aspects |  | 214d | 2000-02-22 A | 2000-12-15 A |  | 100% |  | 2000-02-22 | 2000-12-15 | 214d |  |  | finish no earlier than 2000-12-15 | T2 | 1712h | 1712h | Ter |  | 1448 |  |  |  |  |  |  |
| 381 | 55.2 | **MExE Rel4 Improvements and Investigations** |  | 250d | 2000-01-03 A | 2000-12-15 |  | 99% | 0d | 2000-01-03 | 2000-12-15 | 250d | 0d |  |  | T2 | 6480h | 6320h | Ter | TSG | 1810 | MEXE-ENHANC | 22.057, 23.057 |  |  | Mark CATALDO, Motorola | mcatald1@MOTOROLA.COM |
| 382 | 55.2.1 | 3rd MExE classmark |  | 250d | 2000-01-03 A | 2000-12-15 A |  | 100% |  | 2000-01-03 | 2000-12-15 | 250d |  |  | finish no earlier than 2000-12-15 | T2 | 2000h | 2000h | Ter | TSG | 1812 |  | 22.057, 23.057 |  |  | Mark CATALDO, Motorola | mcatald1@MOTOROLA.COM |
| 383 | 55.2.2 | FS on Secure download mechanism and capabilities to support SDR concepts |  | 225d | 2000-02-07 A | 2000-12-15 A |  | 100% |  | 2000-02-07 | 2000-12-15 | 225d |  |  | finish no earlier than 2000-12-15 | T2 | 1800h | 1800h | Ter | TSG | 1814 |  | 22.057, 23.057 |  |  | Mark CATALDO, Motorola | mcatald1@MOTOROLA.COM |
| 384 | 55.2.3 | FS on Support of MP3/MPEG4 content |  | 225d | 2000-02-07 A | 2000-12-15 A |  | 100% |  | 2000-02-07 | 2000-12-15 | 225d |  |  | finish no earlier than 2000-12-15 | T2 | 1800h | 1800h | Ter | TSG | 1815 |  | 22.057, 23.057 |  |  | Mark CATALDO, Motorola | mcatald1@MOTOROLA.COM |
| 385 | 55.3 | Conformance testing of MExE capability (Feasibility study) |  | 176d | 2002-05-28 | 2003-01-28 |  |  |  | 2002-05-28 | 2002-05-28 | 1d | 260d |  | finish no earlier than 2003-01-28 | T1 | 1408h |  |  | TSG |  |  |  | Rel4 |  |  |  |
| 386 | 56 | **Tandem Free aspects for 3G and between 2G and 3G systems** |  | 344d | 2000-02-22 A | 2001-06-15 A |  | 100% |  | 2000-02-22 | 2001-06-15 | 344d |  |  |  | S4 | 9696h | 9696h | Cod |  | 1631 | TFO |  | Rel4 | Paolo |  |  |
| 387 | 56.1 | **Tandem Free AMR** |  | 344d | 2000-02-22 A | 2001-06-15 A |  | 100% |  | 2000-02-22 | 2001-06-15 | 344d |  |  |  | S4 | 6944h | 6944h | Cod |  | 1632 | TFO-AMR |  |  |  |  |  |
| 388 | 56.1.1 | Specification |  | 284d | 2000-02-22 A | 2001-03-23 A |  | 100% |  | 2000-02-22 | 2001-03-23 | 284d |  |  | start no earlier than 2000-02-22 | S4 | 2272h | 2272h | Cod |  | 130 |  | 28.062 |  |  |  |  |
| 389 | 56.1.2 | **Impact on:** |  | 115d | 2001-01-08 A | 2001-06-15 A |  | 100% |  | 2001-01-08 | 2001-06-15 | 115d |  |  |  | NP | 1920h | 1920h | Cod |  | 907 |  |  |  |  |  |  |
| 390 | 56.1.2.1 | CN |  | 60d | 2001-03-26 A | 2001-06-15 A |  | 100% |  | 2001-03-26 | 2001-06-15 | 60d |  |  | finish no earlier than 2001-06-15 | NP | 480h | 480h | Cod |  | 131 |  |  |  |  |  |  |
| 391 | 56.1.2.2 | GERAN |  | 65d | 2001-01-08 A | 2001-04-06 A |  | 100% |  | 2001-01-08 | 2001-04-06 | 65d |  |  | finish no earlier than 2001-04-06 | GP | 520h | 520h | Cod |  | 132 |  |  |  |  |  |  |
| 392 | 57 | **Advanced Speech Call Items enhancements_REL-4** |  | 334d | 2000-12-03 A | 2002-03-14 A |  | 100% |  | 2000-12-03 | 2002-03-14 | 334d |  |  |  | N1 | 5925.6h | 5925.6h |  | TSG | 2230 | ASCI |  | Rel4 | Per | Sonia Garapaty | sonia.garapaty@nortelnetworks.com |
| 393 | 57.1 | Stage 2 |  | 326.7d | 2000-12-03 A | 2002-03-14 A |  | 100% |  | 2000-12-03 | 2002-03-14 | 326.7d |  |  | finish no earlier than 2002-03-14 | N4 | 2613.6h | 2613.6h |  | WG | 2232 |  | 23.067, 24.067 |  | Kimmo | Vivien Perlic, Sagem |  |
| 394 | 57.2 | Stages 2 and 3 on A interface |  | 80d | 2000-12-03 A | 2001-03-23 A |  | 100% |  | 2000-12-03 | 2001-03-23 | 80d |  |  | finish no earlier than 2001-03-23 | N1 | 640h | 640h |  | WG | 2231 |  | 44.068, 44.069, 24.008 |  | Per | Sonia Garapaty | sonia.garapaty@nortelnetworks.com |

Notes:
- 374: Requirements capture: S3#14 (Aug 00), Feature specification: S3#15 (Sep 00), Definition of architecture. Should be included in general LI work mentioned above.
- 378: Presentation to S3 of threats and countermeasures analysis: S3#15, Feature specification: S3#16. S3#18: WID updated
- 379: Analysis undertaken by T2. No additional analysis needed for Rel-4
- 382: Additional features for MExE R2000
- 386: RAN and CN to verify no problems for GSM terminals roaming in 3G R99
- 387: RAN and CN to verify UMTS_AMR_2 support
- 389: "Implementation" changed to "Impact on:" by A. Sultan (for better wording)
- 390: RAN and CN to verify UMTS_AMR_2 support
- 391: End date Modified from June to March to have it in Rel4
- 392: Approved in TSGN_10
- 393: CN4#11 30/11/02: no inputs received in CN4

| ID | WBS | Task | Duration | Start | Finish | Complete | Remaining | Baseline start | Baseline finish | Baseline duration | Total slack | Constraint | Resources | Work | Actual work | Text1 | Text6 | Text8 | Text9 | Text5 | Text7 | Text3 | Text2 |
| --- | --- | --- | --- | --- | --- | --- | --- | --- | --- | --- | --- | --- | --- | --- | --- | --- | --- | --- | --- | --- | --- | --- | --- |
| 395 | 58 | **700 MHz spectrum support** | 775d | 2000-01-03 A | 2002-12-20 | 99% | 0d | 2000-01-03 | 2002-06-28 | 650d | 0d |  | GP | 25000h | 18800h | 700SS | Rel4 | Paolo | 2403 |  |  |  |  |
| 396 | 58.1 | **GERAN support for the 700 MHz band** | 275d | 2000-01-03 A | 2001-01-19 A | 100% |  | 2000-01-03 | 2001-01-19 | 275d |  |  | GP | 8800h | 8800h |  |  |  | 2404 |  |  |  |  |
| 397 | 58.1.1 | Signalling support | 275d | 2000-01-03 A | 2001-01-19 A | 100% |  | 2000-01-03 | 2001-01-19 | 275d |  | finish no earlier than 2001-01-19 | GP | 2200h | 2200h |  |  |  | 2405 |  |  |  |  |
| 398 | 58.1.2 | Physical layer definitions | 275d | 2000-01-03 A | 2001-01-19 A | 100% |  | 2000-01-03 | 2001-01-19 | 275d |  | finish no earlier than 2001-01-19 | GP | 2200h | 2200h |  |  |  | 2406 |  |  |  |  |
| 399 | 58.1.3 | Receiver performance and RF budget | 275d | 2000-01-03 A | 2001-01-19 A | 100% |  | 2000-01-03 | 2001-01-19 | 275d |  | finish no earlier than 2001-01-19 | GP | 2200h | 2200h |  |  |  | 2407 |  |  |  |  |
| 400 | 58.2 | **GERAN MS Conformance test for 700 MHz band** | 175d | 2001-04-02 A | 2001-11-30 A | 100% |  | 2001-04-02 | 2001-11-30 | 175d |  |  | GP | 2800h | 2800h |  |  |  | 2408 |  |  |  |  |
| 401 | 58.2.1 | MS test | 175d | 2001-04-02 A | 2001-11-30 A | 100% |  | 2001-04-02 | 2001-11-30 | 175d |  | finish no earlier than 2001-11-30 | GP | 1400h | 1400h |  |  |  | 2409 |  |  |  |  |
| 402 | 58.3 | **GERAN BTS Conformance test for 700 MHz band** | 450d | 2001-04-02 A | 2002-12-20 A | 100% |  | 2001-04-02 | 2002-06-28 | 325d |  |  | GP | 7200h | 7200h |  |  | Paolo | 2410 |  |  |  |  |
| 403 | 58.3.1 | BTS test | 450d | 2001-04-02 A | 2002-12-20 A | 100% |  | 2001-04-02 | 2002-06-28 | 325d |  | finish no earlier than 2002-12-20 | GP | 3600h | 3600h |  |  |  | 2411 |  |  |  |  |
| 404 | 59 | Operator Determined Barring for Packet Oriented Services | 208d | 2000-06-01 A | 2001-03-19 A | 100% |  | 2000-06-01 | 2001-03-19 | 208d |  | finish no earlier than 2001-03-19 | NP | 1664h | 1664h | ODB | Rel4 |  | 2463 | tamurato@nsf.ncos.nec.co.jp | TSG |  |  |
| 405 | 60 | **UMTS QoS Architecture for PS Domain** | 758d | 2000-01-03 A | 2002-11-27 | 61% | 295.18d | 2000-01-03 | 2002-11-27 | 758d | 304d |  | S2 | 54256h | 20605.3h | QoSPS | Rel4 |  |  | Ina.widegren@era.ericsson.se | TSG |  |  |
| 406 | 60.1 | Architecture | 153d | 2000-06-05 A | 2001-01-03 A | 100% |  | 2000-06-05 | 2001-01-03 | 153d |  | finish no earlier than 2001-01-03 | S2 | 1224h | 1224h |  |  |  |  |  | TSG | 23.107 |  |
| 407 | 60.2 | Charging and OAM&P for QoS Management | 201d | 2001-09-21 A | 2002-06-28 A | 100% |  | 2001-09-21 | 2002-06-28 | 201d |  | finish no earlier than 2002-06-28 | S5 | 1608h | 1608h | QoSPS-OAM |  |  |  | Albert.Yuhan@voicestream.com; Michael.Truss@MOTOROLA.COM | TSG | 32-series |  |
| 408 | 60.3 | **RAB Quality of Service (re)Negotiation over Iu** | 155d | 2000-08-21 A | 2001-03-23 | 99% | 0d | 2000-08-21 | 2001-03-23 | 155d | 0d |  | R3 | 3648h | 2501.6h | QoSPS-MAPEND-RABQoS |  |  | 1681 |  | TSG | 25.413 |  |
| 409 | 60.3.1 | RAB Quality of Service Negotiation over Iu | 155d | 2000-08-21 A | 2001-03-23 A | 100% |  | 2000-08-21 | 2001-03-23 | 155d |  | finish no earlier than 2001-03-23 | R3 | 1240h | 1240h | QoSPS-MAPEND-RABQoS-Negot |  |  | 1991 |  | TSG |  |  |
| 410 | 60.3.2 | RAB Quality of Service Negotiation over Iu during relocation | 16d | 2001-03-02 A | 2001-03-23 A | 100% |  | 2001-03-02 | 2001-03-23 | 16d |  | start no earlier than 2001-03-02 | R3 | 128h | 128h | QoSPS-MAPEND-RABQoS-NegotReloc |  |  | 2456 |  | TSG |  |  |
| 411 | 60.3.3 | RAB Quality of Service Re-Negotiation over Iu | 130d | 2000-09-25 A | 2001-03-23 A | 100% |  | 2000-09-25 | 2001-03-23 | 130d |  | finish no earlier than 2001-03-23 | R3 | 1040h | 1040h | QoSPS-MAPEND-RABQoS-ReNegot |  |  | 1992 |  | TSG |  |  |
| 412 | 60.4 | **GERAN QoS Aspects - Handovers: maintenance of real-time QoS while moving between cells in the PLMN including inter-SGSN and SRNS relocation or possibly other mechanisms** | 500d | 2000-01-03 A | 2001-11-30 | 99% | 0d | 2000-01-03 | 2001-11-30 | 500d | 0d |  | GP | 14440h | 10544h | GERQoS |  | Paolo | 1553 |  | TSG |  | QoS |
| 413 | 60.4.1 | **Handover Concept for the PS domain** | 500d | 2000-01-03 A | 2001-11-30 | 99% | 0d | 2000-01-03 | 2001-11-30 | 500d | 0d |  | GP | 10440h | 6544h |  |  |  | 2306 |  | TSG |  |  |
| 414 | 60.4.1.1 | Stable RT handover report 25.936 including header removal | 13d | 2000-01-03 A | 2000-01-19 A | 100% |  | 2000-01-03 | 2000-01-19 | 13d |  | start no earlier than 2000-01-03 | GP | 104h | 104h |  |  |  | 2309 |  | TSG |  |  |
| 415 | 60.4.1.2 | Update of stage 2 | 292d | 2000-01-03 A | 2001-02-13 A | 100% |  | 2000-01-03 | 2001-02-13 | 292d |  | finish no earlier than 2001-02-13 | GP | 2336h | 2336h |  |  |  | 2307 |  | TSG |  |  |
| 416 | 60.4.1.3 | Update of relevant stage 3 specs -> RRC | 500d | 2000-01-03 A | 2001-11-30 A | 100% |  | 2000-01-03 | 2001-11-30 | 500d |  | finish no earlier than 2001-11-30 | G2 | 4000h | 4000h |  |  |  | 2308 |  | TSG |  |  |
| 417 | 60.5 | **GERAN MS Conformance test for inter-system and intra-system Packet data real-time Handover** | 324d | 2001-08-31 | 2002-11-27 |  |  | 2001-08-31 | 2002-11-27 | 324d | 304d |  | G4; R3 | 25920h |  | GERQoS-Mstest |  |  |  |  | TSG |  |  |
| 418 | 60.5.1 | **Handover for the PS domain** | 324d | 2001-08-31 | 2002-11-27 |  |  | 2001-08-31 | 2002-11-27 | 324d | 304d |  | G4; R3 | 20736h |  |  |  |  |  |  | TSG |  |  |
| 419 | 60.5.1.1 | Stable RT handover report 25.936 including header removal | 324d | 2001-08-31 | 2002-11-27 |  |  | 2001-08-31 | 2002-11-27 | 324d | 304d | finish no earlier than 2002-11-27 | G4; R3 | 5184h |  |  |  |  |  |  | TSG |  |  |
| 420 | 60.5.1.2 | Update of stage 2 | 324d | 2001-08-31 | 2002-11-27 |  |  | 2001-08-31 | 2002-11-27 | 324d | 304d | finish no earlier than 2002-11-27 | G4; R3 | 5184h |  |  |  |  |  |  | TSG |  |  |
| 421 | 60.5.1.3 | Update of relevant stage 3 specs | 324d | 2001-08-31 | 2002-11-27 |  |  | 2001-08-31 | 2002-11-27 | 324d | 304d | finish no earlier than 2002-11-27 | G4; R3 | 5184h |  |  |  |  |  |  | TSG |  |  |
| 422 | 60.6 | PS-domain handover for real-time services | 155d | 2000-08-28 A | 2001-03-30 A | 100% |  | 2000-08-28 | 2001-03-30 | 155d |  | finish no earlier than 2001-03-30 | R3 | 1240h | 1240h | QoSPS-PSdoRTS |  |  | 1685 |  | TSG |  | QoS |
| 423 | 60.7 | RAB QoS Renegotiation at Relocation | 58d | 2001-01-03 | 2001-03-23 |  |  | 2001-01-03 | 2001-03-23 | 58d | 742d | finish no earlier than 2001-03-23 | R3 | 464h |  |  |  |  |  |  | TSG | 25.851, 25.946 |  |
| 424 | 61 | small Technical Enhancements and Improvements for Rel4 | 325d | 2000-01-03 A | 2001-03-30 A | 100% |  | 2000-01-03 | 2001-03-30 | 325d |  |  | Generic | 2600h | 2600h | TEI4 | Rel4 |  | 1993 |  | TSG |  |  |

Notes:
- 404: Completed WI missing from the P-plan Added for tracking / Text4: oshiyuki Tamura
- 405: Text4: Ina Widegren, Ericsson
- 407: Text4: Albert YUHAN (VoiceStream Wireless), Michael TRUSS (Motorola)
- 408: Text4: A. Molander, Ericsson
- 409: Text4: A. Molander, Ericsson
- 411: Text4: S. Irwin, Motorola
- 417: Still exist? To be clarified by GERAN4/5
- 422: Text4: A. Lansisalmi, Nokia
- 424: "Joker" WI, to be used for a Rel 4 CR not related to any feature and with very limited impact on the system

| ID | WBS | Task | Duration | Start | Finish | Complete | Remaining | Baseline start | Baseline finish | Baseline duration | Total slack | Constraint | Resources | Work | Actual work | Text1 | Text4 | Text6 | Text7 | Text8 | Text2 | Text9 | Text3 | Text5 |
| --- | --- | --- | --- | --- | --- | --- | --- | --- | --- | --- | --- | --- | --- | --- | --- | --- | --- | --- | --- | --- | --- | --- | --- | --- |
| 425 | 62 | **Rel-4 Evolutions of the transport in the UTRAN** | 525d | 2000-08-21 A | 2002-08-23 | 69% | 162.5d | 2000-08-21 | 2002-08-23 | 525d | 372d |  | RP | 8600h | 6501.38h | ETRAN | Francois Courau | NA | TSG | Carolyn |  |  |  |  |
| 426 | 62.1 | QoS optimisation for AAL2 connections over Iub and Iur interfaces | 160d | 2000-08-21 A | 2001-03-30 A | 100% |  | 2000-08-21 | 2001-03-30 | 160d |  | finish no earlier than 2001-03-30 | R3 | 1280h | 1280h | ETRAN-QoSAAL2 | T. Yoshimura, Japan Telecom | Rel4 | TSG |  | BaAS | 12 |  |  |
| 427 | 62.2 | Transport bearer modification procedure on Iub, Iur, and Iu | 130d | 2000-10-02 A | 2001-03-30 A | 100% |  | 2000-10-02 | 2001-03-30 | 130d |  | finish no earlier than 2001-03-30 | R3 | 1040h | 1040h | ETRAN-MigrMod | T. Yoshimura, Japan Telecom | Rel4 | TSG |  |  | 1995 |  |  |
| 428 | 62.3 | **Conformance Test Aspects of Rel-4 evolutions of the transport in UTRAN** | 130d | 2002-02-25 | 2002-08-23 |  |  | 2002-02-25 | 2002-08-23 | 130d | 372d |  | T1 | 2080h |  |  |  |  |  |  |  | 1834 |  |  |
| 429 | 62.3.1 | Testing RAB support enhancements | 130d | 2002-02-25 | 2002-08-23 |  |  | 2002-02-25 | 2002-08-23 | 130d | 372d | finish no earlier than 2002-08-23 | T1 | 1040h |  | CT-RABS? |  |  |  |  |  | 2208 | 34.108, 34. 121, 34.122, 34.123 pts 1,2, 34.123 pt 3 |  |
| 430 | 63 | **Rel-4 Evolutions of the transport in the CN** | 215d | 2000-05-29 A | 2001-03-23 A | 100% |  | 2000-05-29 | 2001-03-23 | 215d |  |  | N4 | 7968h | 7968h | CNTRSP |  | NA |  | Kimmo | BaAS |  |  |  |
| 431 | 63.1 | **IP Transport of CN protocols (e.g., CAP, MAP)** | 77d | 2000-12-07 A | 2001-03-23 A | 100% |  | 2000-12-07 | 2001-03-23 | 77d |  |  | N4 | 2808h | 2808h | SS7IP |  | Rel4 |  |  | BaAS | 859 |  |  |
| 432 | 63.1.1 | **Stage 3** | 77d | 2000-12-07 A | 2001-03-23 A | 100% |  | 2000-12-07 | 2001-03-23 | 77d |  |  | N4 | 2192h | 2192h |  |  |  |  |  |  | 1679 |  |  |
| 433 | 63.1.1.1 | CAP | 77d | 2000-12-07 A | 2001-03-23 A | 100% |  | 2000-12-07 | 2001-03-23 | 77d |  | finish no earlier than 2001-03-23 | N2 | 616h | 616h |  |  |  | WG |  |  | 2018 |  |  |
| 434 | 63.1.1.2 | MAP | 77d | 2000-12-07 A | 2001-03-23 A | 100% |  | 2000-12-07 | 2001-03-23 | 77d |  | finish no earlier than 2001-03-23 | N4 | 616h | 616h |  |  |  |  |  |  | 2019 |  |  |
| 435 | 63.1.1.3 | BSSAP+ | 43d | 2001-01-15 A | 2001-03-14 A | 100% |  | 2001-01-15 | 2001-03-14 | 43d |  | finish no earlier than 2001-03-14 | N1 | 344h | 344h | SS7IP-BSSAP+ |  |  | WG |  | Loc | 2253 |  |  |
| 436 | 63.2 | **FS on Transport and control separation in the PS CN domain** | 215d | 2000-05-29 A | 2001-03-23 A | 100% |  | 2000-05-29 | 2001-03-23 | 215d |  |  | S2 | 3440h | 3440h |  | Juan-Antonio Ibanez, Ericsson Deutschland | Rel4 | TSG |  | BaAS | 1513 |  | Juan-Antonio.Ibanez@eed.ericsson.se |
| 437 | 63.2.1 | Architectural impacts | 215d | 2000-05-29 A | 2001-03-23 A | 100% |  | 2000-05-29 | 2001-03-23 | 215d |  | finish no earlier than 2001-03-23 | S2 | 1720h | 1720h |  |  |  | WG |  | BaAS | 1615 |  |  |
| 438 | 64 | **Rel-4 Improvements of Radio Interface** | 700d | 2000-07-10 A | 2003-03-14 | 83% | 117.46d | 2000-07-10 | 2003-03-14 | 700d | 227d |  | RP | 28624h | 23247.4h | RInImp |  | NA | TSG | Shinobu |  |  |  |  |
| 439 | 64.1 | UTRA repeater specification (master) | 183d | 2000-07-10 A | 2001-03-21 A | 100% |  | 2000-07-10 | 2001-03-21 | 183d |  | finish no earlier than 2001-03-21 | R4 | 1464h | 1464h | RInImp-REP | T. Kummetz, Mikom; Alf Ahlström, Allgon | Rel4 | TSG |  |  | 1509 |  |  |
| 440 | 64.2 | DSCH power control improvement in soft handover | 140d | 2000-09-11 A | 2001-03-23 A | 100% |  | 2000-09-11 | 2001-03-23 | 140d |  | finish no earlier than 2001-03-23 | R1 | 1120h | 1120h | RInImp-DSCHsho | A. Toskala, Nokia | Rel4 | TSG |  |  | 1994 |  |  |
| 441 | 64.3 | UMTS 1800 | 320d | 2000-09-25 A | 2001-12-14 A | 100% |  | 2000-09-25 | 2001-12-14 | 320d |  | finish no earlier than 2001-12-14 | R4 | 2560h | 2560h | RInImp-UMTS18 | H. Benn, Motorola | Rel indep | TSG |  |  | 1996 |  |  |
| 442 | 64.4 | UMTS 1900 | 195d | 2001-03-19 A | 2001-12-14 A | 100% |  | 2001-03-19 | 2001-12-14 | 195d |  | finish no earlier than 2001-12-14 | R4 | 1560h | 1560h | RInImp-UMTS19 | Howard Benn, Motorola | Rel indep | TSG | Cesar |  | 2467 |  |  |
| 443 | 64.5 | FS on High Speed downlink packet access | 155d | 2000-08-21 A | 2001-03-23 A | 100% |  | 2000-08-21 | 2001-03-23 | 155d |  | finish no earlier than 2001-03-23 | R2 | 1240h | 1240h | RInImp-HSDPA | A. Ghosh, Motorola |  | TSG |  |  | 1219 |  |  |
| 444 | 64.6 | FS on improved common DL channel for Cell-FACH state | 340d | 2000-09-11 A | 2001-12-28 A | 100% |  | 2000-09-11 | 2001-12-28 | 340d |  | finish no earlier than 2001-12-28 | R2 | 2720h | 2720h | RInImp-DLCFACH | J. Kwak, GBT |  | TSG |  |  | 1510 |  |  |
| 445 | 64.7 | **Conformance Test Spec. Rel-4 improvements in Radio Interface** | 375d | 2001-10-08 A | 2003-03-14 | 64% | 134.62d | 2001-10-08 | 2003-03-14 | 375d | 227d |  | T1 | 12360h | 7923.08h |  |  |  |  |  |  |  |  |  |
| 446 | 64.7.1 | Testing Improved usage of downlink resource in FDD for CCTrCHs of dedicated type | 140d | 2002-02-18 | 2002-08-30 |  |  | 2002-02-18 | 2002-08-30 | 140d | 367d | finish no earlier than 2002-08-30 | T1 | 1120h |  |  |  |  |  |  |  | 2212 |  |  |
| 447 | 64.7.2 | Testing Terminal Power saving features | 140d | 2002-02-18 | 2002-08-30 |  |  | 2002-02-18 | 2002-08-30 | 140d | 367d | finish no earlier than 2002-08-30 | T1 | 1120h |  |  |  |  |  |  |  | 2213 |  |  |
| 448 | 64.7.3 | Testing DSCH power control improvement in soft handover | 140d | 2002-02-18 | 2002-08-30 |  |  | 2002-02-18 | 2002-08-30 | 140d | 367d | finish no earlier than 2002-08-30 | T1 | 1120h |  |  |  | Rel4 |  |  |  | 2214 |  |  |
| 449 | 64.7.4 | Testing UMTS 1800 | 180d | 2001-10-08 A | 2002-06-14 A | 100% |  | 2001-10-08 | 2002-06-14 | 180d |  | finish no earlier than 2002-06-14 | T1 | 1440h | 1440h |  |  | Rel indep | TSG |  |  | 2215 | 34.108, 34,121, 34.122, 34.123-1 |  |
| 450 | 64.7.5 | Testing UMTS 1900 | 180d | 2001-10-08 A | 2002-06-14 A | 100% |  | 2001-10-08 | 2002-06-14 | 180d |  | finish no earlier than 2002-06-14 | T1 | 1440h | 1440h |  |  | Rel indep | TSG |  |  | 2215 | 34.108, 34,121, 34.122, 34.123-1 |  |
| 451 | 64.7.6 | Testing UMTS 1800 - TTCN | 195d | 2002-06-17 A | 2003-03-14 A | 100% |  | 2002-06-17 | 2003-03-14 | 195d |  | finish no earlier than 2003-03-14 | T1 | 1560h | 1560h |  |  | Rel indep | TSG |  |  |  | 34.123-3 |  |
| 452 | 64.7.7 | Testing UMTS 1900 - TTCN | 195d | 2002-06-17 A | 2003-03-14 A | 100% |  | 2002-06-17 | 2003-03-14 | 195d |  | finish no earlier than 2003-03-14 | T1 | 1560h | 1560h |  |  | Rel indep | TSG |  |  |  | 34.123-3 |  |

Notes:
- 429: Requires supporting companies
- 430: WI formulation assigned to N4
- 431: AS: corrected to Rel4 as stated at SA#10
- 436: Rel4 added
- 444: Stopped at RAN#14
- 446: start/finish dates set / Not started yet due to lack of supporting companies
- 447: start/finish dates set / Not started yet due to lack of supporting companies
- 448: start/finish dates set / Not started yet due to lack of supporting companies
- 449: finish date set
- 450: finish date set
- 451: finish date set
- 452: finish date set

| ID | WBS | Task | Type | Duration | Start | Finish | Predecessors | Complete | Remaining | Baseline start | Baseline finish | Baseline duration | Total slack | Free slack | Constraint | Resources | Work | Actual work | Text1 | Text6 | Text7 | Text8 | Text2 | Text4 | Text9 | Text3 | Text5 |
| --- | --- | --- | --- | --- | --- | --- | --- | --- | --- | --- | --- | --- | --- | --- | --- | --- | --- | --- | --- | --- | --- | --- | --- | --- | --- | --- | --- |
| 453 | 65 | **Rel-4 RAN improvements** |  | 817d | 2000-08-14 A | 2003-09-30 |  | 23% | 632.57d | 2000-08-14 | 2003-03-03 | 666d | 85d |  |  | RP | 22304h | 4293.53h | RANimp | NA | TSG | Hans |  |  |  |  |  |
| 454 | 65.1 | Node B synchronisation for TDD |  | 160d | 2000-08-14 A | 2001-03-23 A |  | 100% |  | 2000-08-14 | 2001-03-23 | 160d |  |  | finish no earlier than 2001-03-23 | R1 | 1280h | 1280h | RANimp-NBsync | Rel4 | TSG |  | BaAS | S. Oestreich, Siemens | 655 |  |  |
| 455 | 65.2 | RAB support enhancement for Rel-4 |  | 155d | 2000-08-21 A | 2001-03-23 A |  | 100% |  | 2000-08-21 | 2001-03-23 | 155d |  |  | finish no earlier than 2001-03-23 | R2 | 1240h | 1240h | RANimp-RABSE | Rel4 | TSG |  |  | M. Israelsson, A. Krishnarajah, Ericsson | 2206 |  |  |
| 456 | 65.3 | Start Testing | milestone | 0d | 2001-12-03 | 2001-12-03 |  |  |  | 2001-12-03 | 2001-12-03 | 0d | 207d | 21d | start no earlier than 2001-12-03 | MLST |  |  |  |  |  |  |  |  | 1912 |  |  |
| 457 | 65.4 | **Conformance Test Aspects - Rel-4 RAN Improvements** |  | 456d | 2002-01-01 A | 2003-09-30 | 456 | 2% | 445.74d | 2002-01-01 | 2003-03-03 | 305d | 85d |  |  | T1 | 13248h | 298.08h |  |  |  |  |  |  | 2102 | 0% |  |
| 458 | 65.4.1 | Testing Radio access bearer support enhancments |  | 175d | 2002-01-01 | 2002-09-02 |  |  |  | 2002-01-01 | 2002-09-02 | 175d | 366d |  | finish no earlier than 2002-09-02 | T1 | 1400h |  |  |  |  |  |  |  | 2222 |  |  |
| 459 | 65.4.2 | Testing RAB support enhancements-Robust Header Compression |  | 200d | 2002-05-28 | 2003-03-03 |  |  |  | 2002-05-28 | 2003-03-03 | 200d | 236d |  | finish no earlier than 2003-03-03 | T1 | 1600h |  | RABimp-RoCH | Rel4 | TSG |  |  |  | 2461 | 34.123-1, -2 |  |
| 460 | 65.4.3 | Testing RAB support enhancements-Robust Header Compression - TTCN |  | 285d | 2002-05-28 | 2003-06-30 |  |  |  |  |  |  | 151d |  | finish no earlier than 2003-06-30 | T1 | 2280h |  |  | Rel4 | TSG |  |  |  |  | 34.123-3 |  |
| 461 | 65.4.4 | Testing of Extended Robut Header Compression |  | 270d | 2002-09-18 A | 2003-09-30 |  | 10% | 243d |  |  |  | 85d |  | finish no earlier than 2003-09-30 | T1 | 2160h | 216h | Ext-RoHC | Rel4 | TSG |  |  |  |  | 34.123-1, -2 |  |
| 462 | 65.4.5 | Testing of Extended Robut Header Compression - TTCN |  | 270d | 2002-09-18 | 2003-09-30 |  |  |  |  |  |  | 85d |  | finish no earlier than 2003-09-30 | T1 | 2160h |  |  | Rel4 | TSG |  |  |  |  | 34.123-3 |  |
| 463 | 66 | **Rel-4 Emergency call enhancements** |  | 627d | 2000-01-03 A | 2002-05-28 |  | 64% | 227.72d | 2000-01-03 | 2002-05-28 | 627d | 435d |  |  | N1 | 7936h | 5161.18h | EMC1 | NA | WG | Per | CCaR | Mr Rouzbeh, Ericsson | 1652 |  | EUSFARO@am1.ericsson.se |
| 464 | 66.1 | **For CS based calls** |  | 627d | 2000-01-03 A | 2002-05-28 |  | 64% | 227.72d | 2000-01-03 | 2002-05-28 | 627d | 435d |  |  | N1 | 3600h | 2400h | EMC1-CS | Rel4 | TSG |  | CCaR | Mr Rouzbeh, Ericsson | 1654 |  | EUSFARO@am1.ericsson.se |
| 465 | 66.1.1 | Distinction in CS domain of emergency call types to different emergency services |  | 40d | 2000-05-01 A | 2000-06-23 A |  | 100% |  | 2000-05-01 | 2000-06-23 | 40d |  |  | finish no earlier than 2000-06-23 | S1 | 320h | 320h |  |  |  |  | CCaR |  | 1320 |  |  |
| 466 | 66.1.2 | Distinction in CS domain of emergency calls to different emergency types |  | 22d | 2000-08-28 A | 2000-09-26 A |  | 100% |  | 2000-08-28 | 2000-09-26 | 22d |  |  | finish no earlier than 2000-09-22 | N1 | 176h | 176h |  |  |  |  |  |  | 1999 |  |  |
| 467 | 66.1.3 | Conformance Test Aspects - Emergency call enhancements |  | 150d | 2000-01-03 | 2000-07-28 |  |  |  | 2000-01-03 | 2000-07-28 | 150d | 912d |  |  | T1 | 1200h |  |  |  |  |  |  |  | 2224 |  |  |
| 468 | 66.1.4 | Testing CS based emergency calls |  | 67d | 2002-02-25 A | 2002-05-28 A |  | 100% |  | 2002-02-25 | 2002-05-28 | 67d |  |  | finish no earlier than 2002-05-28 | T1 | 536h | 536h |  |  | TSG |  |  |  | 2226 | 34.123-1 |  |
| 469 | 66.1.5 | Testing CS based emergency calls - TTCN |  | 134d | 2001-11-22 A | 2002-05-28 A |  | 100% |  | 2001-11-22 | 2002-05-28 | 134d |  |  | finish no earlier than 2002-05-28 | T1 | 1072h | 1072h |  |  | TSG |  |  |  |  | 34.123-3 |  |
| 470 | 67 | **Rel-4 Terminal interfaces** |  | 314d | 2000-01-03 A | 2001-03-15 |  | 99% | 0d | 2000-01-03 | 2001-03-15 | 314d | 0d |  |  | T2 | 15651.6h | 10635.6h | TI | NA |  | Friedhelm | Ter |  | 1826 |  |  |
| 471 | 67.1 | **AT commands enhancements** |  | 313d | 2000-01-03 A | 2001-03-14 A |  | 100% |  | 2000-01-03 | 2001-03-14 | 313d |  |  |  | T2 | 5008h | 5008h | TI-ATC | Rel4 |  |  | Ter |  | 1827 | 27.007 |  |
| 472 | 67.1.1 | Specification of AT commands for new services |  | 313d | 2000-01-03 A | 2001-03-14 A |  | 100% |  | 2000-01-03 | 2001-03-14 | 313d |  |  | finish no earlier than 2001-03-14 | T2 | 2504h | 2504h |  |  |  |  | Ter |  | 1828 | 27.007 |  |
| 473 | 67.2 | **Wide Area Data Synchronisation** |  | 313d | 2000-01-03 A | 2001-03-14 |  | 99% | 0d | 2000-01-03 | 2001-03-14 | 313d | 0d |  |  | T2 | 5655.2h | 3151.2h | TI-WADS | NA |  |  | Ter |  | 1829 |  |  |
| 474 | 67.2.1 | Continues evolution of Synchronisation protocol |  | 313d | 2000-01-03 A | 2001-03-14 A |  | 100% |  | 2000-01-03 | 2001-03-14 | 313d |  |  | finish no earlier than 2001-03-14 | T2 | 2504h | 2504h | TI-SYNC-EVOL | Rel4 |  |  | Ter |  | 1830 | 27.903, 27.103 |  |
| 475 | 67.3 | Terminal local model |  | 218d | 2000-05-16 A | 2001-03-15 A |  | 100% |  | 2000-05-16 | 2001-03-15 | 218d |  |  | finish no earlier than 2001-03-15 | T2 | 1744h | 1744h | TLM | Rel4 | TSG |  | Ter | Olga Tomé, Ericsson | 1832 | 23.227 | Olga.Tome@ECS.ERICSSON.SE |
| 476 | 68 | **Rel-4 Location Services enhancements** |  | 455d | 2000-04-03 A | 2001-12-28 |  | 99% | 0d | 2000-04-03 | 2001-12-28 | 455d | 0d |  |  | S2 | 28240.8h | 21192.8h | LCS1 | NA | TSG | Alain |  | Jan Kall, Nokia | 1536 |  |  |
| 477 | 68.1 | CBS interactions |  | 455d | 2000-04-03 A | 2001-12-28 A |  | 100% |  | 2000-04-03 | 2001-12-28 | 455d |  |  | finish no earlier than 2001-12-28 | T2 | 3640h | 3640h | LCS1-CBS | Rel4 |  |  | Loc |  | 2229 | 23.041 |  |
| 478 | 68.2 | LCS support in the CS domain |  | 180d | 2000-05-15 A | 2001-01-19 A |  | 100% |  | 2000-05-15 | 2001-01-19 | 180d |  |  | finish no earlier than 2001-01-19 | S2 | 1440h | 1440h | LCS1-CS | Rel4 |  |  | Loc |  | 523 |  |  |

Notes:
- 455: 29 Nov 2000: split into ROHC and non-ROHC part; 5 Mar 2001: splitting off of ROHC for Rel-4 agreed by R2
- 456: UID changed
- 458: duration set to 6 months (was 0) / Task not started due to lack of supporting companies
- 459: UID changed
- 460: UID changed
- 464: WI approved in TSG_10 / CN1#15: ID 2101 REMOVE-Emergency call recalling capability enhancement, no contributions
- 466: Calls to different emergency services such as ambulance, fire brigade, police, etc. can be routed to respective different emergency centres. / NP-000447 is the stage 3 changes for CS call control protocol.
- 467: UID changed
- 472: goal not completely achieved because of missing input
- 473: AS: Rel5 changed to Rel4 according to SA#10 decision, milestone on testing added
- 478: Only MAP impact foreseen so far. To be further split if needed.

| ID | WBS | Task | Duration | Start | Finish | Complete | Remaining | Baseline start | Baseline finish | Baseline duration | Total slack | Constraint | Resources | Work | Actual work | Text1 | Text6 | Text9 | Text2 | Text3 | Text4 | Text5 | Text7 | Text8 |
| --- | --- | --- | --- | --- | --- | --- | --- | --- | --- | --- | --- | --- | --- | --- | --- | --- | --- | --- | --- | --- | --- | --- | --- | --- |
| 479 | 68.3 | **LCS support in the PS domain** | 435d | 2000-05-01 A | 2001-12-28 | 99% | 0d | 2000-05-01 | 2001-12-28 | 435d | 0d |  | S2 | 14164.8h | 10684.8h | LCS1-PS | Rel4 | 525 |  |  |  |  |  |  |
| 480 | 68.3.1 | Stage 1 | 40d | 2000-07-03 A | 2000-08-25 A | 100% |  | 2000-07-03 | 2000-08-25 | 40d |  | start no earlier than 2000-07-03 | S1 | 320h | 320h |  |  | 1642 | Loc | 22.071 | Randolph Wohlert, Pacific Bell Wireless | rwohlert@tri.sbc.com |  |  |
| 481 | 68.3.2 | Stage 2 | 190d | 2000-05-01 A | 2001-01-19 A | 100% |  | 2000-05-01 | 2001-01-19 | 190d |  | finish no earlier than 2001-01-19 | S2 | 1520h | 1520h |  |  | 1181 |  | 23.271 |  |  |  |  |
| 482 | 68.3.3 | **Stage 3** | 355d | 2000-08-21 A | 2001-12-28 A | 100% |  | 2000-08-21 | 2001-12-28 | 355d |  |  | N1 | 8240h | 8240h |  |  | 1180 | Loc |  |  |  |  |  |
| 483 | 68.3.3.1 | Layer 3 LCS signaling UE (MS) -SGSN (UMTS PS and and GSM-GPRS) | 355d | 2000-08-21 A | 2001-12-28 A | 100% |  | 2000-08-21 | 2001-12-28 | 355d |  | finish no earlier than 2001-12-28 | N1 | 2840h | 2840h |  |  | 526 | Loc |  | Janne Muhonen / Nokia |  |  |  |
| 484 | 68.3.3.2 | MAP impacts of LCS | 160d | 2000-08-21 A | 2001-03-30 A | 100% |  | 2000-08-21 | 2001-03-30 | 160d |  | finish no earlier than 2001-03-30 | N4 | 1280h | 1280h |  |  | 2462 | Loc |  |  |  |  |  |
| 485 | 68.3.3.3 | GTP signaling for LCS | 160d | 2000-08-21 A | 2001-03-30 A | 100% |  | 2000-08-21 | 2001-03-30 | 160d |  | finish no earlier than 2001-03-30 | N4 | 1280h | 1280h |  |  | 527 | Loc |  |  |  |  |  |
| 486 | 68.4 | **UE positioning Rel-4** | 260d | 2000-04-03 A | 2001-03-30 A | 100% |  | 2000-04-03 | 2001-03-30 | 260d |  |  | RP | 4591.2h | 4591.2h | LCS1-UEpos | NA | 1600 |  |  |  |  | TSG |  |
| 487 | 68.4.1 | Iub/Iur interfaces for methods Rel 99 | 233.9d | 2000-04-03 A | 2001-03-30 A | 100% |  | 2000-04-03 | 2001-03-30 | 233.9d |  | finish no earlier than 2001-03-30 | R3 | 1871.2h | 1871.2h | LCS1-UEpos-IubIur | Rel4 | 1601 |  |  | Yun-Chao Hu, Ericsson |  | TSG |  |
| 488 | 68.4.2 | UE positioning enhancements - IPDL for TDD | 150d | 2000-08-28 A | 2001-03-23 A | 100% |  | 2000-08-28 | 2001-03-23 | 150d |  | finish no earlier than 2001-03-23 | R2 | 1200h | 1200h | LCS1-UEpos-enh | Rel4 | 1602 |  |  | M. Beckmann, Siemens |  | TSG |  |
| 489 | 69 | **Rel-4 UICC/(U)SIM enhancements and interworking** | 175d | 2000-07-24 A | 2001-03-23 A | 100% |  | 2000-07-24 | 2001-03-23 | 175d |  |  | T3 | 2800h | 2800h | UICC1 | NA | 1560 | Ter |  |  |  |  | MichaelS |
| 490 | 69.1 | Common PCN Handset Specification (CPHS) | 175d | 2000-07-24 A | 2001-03-23 A | 100% |  | 2000-07-24 | 2001-03-23 | 175d |  | finish no earlier than 2001-03-23 | T3 | 1400h | 1400h | UICC1-CPHS | Rel4 | 1799 | Ter | 27.103 | ?, One2One |  | TSG |  |
| 491 | 70 | **Rel-4 (U)SIM toolkit enhancements** | 210d | 2000-06-05 A | 2001-03-23 A | 100% |  | 2000-06-05 | 2001-03-23 | 210d |  |  | T3 | 3360h | 3360h | USAT1 | NA | 1800 | Ter |  |  |  |  | MichaelS |
| 492 | 70.1 | USAT local link | 210d | 2000-06-05 A | 2001-03-23 A | 100% |  | 2000-06-05 | 2001-03-23 | 210d |  | finish no earlier than 2001-03-23 | T3 | 1680h | 1680h | USAT1-LocLnk | Rel4 | 2034 |  |  | Jean-Francois Rubon (Gemplus) |  | TSG |  |
| 493 | 71 | **Rel-4 Security enhancements** | 575d | 2000-01-03 A | 2002-03-15 | 87% | 74.38d | 2000-01-03 | 2002-03-15 | 575d | 487d |  | S3 | 24144h | 20865.5h | SEC1 | NA |  |  |  | Peter Howard, Vodafone | Peter.Howard@vodafone.com | TSG | Maurice |
| 494 | 71.1 | Evolution of GSM CS algorithms (e.g. A5/3 development and deployment) | 271d | 2000-01-03 A | 2001-01-15 A | 100% |  | 2000-01-03 | 2001-01-15 | 271d |  | finish no earlier than 2001-01-15 | S3 | 2168h | 2168h | SEC1-CSALGO1 | Rel4 | 1587 | Sec |  |  |  | TSG |  |
| 495 | 71.2 | **Evolution of GSM PS algorithms (e.g. GEA 2 deployment)** | 219d | 2000-02-22 A | 2000-12-22 A | 100% |  | 2000-02-22 | 2000-12-22 | 219d |  |  | S3 | 6024h | 6024h | SEC1-PSALGO1 | Rel4 | 1588 | Sec |  |  |  | TSG |  |
| 496 | 71.2.1 | Main aspects | 199d | 2000-02-22 A | 2000-11-24 A | 100% |  | 2000-02-22 | 2000-11-24 | 199d |  | finish no earlier than 2000-11-24 | S3 | 1592h | 1592h |  |  | 1589 | Sec |  |  |  |  |  |
| 497 | 71.2.2 | Impact on GTP | 200d | 2000-03-20 A | 2000-12-22 A | 100% |  | 2000-03-20 | 2000-12-22 | 200d |  | finish no earlier than 2000-12-22 | N4 | 1600h | 1600h |  |  | 1618 |  |  |  |  | WG |  |
| 498 | 71.2.3 | GEA capability indication in MS CM | 135d | 2000-06-19 A | 2000-12-22 A | 100% |  | 2000-06-19 | 2000-12-22 | 135d |  | finish no earlier than 2000-12-22 | N1 | 1080h | 1080h | SEC1-PSALGO1-GEACAP |  | 1661 | Sec |  | Duncan Mills / Vodafone Airtouch |  |  |  |
| 499 | 71.3 | **MAP application layer security** | 575d | 2000-01-03 A | 2002-03-15 | 76% | 135.92d | 2000-01-03 | 2002-03-15 | 575d | 487d |  | S3 | 11352h | 8668.59h | SEC1-MAPAL | Rel4 |  | Sec |  |  |  | TSG |  |
| 500 | 71.3.1 | Main aspects | 199d | 2000-02-21 A | 2001-03-29 A | 100% |  | 2000-02-21 | 2001-03-29 | 199d |  | start no earlier than 2000-02-21 | S3 | 1592h | 1592h |  |  | 1584 | Sec |  |  |  | WG |  |
| 501 | 71.3.2 | Other stage 3 aspects | 199d | 2000-02-22 A | 2000-11-24 A | 100% |  | 2000-02-22 | 2000-11-24 | 199d |  | finish no earlier than 2000-11-24 | N4 | 1592h | 1592h |  |  | 2025 | Sec |  |  |  | TSG |  |
| 502 | 71.3.3 | CHECK STATUS - Visibility and Configurability of security | 575d | 2000-01-03 A | 2002-03-15 | 60% | 230d | 2000-01-03 | 2002-03-15 | 575d | 487d | finish no earlier than 2002-03-15 | S3 | 4600h | 2760h | SEC1-VCS | Rel5 | 1594 | Sec |  | Sébastien Nguyen Ngoc, France Telecom | Sebastien.nguyenngoc@rd.francetelecom.com | TSG |  |

Notes:
- 480: To be also considered: External LCS client identity, and Privacy options when PDP-context and when no PDP-context is established
- 481: AS: 23.271 completed at SA#10
- 484: Missing work task
- 486: UID changed
- 487: 27/11: WG corrected; rapporteur corrected
- 488: 5 Mar 2001: splitting off of IPDL for TDD for Rel-4 agreed by R2
- 490: 28/5/2001: CRs approved at TP-11. WI complete.
- 491: UID changed
- 492: 25/5/2001:CR was approved at TP-11. WI is complete
- 493: Added BB UE authentication and rapporteur added. TO BE DELETED
- 494: Algorithm development go-ahead at SA3#21. Scheduled for completion in August 2002?. Approved SA#17. DELETE ENTRY FROM REL-4?
- 495: A5/3 development will consider new GEA algorithm based on Kasumi.
- 496: Complete TSG#09 (09/2000). S3#17: Proposed for deletion. TO BE DELETED
- 499: TO DELETE: REPLACED BY NDS-MAP and NDS-IP. TO BE DELETED, but replacement NDS-MAP was missing. Completed Auto Key Management -> Rel-6
- 500: UID changed
- 501: UID changed
- 502: CR approved at SA3#21 awaiting comments from CN1.

| ID | WBS | Task | Type | Duration | Start | Finish | Predecessors | Complete | Remaining | Baseline start | Baseline finish | Baseline duration | Total slack | Free slack | Constraint | Resources | Work | Actual work | Text1 | Text3 | Text5 | Text6 | Text7 | Text8 | Text2 | Text9 |
| --- | --- | --- | --- | --- | --- | --- | --- | --- | --- | --- | --- | --- | --- | --- | --- | --- | --- | --- | --- | --- | --- | --- | --- | --- | --- | --- |
| 503 | 72 | **Rel-4 Charging and OAM&P** |  | 221d | 2000-12-01 A | 2001-10-05 A |  | 100% |  | 2000-12-01 | 2001-10-05 | 221d |  |  |  | S5 | 10472h | 10472h | OAM | 32-series | Albert.Yuhan@voicestream.com; Michael.Truss@MOTOROLA.COM | NA | TSG | Adrian |  |  |
| 504 | 72.1 | Rel4 Principles, high level Requirements and Architecture |  | 145d | 2000-12-01 A | 2001-06-21 A |  | 100% |  | 2000-12-01 | 2001-06-21 | 145d |  |  | finish no earlier than 2001-06-21 | S5 | 1160h | 1160h | OAM-AR/PR | 32.101, 32.102 | Michael.Truss@MOTOROLA.COM; Tommy.R.Berggren@TELIA.SE | Rel4 | TSG |  | BCaM | 2089 |
| 505 | 72.2 | Rel4 Performance Management |  | 216d | 2000-12-01 A | 2001-09-28 A |  | 100% |  | 2000-12-01 | 2001-09-28 | 216d |  |  | finish no earlier than 2001-06-21 | S5 | 1728h | 1728h |  | 32.4xy, 52.402 | karl-heinz.nenner@t-mobile.de | Rel4 | TSG |  | BCaM | 2088 |
| 506 | 72.3 | Fault Management |  | 221d | 2000-12-01 A | 2001-10-05 A |  | 100% |  | 2000-12-01 | 2001-10-05 | 221d |  |  | finish no earlier than 2001-06-21 | S5 | 1768h | 1768h |  | 32.111-1/4 | pjure@LUCENT.COM | Rel4 | TSG |  | BCaM | 2081 |
| 507 | 72.4 | Configuration Management |  | 145d | 2000-12-01 A | 2001-06-21 A |  | 100% |  | 2000-12-01 | 2001-06-21 | 145d |  |  | finish no earlier than 2001-06-21 | S5 | 1160h | 1160h | OAM-CM | 32.106-1/8 | Thomas.Tovinger@emw.ericsson.se | Rel4 | TSG |  | BCaM | 2082 |
| 508 | 72.5 | Rel4 Charging Management |  | 216d | 2000-12-01 A | 2001-09-28 A |  | 100% |  | 2000-12-01 | 2001-09-28 | 216d |  |  | finish no earlier than 2001-06-21 | S5 | 1728h | 1728h | OAM-CH | 32.2xy (Charging) | karl-heinz.nenner@t-mobile.de | Rel4 | TSG |  | BCaM | 2083 |
| 509 | 72.6 | UTRAN Operations and Maintenance procedures |  | 145d | 2000-12-01 A | 2001-06-21 A |  | 100% |  | 2000-12-01 | 2001-06-21 | 145d |  |  | finish no earlier than 2001-06-21 | S5 | 1160h | 1160h | UOAM | 32.800 | bert.boden@d2mannesmann.de | Rel4 | TSG | Adrian |  | 2071 |
| 510 | 73 | **Global Text Telephony** |  | 567d | 2000-06-28 A | 2002-08-29 |  | 82% | 101.67d | 2000-06-28 | 2002-08-29 | 567d | 368d |  |  | S2 | 9984h | 8388.85h | GTT |  | gunnar.hellstrom@omnitor.se | Rel Indep | TSG | Alain |  |  |
| 511 | 73.1 | Stage 1 |  | 188d | 2000-06-28 A | 2001-03-16 A |  | 100% |  | 2000-06-28 | 2001-03-16 | 188d |  |  | finish no earlier than 2000-12-22 | S1 | 1504h | 1504h |  | 22.976, 22.226 |  |  | TSG |  |  | 1634 |
| 512 | 73.2 | Stage 2 |  | 205d | 2000-09-11 A | 2001-06-22 A |  | 100% |  | 2000-09-11 | 2001-06-22 | 205d |  |  |  | S2 | 1640h | 1640h |  | 23.226 |  |  | TSG |  |  |  |
| 513 | 73.3 | **Specification of Cellular Text telephone Modem** |  | 136d | 2000-09-11 A | 2001-03-19 A |  | 100% |  | 2000-09-11 | 2001-03-19 | 136d |  |  |  | S4 | 2704h | 2704h | GTT-CTM |  |  |  |  |  |  | 2234 |
| 514 | 73.3.1 | General description and C-code |  | 66d | 2000-09-11 A | 2000-12-11 A |  | 100% |  | 2000-09-11 | 2000-12-11 | 66d |  |  | finish no earlier than 2000-12-11 | S4 | 528h | 528h |  | 26.226, 26.230 |  |  |  |  |  | 2238 |
| 515 | 73.3.2 | Minimum Performance requirements |  | 136d | 2000-09-11 A | 2001-03-19 A |  | 100% |  | 2000-09-11 | 2001-03-19 | 136d |  |  | finish no earlier than 2001-03-19 | S4 | 1088h | 1088h |  | 26.231 |  |  |  |  |  | 2237 |
| 516 | 73.4 | Start Testing | milestone | 0d | 2002-02-18 | 2002-02-18 |  |  |  | 2002-02-18 | 2002-02-18 | 0d | 377d | 9d | start no earlier than 2002-02-18 | MLST |  |  |  |  |  |  |  |  |  |  |
| 517 | 73.5 | Conformance Test Aspects - Global Text telephony |  | 130d | 2002-03-01 | 2002-08-29 | 516 |  |  | 2002-03-01 | 2002-08-29 | 130d | 368d |  | finish no earlier than 2002-08-29 | T1 | 1040h |  |  | 34.125 |  |  |  |  |  |  |
| 518 | 76 | Enhanced Tandem Free Operation |  | 160d | 2002-11-11 | 2003-06-20 |  |  |  |  |  |  | 157d |  | finish no earlier than 2003-06-20 | S4 | 1280h |  | eTFO |  |  | Rel6 | WG | Paolo |  |  |
| 519 | 77 | Packet Switched Streaming Services Rel-6 |  | 160d | 2002-11-11 | 2003-06-20 |  |  |  |  |  |  | 157d |  | finish no earlier than 2003-06-20 | S4 | 1280h |  | PSSrel6 |  |  | Rel6 | WG | Paolo |  |  |
| 520 | 78 | AMR-WB extension for high audio quality |  | 160d | 2002-11-11 | 2003-06-20 |  |  |  |  |  |  | 157d |  | finish no earlier than 2003-06-20 | S4 | 1280h |  | AMRWB+ |  |  | Rel6 | WG | Paolo |  |  |
| 521 | 74 | ----- Rel-5 features listed below ----- |  | 1d | 2000-01-03 | 2000-01-03 |  |  |  | 2000-01-03 | 2000-01-03 | 1d | 1061d |  |  |  |  |  |  |  |  | Rel5 |  |  |  |  |
| 522 | 75 | IP transport in the UTRAN |  | 445d | 2000-07-17 A | 2002-03-29 A |  | 100% |  | 2000-07-17 | 2002-03-29 | 445d |  |  | finish no earlier than 2002-03-29 | R3 | 3560h | 3560h | ETRAN-IPtrans |  |  | Rel5 | TSG |  | BaAS | 625 |
| 523 | 76 | FS on Usage of SUA |  | 205d | 2001-03-12 A | 2001-12-21 A |  | 100% |  | 2001-03-12 | 2001-12-21 | 205d |  |  | finish no earlier than 2001-12-21 | N4 | 1640h | 1640h | SS7IP |  |  | Rel5 |  |  |  | 2455 |
| 524 | 77 | **High Speed Downlink Packet Access** |  | 438d | 2001-04-02 A | 2002-12-04 |  | 96% | 15.71d | 2001-04-02 | 2002-10-04 | 395d | 299d |  |  | R2 | 13160h | 12687.9h | HSDPA |  |  | Rel5 | TSG | Hans |  | 2476 |
| 525 | 77.1 | Physical Layer |  | 257d | 2001-04-05 A | 2002-03-29 A |  | 100% |  | 2001-04-05 | 2002-03-29 | 257d |  |  | finish no earlier than 2002-03-29 | R1 | 2056h | 2056h | HSDPA-Phys |  |  |  | TSG |  |  | 2477 |
| 526 | 77.2 | Layer 2 and 3 aspects |  | 257d | 2001-04-05 A | 2002-03-29 A |  | 100% |  | 2001-04-05 | 2002-03-29 | 257d |  |  | finish no earlier than 2002-03-29 | R2 | 2056h | 2056h | HSDPA-L23 |  |  |  | TSG |  |  | 2478 |
| 527 | 77.3 | Iub/Iur protocol aspects |  | 260d | 2001-04-02 A | 2002-03-29 A |  | 100% |  | 2001-04-02 | 2002-03-29 | 260d |  |  | finish no earlier than 2002-03-29 | R3 | 2080h | 2080h | HSDPA-IubIur |  |  |  | TSG |  |  | 2479 |
| 528 | 77.4 | RF Radio Transmission/ Reception, System Performance Requirements and Conformance Testing |  | 433d | 2001-04-09 A | 2002-12-04 |  | 90% | 43.3d | 2001-04-09 | 2002-10-04 | 390d | 299d |  | finish no earlier than 2002-12-04 | R4 | 3464h | 3117.6h | HSDPA-RF |  |  |  | TSG |  |  | 2480 |

Notes:
- 503: az: WID appr.SA#13. / Text4: Albert YUHAN (VoiceStream Wireless), Michael TRUSS (Motorola)
- 504: Text4: Michael TRUSS (Motorola), Tommy BERGGREN (Telia AB)
- 505: Changed Rapp email / Text4: Karl-Heinz NENNER (T-Mobile)
- 506: Text4: Patrick JURÉ (Lucent Technologies)
- 507: Text4: Thomas TOVINGER (Ericsson)
- 508: Changed Rapp email / Text4: Karl-Heinz NENNER (T-Mobile)
- 509: Text4: Bert Boden (Mannesmann Mobilfunk)
- 510: SP-000162 agreed WI. Rapporteur / Gunnar Hellström, Ericsson Radio Systems AB, / email: gunnar.hellstrom@omnitor.se tel: +46 708 204 288 / Text4: Gunnar Hellström, Ericsson
- 517: Bearer services, new spec document? / This task requires supporting companies before it can start
- 518: Text4: Andrew Harrison, Nortel Networks
- 519: Text4: Olle Franceschi (Ericsson)
- 520: Text4: Janne Vainio (Nokia)
- 522: Text4: Nicolas Drevon, Alcatel
- 523: update WID / 30.11.2001: To CN #14 for approval
- 524: Text4: Ravi Kuchibhotla, Motorola
- 525: Text4: Amitava Ghosh, Motorola
- 526: 30 November: Completion date shifted to March 2002 / Text4: Ravi Kuchibhotla, Motorola
- 527: Text4: Mike Diesen, Motorola
- 528: Text4: Howard Benn, Motorola

| ID | WBS | Task | Type | Duration | Start | Finish | Complete | Remaining | Baseline start | Baseline finish | Baseline duration | Total slack | Free slack | Constraint | Resources | Work | Actual work | Text1 | Text6 | Text7 | Text8 | Text2 | Text4 | Text9 |
| --- | --- | --- | --- | --- | --- | --- | --- | --- | --- | --- | --- | --- | --- | --- | --- | --- | --- | --- | --- | --- | --- | --- | --- | --- |
| 529 | 78 | **Rel-5 Improvements of Radio Interface** |  | 535d | 2000-08-14 A | 2002-08-30 | 89% | 56.7d | 2000-06-19 | 2003-06-30 | 791d | 367d |  |  | RP | 30376h | 27009h | RInImp | NA | TSG | Shinobu |  |  |  |
| 530 | 78.1 | **Base station classification** |  | 480d | 2000-08-14 A | 2002-06-14 A | 100% |  | 2000-08-14 | 2002-12-20 | 615d |  |  |  | R4 | 9208h | 9208h | RInImp-BSClass | Rel5 | TSG |  | BaAS | A. Toskala, Nokia | 1471 |
| 531 | 78.1.1 | TDD Base station classification |  | 410d | 2000-08-14 A | 2002-03-08 A | 100% |  | 2000-08-14 | 2002-03-08 | 410d |  |  | finish no earlier than 2002-03-08 | R4 | 3280h | 3280h | RInImp-BSClass-TDD |  | TSG |  | BaAs | A. Toskala, Nokia | 1477 |
| 532 | 78.1.2 | Base Station Classification for 1.28 Mcps TDD option |  | 261d | 2001-06-15 A | 2002-06-14 A | 100% |  | 2001-06-15 | 2002-06-14 | 261d |  |  | finish no earlier than 2002-06-14 | R4 | 2088h | 2088h | RInImp-BSClass-LCRTDD |  | TSG |  |  | Meik Kottkamp, Siemens |  |
| 533 | 78.2 | Enhancement on the DSCH hard split mode |  | 271d | 2001-03-16 A | 2002-03-29 A | 100% |  | 2001-03-16 | 2002-03-29 | 271d |  |  | finish no earlier than 2002-03-29 | R1 | 2168h | 2168h | RInImp-DSCHhsp | Rel5 | TSG |  |  | Jaeyoel KIM, Samsung | 2469 |
| 534 | 78.3 | Hybrid ARQ II/III |  | 355d | 2000-08-21 A | 2001-12-28 A | 100% |  | 2000-08-21 | 2001-12-28 | 355d |  |  | finish no earlier than 2001-12-28 | R2 | 2840h | 2840h | RInImp-HARQ | Rel5 | TSG |  |  | A. Sitte, Siemens | 1217 |
| 535 | 78.4 | FS on USTS |  | 355d | 2000-08-14 A | 2001-12-21 A | 100% |  | 2000-08-14 | 2001-12-21 | 355d |  |  | finish no earlier than 2001-12-21 | R1 | 2840h | 2840h | RInImp-USTS | Rel5 | TSG |  | BaAS | D. Kim, SK Telecom | 1221 |
| 536 | 78.5 | FS on UE antenna efficency test method performance requirements |  | 255d | 2000-09-25 A | 2001-09-14 A | 100% |  | 2000-09-25 | 2001-09-14 | 255d |  |  | finish no earlier than 2001-09-14 | R4 | 2040h | 2040h | RInImp-UEAnTM | Rel5 | TSG |  |  | O. Edvardsson, Allgon | 1997 |
| 537 | 78.6 | FS on the re-introduction of the downlink SIR measurement |  | 200d | 2001-03-12 A | 2001-12-14 A | 100% |  | 2001-03-12 | 2001-12-14 | 200d |  |  | finish no earlier than 2001-12-14 | R4 | 1600h | 1600h | RInImp-SIR | Rel5 | TSG | Cesar |  | Torgny Palenius, Ericsson | 24002 |
| 538 | 78.7 | FS on mitigating the effect of CPICH interference at the UE |  | 255d | 2001-03-19 A | 2002-03-08 A | 100% |  | 2001-03-19 | 2002-03-08 | 255d |  |  | finish no earlier than 2002-03-08 | R4 | 2040h | 2040h | RInImp-CPICH_Intf | Rel5 | TSG | Cesar |  | Shimon Moshavi, Intel | 24001 |
| 539 | 78.8 | **Conformance Test Spec. improvements in Radio Interface** |  | 140d | 2002-02-18 | 2002-08-30 |  |  | 2002-02-18 | 2002-08-30 | 140d | 367d |  |  | T1 | 3360h |  |  |  |  |  |  |  |  |
| 540 | 78.8.1 | Testing improvement of inter-frequency and inter-system measurement |  | 140d | 2002-02-18 | 2002-08-30 |  |  | 2002-02-18 | 2002-08-30 | 140d | 367d |  | finish no earlier than 2002-08-30 | T1 | 1120h |  |  | Rel5 |  |  |  |  | 2210 |
| 541 | 78.8.2 | Testing Hybrid ARQ II/III |  | 140d | 2002-02-18 | 2002-08-30 |  |  | 2002-02-18 | 2002-08-30 | 140d | 367d |  | finish no earlier than 2002-08-30 | T1 | 1120h |  |  | Rel5 |  |  |  |  | 2211 |
| 542 | 79 | **Rel-5 RAN improvements** |  | 383d | 2001-03-16 A | 2002-09-03 | 94% | 21.75d | 2000-08-21 | 2003-06-30 | 746d | 365d |  |  | RP | 31664h | 28864h | RANimp | NA | TSG | Hans |  |  |  |
| 543 | 79.1 | **RRM optimization for Iur and Iub** |  | 318d | 2001-03-16 A | 2002-06-04 A | 100% |  | 2001-03-16 | 2002-06-28 | 336d |  |  |  | R3 | 8904h | 8904h | RANimp-RRMopt | Rel5 | TSG |  | BaAS | Gert-Jan van Lieshout, Ericsson | 656 |
| 544 | 79.1.1 | Iur common transport channel efficiency optimisation |  | 271d | 2001-03-16 A | 2002-03-29 A | 100% |  | 2001-03-16 | 2002-03-29 | 271d |  |  | finish no earlier than 2002-03-29 | R3 | 2168h | 2168h | RANimp-RRMopt-ctc |  | TSG |  |  | Shahrokh Amirijoo, Ericsson |  |
| 545 | 79.1.2 | Iur neighbouring cell reporting efficiency optimisation |  | 271d | 2001-03-16 A | 2002-03-29 A | 100% |  | 2001-03-16 | 2002-03-29 | 271d |  |  | finish no earlier than 2002-03-29 | R3 | 2168h | 2168h | RANimp-RRMopt-ncr |  | TSG |  |  | Shahrokh Amirijoo, Ericsson |  |
| 546 | 79.1.3 | FS Introduction of direct transport bearers between SRNC and Node-B |  | 253d | 2001-06-15 A | 2002-06-04 A | 100% |  | 2001-06-15 | 2002-06-28 | 271d |  |  | finish no earlier than 2002-06-28 | R3 | 2024h | 2024h | RAN-imp-RRMopt-DTB |  | TSG |  |  | Risto Sepponen, Ericsson |  |
| 547 | 79.2 | RL Timing Adjustment |  | 271d | 2001-03-16 A | 2002-03-29 A | 100% |  | 2001-03-16 | 2002-03-29 | 271d |  |  | finish no earlier than 2002-03-29 | R3 | 2168h | 2168h | RANimp-RLTA | Rel5 | TSG |  |  | Elena Voltolina, Ericsson | 22003 |
| 548 | 79.3 | Separation of resource reservation and radio link activation |  | 271d | 2001-03-16 A | 2002-03-29 A | 100% |  | 2001-03-16 | 2002-03-29 | 271d |  |  | finish no earlier than 2002-03-29 | R3 | 2168h | 2168h | RANimp-SepRR | Rel5 | TSG |  |  | Gert-Jan van Lieshout, Ericsson | 22004 |
| 549 | 79.4 | FS SRNS Relocation Procedure Enhancement |  | 318d | 2001-06-15 A | 2002-09-03 A | 100% |  | 2001-06-15 | 2002-06-28 | 271d |  |  | finish no earlier than 2002-09-06 | R3 | 2544h | 2544h | RANimp-SRNS | Rel5 | TSG |  |  | Olivier Guyot, Nokia |  |
| 550 | 79.5 | FS Improvement of Radio Resource Management across RNS and RNS/PSS |  | 201d | 2001-03-16 A | 2001-12-21 A | 100% |  | 2001-03-16 | 2001-12-21 | 201d |  |  | finish no earlier than 2001-12-21 | R3 | 1608h | 1608h | RANimp-ImpRRM | Rel5 | TSG |  |  | Antti Toskala, Nokia | 22001 |
| 551 | 79.6 | Re-arrangements of Iub transport bearers |  | 271d | 2001-03-16 A | 2002-03-29 A | 100% |  | 2001-03-16 | 2002-03-29 | 271d |  |  | finish no earlier than 2002-03-29 | R3 | 2168h | 2168h | RANimp-TTPS | Rel5 | TSG |  |  | Antti Toskala, Nokia | 22002 |
| 552 | 79.7 | RAB support enhancement for Rel-5 |  | 325d | 2001-04-02 A | 2002-06-28 A | 100% |  | 2001-04-02 | 2002-06-28 | 325d |  |  | finish no earlier than 2002-06-28 | R2 | 2600h | 2600h | RANimp-RABSE5 | Rel5 | TSG |  |  | Juha Mikola, Nokia |  |
| 553 | 79.8 | Beamforming requirements for UE |  | 61d | 2001-09-21 A | 2001-12-14 A | 100% |  | 2001-09-21 | 2001-12-14 | 61d |  |  | finish no earlier than 2001-12-14 | R1 | 488h | 488h | RANimp-BFR-UE | Rel5 | TSG |  |  | Jussi Kähtävä, Nokia |  |
| 554 | 79.9 | Support of Site Selection Diversity Transmission in UTRAN |  | 123d | 2001-12-14 A | 2002-06-04 A | 100% |  | 2001-12-14 | 2002-06-04 | 123d |  |  | finish no earlier than 2002-06-04 | R1 | 984h | 984h | RANimp-SSDT | Rel5 | TSG |  |  | NEC |  |
| 555 | 79.10 | Node B Synchronisation for 1.28 Mcps TDD |  | 271d | 2001-03-16 A | 2002-03-29 A | 100% |  | 2001-03-16 | 2002-03-29 | 271d |  |  | finish no earlier than 2002-03-29 | R1 | 2168h | 2168h | RANimp-NBSLCR | Rel5 | TSG |  |  | Jinling HU, CWTS/CATT | 2472 |
| 556 | 79.11 | Start Testing | milestone | 0d | 2001-12-03 | 2001-12-03 |  |  | 2001-12-03 | 2001-12-03 | 0d | 387d | 21d | start no earlier than 2001-12-03 | MLST |  |  |  |  |  |  |  |  | 1912 |

Notes:
- 534: Stopped at RAN#14; work on this task was performed as part of High Speed Downlink Packet Access feature
- 540: start/finish dates set / Not started due to lack of supporting companies
- 541: start/finish dates set / Not started yet due to lack of supporting companies
- 546: FS was closed and introduction of WI not agreed at RAN #16
- 550: FS was closed and WI was introduced at RAN #14
- 552: RFC 3095 context relocation
- 554: RP-020356

| ID | WBS | Task | Duration | Start | Finish | Predecessors | Complete | Remaining | Baseline start | Baseline finish | Baseline duration | Total slack | Constraint | Resources | Work | Actual work | Text3 | Text9 | Text1 | Text4 | Text6 | Text7 | Text8 | Text2 |
| --- | --- | --- | --- | --- | --- | --- | --- | --- | --- | --- | --- | --- | --- | --- | --- | --- | --- | --- | --- | --- | --- | --- | --- | --- |
| 557 | 79.12 | **Conformance Test Aspects - RAN Improvements** | 175d | 2002-01-01 | 2002-09-02 | 556 |  |  | 2002-01-01 | 2002-09-02 | 175d | 366d |  | T1 | 2800h |  | 0% | 2102 |  |  |  |  |  |  |
| 558 | 79.12.1 | Testing Radio access bearer support enhancments | 175d | 2002-01-01 | 2002-09-02 |  |  |  | 2002-01-01 | 2002-09-02 | 175d | 366d | finish no earlier than 2002-09-02 | T1 | 1400h |  |  | 2222 |  |  |  |  |  |  |
| 559 | 80 | UTRAN Sharing in Connected Mode | 197d | 2001-12-03 A | 2002-09-03 A |  | 100% |  | 2001-12-03 | 2002-07-03 | 153d |  | finish no earlier than 2002-09-06 | R3 | 1576h | 1576h |  |  | NETSHARE | Martin Israelsson, Ericsson | Rel5 |  |  |  |
| 560 | 81 | **Provisioning of IP-based multimedia services** | 977d | 2000-01-03 A | 2003-09-30 |  | 89% | 107.01d | 2000-01-03 | 2002-12-27 | 780d | 85d |  | S1 | 188369h | 153972h |  |  | IMS | Mark Cataldo, Openwave | NA | TSG | MichaelC/Alain |  |
| 561 | 81.1 | **Call control and roaming to support IMS in UMTS** | 640d | 2000-01-03 A | 2002-06-14 |  | 93% | 42.79d | 2000-01-03 | 2002-06-14 | 640d | 422d |  | S2 | 85934.6h | 72546h |  |  | IMS-CCR | Liz Daniel, Lucent | Rel5 | TSG |  |  |
| 562 | 81.1.1 | Stage 1 | 215d | 2000-02-21 A | 2000-12-15 A |  | 100% |  | 2000-02-21 | 2000-12-15 | 215d |  | finish no earlier than 2000-09-21 | S1 | 1720h | 1720h | 22.228 | 1633 |  | Mark Cataldo, Motorola |  |  |  | CCaR |
| 563 | 81.1.2 | Stage 2 (Architecture and Main flows) | 246d | 2000-04-14 A | 2001-03-23 A |  | 100% |  | 2000-04-14 | 2001-03-23 | 246d |  | finish no earlier than 2001-03-23 | S2 | 1968h | 1968h | 23.228 | 1514 |  | Liz Daniel, Lucent |  | TSG |  | CCaR |
| 564 | 81.1.3 | Impact on MM/CC/SM | 400d | 2000-08-28 A | 2002-03-08 A |  | 100% |  | 2000-08-28 | 2002-03-08 | 400d |  | finish no earlier than 2002-03-08 | N1 | 3200h | 3200h |  | 1296 | IMS-CCR-IWMM | Keith Drage, Lucent |  |  |  | CCaR |
| 565 | 81.1.4 | **SIP Call Control protocol for the IMS** | 640d | 2000-01-03 A | 2002-06-14 |  | 93% | 47.72d | 2000-01-03 | 2002-06-14 | 640d | 422d |  | N1 | 74008h | 65451.4h | TS 24.228, TS 24.229, TS 23.218 |  |  | Keith Drage, Lucent |  | TSG |  |  |
| 566 | 81.1.4.1 | IMS signalling flows | 385d | 2000-10-02 A | 2002-03-22 |  | 90% | 38.5d | 2000-10-02 | 2002-03-22 | 385d | 482d | finish no earlier than 2002-03-22 | N1 | 3080h | 2772h | TS 24.228 | 1998 |  |  |  | TSG |  | CCaR |
| 567 | 81.1.4.2 | IMS stage 3 | 385d | 2000-10-02 A | 2002-03-22 |  | 90% | 38.5d | 2000-10-02 | 2002-03-22 | 385d | 482d | finish no earlier than 2002-03-22 | N1 | 3080h | 2772h | TS 24.229 | 1278 |  |  |  | TSG |  | CCaR |
| 568 | 81.1.4.3 | IMS Session Handling; stage 2 | 385d | 2000-10-02 A | 2002-03-22 A |  | 100% |  | 2000-10-02 | 2002-03-22 | 385d |  | finish no earlier than 2002-03-22 | N1 | 3080h | 3080h | TS 23.218 | 2255 |  |  |  | TSG |  |  |
| 569 | 81.1.4.4 | **Main IETF dependencies** | 635d | 2000-01-03 A | 2002-06-07 |  | 94% | 38.43d | 2000-01-03 | 2002-06-07 | 635d | 427d |  | NP | 48600h | 44286.4h |  |  |  |  |  |  |  |  |
| 570 | 81.1.4.4.1 | IETF: draft-ietf-sip-rfc2543bis (Session Initiation Protocol) | 346d | 2000-11-24 A | 2002-03-22 A |  | 100% |  | 2000-11-24 | 2002-03-22 | 346d |  | finish no earlier than 2002-03-22 | N1 | 2768h | 2768h |  |  |  |  |  |  |  |  |
| 571 | 81.1.4.4.2 | IETF: draft-sip-100rel | 346d | 2000-11-24 A | 2002-03-22 A |  | 100% |  | 2000-11-24 | 2002-03-22 | 346d |  | finish no earlier than 2002-03-22 | N1 | 2768h | 2768h |  |  |  |  |  |  |  |  |
| 572 | 81.1.4.4.3 | IETF: draft-sip-manyfolks-resource (Without COMET)(Integration of resource management and SIP) | 382d | 2000-11-24 A | 2002-05-13 A |  | 100% |  | 2000-11-24 | 2002-05-13 | 382d |  | finish no earlier than 2002-05-13 | N1 | 3056h | 3056h |  |  |  |  |  |  |  |  |
| 573 | 81.1.4.4.4 | IETF: draft-ietf-sip-privacy (SIP extensions for caller identity and privacy) | 382d | 2000-11-24 A | 2002-05-13 |  | 90% | 38.2d | 2000-11-24 | 2002-05-13 | 382d | 446d | finish no earlier than 2002-05-13 | N1 | 3056h | 2750.4h |  |  |  |  |  |  |  |  |
| 574 | 81.1.4.4.5 | IETF: draft-ietf-sip-call-auth (SIP extensions for media authorization) | 382d | 2000-11-24 A | 2002-05-13 A |  | 100% |  | 2000-11-24 | 2002-05-13 | 382d |  | finish no earlier than 2002-05-13 | N1 | 3056h | 3056h |  |  |  |  |  |  |  |  |
| 575 | 81.1.4.4.6 | IETF: draft-ietf-sip-events (specific event notification) | 346d | 2000-11-24 A | 2002-03-22 A |  | 100% |  | 2000-11-24 | 2002-03-22 | 346d |  | finish no earlier than 2002-03-22 | N1 | 2768h | 2768h |  |  |  |  |  |  |  |  |
| 576 | 81.1.4.4.7 | IETF: draft-ietf-sip-refer (refer method) | 401d | 2000-11-24 A | 2002-06-07 |  | 90% | 40.1d | 2000-11-24 | 2002-06-07 | 401d | 427d | finish no earlier than 2002-06-07 | N1 | 3208h | 2887.2h |  |  |  |  |  |  |  |  |
| 577 | 81.1.4.4.8 | IETF: draft-ietf-dhc-dhcpv6 (DHCP options for SIP servers) | 382d | 2000-11-24 A | 2002-05-13 |  | 90% | 38.2d | 2000-11-24 | 2002-05-13 | 382d | 446d | finish no earlier than 2002-05-13 | N1 | 3056h | 2750.4h |  |  |  |  |  |  |  |  |
| 578 | 81.1.4.4.9 | IETF: draft-ietf-sip-replaces (SIP replaces header) | 401d | 2000-11-24 A | 2002-06-07 |  | 90% | 40.1d | 2000-11-24 | 2002-06-07 | 401d | 427d | finish no earlier than 2002-06-07 | N1 | 3208h | 2887.2h |  |  |  |  |  |  |  |  |
| 579 | 81.1.4.4.10 | IETF: draft-ietf-avt-rtp-amr (AMR and AMR WB RTP and SDP) | 346d | 2000-11-24 A | 2002-03-22 A |  | 100% |  | 2000-11-24 | 2002-03-22 | 346d |  | finish no earlier than 2002-03-22 | N1 | 2768h | 2768h |  |  |  |  |  |  |  |  |
| 580 | 81.1.4.4.11 | IETF: draft-ietf-mmusic-sdp-new (IPv6 support within SDP) | 580d | 2000-01-03 A | 2002-03-22 |  | 90% | 58d | 2000-01-03 | 2002-03-22 | 580d | 482d | finish no earlier than 2002-03-22 | N1 | 4640h | 4176h |  |  |  |  |  |  |  |  |
| 581 | 81.1.4.4.12 | IETF: draft-ietf-sip-update | 382d | 2000-11-24 A | 2002-05-13 A |  | 100% |  |  |  |  |  | finish no earlier than 2002-05-13 | N1 | 3056h | 3056h |  |  |  |  |  |  |  |  |
| 582 | 81.1.4.4.13 | IETF: draft-jennings-sipping-nai (Network Asserted Identity) | 382d | 2000-11-24 A | 2002-05-13 |  | 90% | 38.2d |  |  |  | 446d | finish no earlier than 2002-05-13 | N1 | 3056h | 2750.4h |  |  |  |  |  |  |  |  |
| 583 | 81.1.4.4.14 | IETF: p-header drafts for 3GPP (Various 3GPP dependencies) | 382d | 2000-11-24 A | 2002-05-13 |  | 80% | 76.4d |  |  |  | 446d | finish no earlier than 2002-05-13 | N1 | 3056h | 2444.8h |  |  |  |  |  |  |  |  |

Notes:
- 558: duration set to 6 months (was 0) / Task not started due to lack of supporting companies
- 559: Formerly 'Shared Network support in connected mode', renamed at RAN #16.
- 560: S1 WI proposed S1-000290 / TR22.976, WI Rapporteur, Mark Cataldo, Motorola
- 562: Issues include e.g.: Roaming requirements, Requirements on supplementary services, Interworking requirements / Text5: 17.-21.7., S1#9, Completion of CR's against 22 series [dates taken from 22.976]
- 563: Issues include e.g.: Mobile IP, RAB selection principles, Optimized VoIP bearer mechanisms, SIP multimedia protocol / Text5: R00 stage 2 at least 80 % complete in TSGS #8 21.-23.6.2000 [WI dates need revision. To be revised by TSG#8]
- 564: Per 26/2-02: This is understood to be the PCO & TFT CRs which CN1 provides to TSGN #15 for approval. If this is correct understanding, then the task is 100 % complete. / Text5: drage@lucent.com
- 565: TSGN_10 approved the change:CN1 - SA2 SIP joint meeting spotted one more place for improvement: work tasks with ID 1998 and 1278 are actually subtasks under of single CN1 WT. One WI has been approved for the CN1 WT with title "SIP Call Control protocol... / Text5: drage@lucent.com
- 566: TS 24.228...
- 567: TS 24.229...
- 568: TS 23.218...
- 580: [DAB 08-03-02] - Needs to be replaced by mmusic SDP IPv6 + rfc2327

| ID | WBS | Task | Duration | Start | Finish | Complete | Remaining | Baseline start | Baseline finish | Baseline duration | Total slack | Constraint | Resources | Work | Actual work | Text2 | Text9 | Text1 | Text3 | Text5 | Text7 | Text6 |
| --- | --- | --- | --- | --- | --- | --- | --- | --- | --- | --- | --- | --- | --- | --- | --- | --- | --- | --- | --- | --- | --- | --- |
| 584 | 81.1.4.5 | **Addressing** | 380d | 2000-10-09 A | 2002-03-22 A | 100% |  | 2000-10-09 | 2002-03-22 | 380d |  |  | S2 | 7744h | 7744h | CCaR | 1290 |  |  |  |  |  |
| 585 | 81.1.4.5.1 | Architectural issues | 235d | 2000-10-09 A | 2001-08-31 A | 100% |  | 2000-10-09 | 2001-08-31 | 235d |  | finish no earlier than 2001-03-16 | S2 | 1880h | 1880h | CCaR | 1291 |  |  |  |  |  |
| 586 | 81.1.4.5.2 | Impact on HSS | 353d | 2000-11-15 A | 2002-03-22 A | 100% |  | 2000-11-15 | 2002-03-22 | 353d |  | finish no earlier than 2002-03-22 | N4 | 2824h | 2824h | CCaR | 1292 |  |  |  |  |  |
| 587 | 81.1.4.6 | **Service Examples** | 304d | 2001-04-17 A | 2002-06-14 | 50% | 152d | 2001-04-17 | 2002-06-14 | 304d | 422d |  | S1 | 4864h | 1502.4h |  |  | IMS-Sex | 22.928 | mcatald1@email.mot.com | TSG |  |
| 588 | 81.1.4.6.1 | IMS Framework Report | 304d | 2001-04-17 A | 2002-06-14 | 50% | 152d | 2001-04-17 | 2002-06-14 | 304d | 422d | finish no earlier than 2002-06-14 | S1 | 2432h | 1216h |  |  | IMS-FrWk | 22.941 | rwohlert@tri.sbc.com | TSG |  |
| 589 | 81.2 | **Access Security for IMS** | 270d | 2001-06-25 A | 2002-07-05 A | 100% |  | 2001-06-25 | 2002-07-05 | 270d |  |  | S3 | 6920h | 6920h |  | 1298 | IMS-ASEC |  | krister.boman@emw.ericsson.se | TSG | Rel5 |
| 590 | 81.2.1 | SA3 task | 270d | 2001-06-25 A | 2002-07-05 A | 100% |  | 2001-06-25 | 2002-07-05 | 270d |  | finish no earlier than 2002-07-05 | S3 | 2160h | 2160h |  |  |  |  |  |  |  |
| 591 | 81.2.2 | IMS impacts on UICC (ISIM application) | 185d | 2001-10-08 A | 2002-06-21 A | 100% |  | 2001-10-08 | 2002-06-21 | 185d |  | finish no earlier than 2002-06-21 | T3 | 1480h | 1480h |  |  |  |  |  |  |  |
| 592 | 81.2.3 | SIP extensions for Integrity protection | 140d | 2001-12-17 A | 2002-06-28 A | 100% |  | 2001-12-17 | 2002-06-28 | 140d |  | finish no earlier than 2002-06-28 | N1 | 1120h | 1120h |  |  |  |  |  |  |  |
| 593 | 81.3 | Security Aspects of Requirement for Network Configuration Independence | 130d | 2001-07-02 A | 2001-12-28 A | 100% |  | 2001-07-02 | 2001-12-28 | 130d |  | finish no earlier than 2001-12-28 | S3 | 1040h | 1040h |  |  | SEC1-NCI |  | hugh.shieh@attws.com | TSG | Rel5 |
| 594 | 81.4 | Lawful interception | 410d | 2000-09-04 A | 2002-03-29 A | 100% |  | 2000-09-04 | 2002-03-29 | 410d |  | finish no earlier than 2002-03-29 | S3 | 3280h | 3280h | CCaR | 1299 | IMS-LI |  | berthold.wilhelm@regtp.de | TSG | Rel5 |
| 595 | 81.5 | Charging and OAM&P for IMS | 383d | 2000-12-25 A | 2002-06-12 A | 100% |  | 2000-12-25 | 2001-12-21 | 260d |  | finish no earlier than 2002-06-12 | S5 | 3064h | 3064h | CCaR | 1303 | IMS-OAM | 32-series | Albert.Yuhan@voicestream.com; Michael.Truss@MOTOROLA.COM | TSG | Rel5 |
| 596 | 81.6 | **Multimedia codecs and protocols for conversational PS services** | 568d | 2000-07-26 A | 2002-09-27 | 94% | 31.29d | 2000-07-26 | 2002-12-06 | 618d | 347d |  | S4 | 15640h | 14778.5h |  |  | IMS-CODEC | 26.235, 26.236 | pasi.s.ojala@nokia.com | TSG | Rel5 |
| 597 | 81.6.1 | Codecs | 427d | 2000-07-26 A | 2002-03-14 A | 100% |  | 2000-07-26 | 2002-03-14 | 427d |  | finish no earlier than 2001-03-21 | S4 | 3416h | 3416h |  | 2039 |  | 26.235, 26.236 |  | TSG |  |
| 598 | 81.6.2 | Transport protocols | 1d | 2002-03-12 A | 2002-03-12 A | 100% |  | 2002-03-12 | 2002-03-12 | 1d |  | finish no earlier than 2002-03-12 | S4 | 8h | 8h |  |  | IMS-CODEC | 26.236 |  |  | Rel5 |
| 599 | 81.6.4 | recommendation for QoS parameter values for various media types | 195d | 2001-12-31 A | 2002-09-27 A | 100% |  | 2001-12-31 | 2002-09-27 | 195d |  | finish no earlier than 2002-09-27 | S4 | 1560h | 1560h |  |  |  |  |  | TSG |  |
| 600 | 81.6.5 | IETF: draft-ietf-sip-digest-aka | 382d | 2000-11-24 A | 2002-05-13 | 90% | 38.2d |  |  |  | 446d | finish no earlier than 2002-05-13 | N1 | 3056h | 2750.4h |  |  |  |  |  |  |  |
| 601 | 81.6.6 | IETF: draft-ietf-sip-sec-agree | 382d | 2000-11-24 A | 2002-05-13 | 90% | 38.2d |  |  |  | 446d | finish no earlier than 2002-05-13 | N1 | 3056h | 2750.4h |  |  |  |  |  |  |  |
| 602 | 81.7 | **SIP message compression** | 185d | 2001-09-24 A | 2002-06-07 | 56% | 81.27d | 2001-09-24 | 2002-06-07 | 185d | 427d |  | S2 | 3128h | 1753.81h |  |  |  |  |  |  | Rel5 |
| 603 | 81.7.1 | Stage 2 | 25d | 2001-09-24 A | 2001-10-26 A | 100% |  | 2001-09-24 | 2001-10-26 | 25d |  | finish no earlier than 2001-10-26 | S2 | 200h | 200h |  |  |  |  |  |  |  |
| 604 | 81.7.2 | Compression signalling | 181d | 2001-09-28 A | 2002-06-07 | 50% | 90.5d | 2001-09-28 | 2002-06-07 | 181d | 427d | finish no earlier than 2002-06-07 | N1 | 1448h | 724h |  |  |  |  |  |  |  |
| 605 | 81.8 | **Stage 3 description of IMS interfaces** | 383d | 2001-03-14 A | 2002-08-30 | 94% | 24.4d | 2001-03-14 | 2002-06-07 | 323d | 367d |  | NP | 29531.6h | 27650.5h |  |  |  |  |  |  | Rel5 |
| 606 | 81.8.1 | Cx interface (HSS to CSCF) | 135.95d | 2001-03-14 A | 2002-06-07 A | 100% |  | 2001-03-14 | 2002-06-07 | 135.95d |  | finish no earlier than 2002-06-07 | N4 | 1087.58h | 1087.58h |  |  |  |  |  | TSG |  |
| 607 | 81.8.2 | Mp interface (MRFC - MRFP) enhancements | 258d | 2001-03-14 A | 2002-03-08 A | 100% |  | 2001-03-14 | 2002-03-08 | 258d |  | finish no earlier than 2002-06-07 | N4 | 2064h | 2064h |  |  |  |  |  |  |  |
| 608 | 81.8.3 | Mw interface (CSCF to P-CSCF) | 323d | 2001-03-14 A | 2002-06-07 | 90% | 32.3d | 2001-03-14 | 2002-06-07 | 323d | 427d | finish no earlier than 2002-06-07 | N1 | 2584h | 2325.6h |  |  |  |  |  |  |  |
| 609 | 81.8.4 | Mr interface (CSCF to MRF) | 273d | 2001-03-14 A | 2002-03-29 A | 100% |  | 2001-03-14 | 2002-03-29 | 273d |  | finish no earlier than 2002-03-29 | N1 | 2184h | 2184h |  |  |  |  |  |  |  |
| 610 | 81.8.5 | Dx interface (I-CSCF to SLF) | 323d | 2001-03-14 A | 2002-06-07 A | 100% |  | 2001-03-14 | 2002-06-07 | 323d |  | finish no earlier than 2002-06-07 | N4 | 2584h | 2584h |  |  |  |  |  |  |  |
| 611 | 81.8.6 | Go interface (GGSN to PCF) | 323d | 2001-03-14 A | 2002-06-07 | 95% | 16.15d | 2001-03-14 | 2002-06-07 | 323d | 427d | finish no earlier than 2002-06-07 | N3 | 2584h | 2454.8h |  |  |  |  |  |  |  |
| 612 | 81.8.7 | ISC (IMS Service Control) Interface | 323d | 2001-03-14 A | 2002-06-07 A | 100% |  | 2001-03-14 | 2002-06-07 | 323d |  | finish no earlier than 2002-06-07 | N1 | 2584h | 2584h |  |  |  |  |  |  |  |
| 613 | 81.8.8 | Sh interface (HSS to AS) | 82d | 2002-02-14 A | 2002-06-07 A | 100% |  | 2002-02-14 | 2002-06-07 | 82d |  | finish no earlier than 2002-06-07 | N4 | 656h | 656h |  |  |  |  |  |  |  |
| 614 | 81.8.9 | Si interface (HSS to IM-SSF) | 162.5d | 2002-01-16 A | 2002-08-30 | 72% | 45d | 2002-01-16 | 2002-06-07 | 102.5d | 367d | finish no earlier than 2002-06-07 | N4 | 1300h | 940h |  |  |  |  |  |  |  |
| 615 | 81.8.10 | Gm interface (UE to CSCF) | 323d | 2001-03-14 A | 2002-06-07 | 90% | 32.3d | 2001-03-14 | 2002-06-07 | 323d | 427d | finish no earlier than 2002-06-07 | N1 | 2584h | 2325.6h |  |  |  |  |  |  |  |
| 616 | 81.8.11 | Mi interface (CSCF to BGCF) | 323d | 2001-03-14 A | 2002-06-07 | 90% | 32.3d | 2001-03-14 | 2002-06-07 | 323d | 427d | finish no earlier than 2002-06-07 | N1 | 2584h | 2325.6h |  |  |  |  |  |  |  |
| 617 | 81.8.12 | Mj interface (BGCF to MGCF) | 323d | 2001-03-14 A | 2002-06-07 | 90% | 32.3d | 2001-03-14 | 2002-06-07 | 323d | 427d | finish no earlier than 2002-06-07 | N1 | 2584h | 2325.6h |  |  |  |  |  |  |  |
| 618 | 81.8.13 | Mk interface (BGCF to BGCF) | 323d | 2001-03-14 A | 2002-06-07 | 90% | 32.3d | 2001-03-14 | 2002-06-07 | 323d | 427d | finish no earlier than 2002-06-07 | N1 | 2584h | 2325.6h |  |  |  |  |  |  |  |
| 619 | 81.9 | Support of VHE/OSA by entities and protocols of the IMS (e.g. CSCF) | 186d | 2001-09-21 A | 2002-06-07 A | 100% |  | 2001-09-21 | 2002-06-07 | 186d |  | finish no earlier than 2002-06-07 | N5 | 1488h | 1488h | CCaR | 1310 | IMS-ONOSA | 29.198, 29.998 | Ard.Jan.Moerdijk@eln.ericsson.se | TSG | Rel5 |

Notes:
- 586: 17th May, KK: This is cover by 29.228 & 29228. Work complete.
- 587: Text4: Mark Cataldo, Motorola
- 588: Text4: Randolph Wohlert, SBC Technology Resources, Inc.
- 589: TS33.203 will be presented for info at SA#14 and is scheduled for approval at SA#15. Dependencies on IETF exist. Approved SA#15 / Text4: Krister Boman, Ericsson
- 590: SHOULD BE DELETED - COVERED BY REAL S3 TASKS
- 591: Text4: Jeremy Norris (Vodafone)
- 592: Per 26/2-02: CN1 is not aware of any requirements and is not doing anything on this task.
- 593: Incorporated into IMS access security TS (33.203) which will be presented for info at SA#14 and is scheduled for approval at SA#15.Editors notes removed SA#16&17 / Text4: Hugh Shieh, AT&T Wireless Services
- 594: Rel-5 33.106 and 33.107 approved at SA#12.Revised WID including new Rel-5 specification (33.108) scheduled for approval at SA#14. 33.108 approved SA#16. CR at SA#17 / Text4: Berthold Wilhelm, Reg TP
- 595: Text4: Albert YUHAN (VoiceStream Wireless), Michael TRUSS (Motorola)
- 596: Text4: B. Aronson, Toshiba, and P. Ojala, Nokia
- 598: Text4: P. Ojala, Nokia
- 606: DAB 12/12/01 to 75% / CN4 14/02/02 to 79% / 17th May work complete. 3GPP TSs 29.228 and 29.229 will be sent for proval in CN#16
- 607: [DAB 08-03-02] - No work required in CN4
- 610: CN4#11 30/11/01: No inputs received in CN4 / 14/02/02 Completed(introduced in 29.228)
- 611: [DAB - 30/07/02] - % complete to 95% (if we exclude Diffserv)
- 613: CN4#11 30/11/01: No inputs received in CN4 / CN4#12bis 14/02/02: WID approved / 17th May 100% complete. 3GPP TS 29.329 will be sent for approval in CN#16
- 614: SA16: Part of Rel5 only if completed in September 02
- 619: Text4: Ard-Jan MOERDIJK (Ericsson)

| ID | WBS | Task | Type | Duration | Start | Finish | Predecessors | Complete | Remaining | Baseline start | Baseline finish | Baseline duration | Total slack | Free slack | Constraint | Resources | Work | Actual work | Text1 | Text2 | Text4 | Text6 | Text9 | Text3 | Text5 | Text7 | Text8 |
| --- | --- | --- | --- | --- | --- | --- | --- | --- | --- | --- | --- | --- | --- | --- | --- | --- | --- | --- | --- | --- | --- | --- | --- | --- | --- | --- | --- |
| 620 | 81.10 | **CAMEL control of IMS services** |  | 365d | 2001-04-16 A | 2002-09-06 |  | 91% | 34.05d | 2001-04-16 | 2002-06-07 | 300d | 362d |  |  | N2 | 9952h | 9023.6h | IMS-CAMEL | CCaR | Angelica Remoquillo, Lucent | Rel5 | 1310 |  |  |  |  |
| 621 | 81.10.1 | Stage2 work 'general' |  | 365d | 2001-04-16 A | 2002-09-06 A |  | 100% |  | 2001-04-16 | 2002-06-07 | 300d |  |  | finish no earlier than 2002-09-06 | N2 | 2920h | 2920h |  |  |  |  |  |  |  |  |  |
| 622 | 81.10.2 | Stage3 work 'CAP' |  | 175d | 2002-01-07 A | 2002-09-06 A |  | 100% |  | 2002-01-07 | 2002-06-07 | 110d |  |  | finish no earlier than 2002-09-06 | N2 | 1400h | 1400h |  |  |  |  |  |  |  |  |  |
| 623 | 81.10.3 | Stage2 work 'Si interface' |  | 175d | 2002-01-07 A | 2002-09-06 A |  | 100% |  | 2002-01-07 | 2002-06-07 | 110d |  |  | finish no earlier than 2002-09-06 | N2 | 1400h | 1400h |  |  |  |  |  |  |  |  |  |
| 624 | 81.10.4 | Stage3 work 'Si interface' |  | 82d | 2002-02-14 A | 2002-06-07 A |  | 100% |  | 2002-02-14 | 2002-06-07 | 82d |  |  | finish no earlier than 2002-06-07 | N4 | 656h | 656h |  |  |  |  |  |  |  |  |  |
| 625 | 81.10.5 | SDM issues for CAMEL control of IMS |  | 82d | 2002-02-14 | 2002-06-07 |  |  |  | 2002-02-14 | 2002-06-07 | 82d | 427d |  | finish no earlier than 2002-06-07 | N4 | 656h |  |  |  |  |  |  |  |  |  |  |
| 626 | 81.11 | Pre-pay/real-time charging in IMS |  | 196d | 2001-06-15 A | 2002-03-15 |  | 60% | 78.4d | 2001-06-15 | 2002-03-15 | 196d | 487d |  | finish no earlier than 2002-03-15 | S1 | 1568h | 940.8h |  |  |  | TBD |  |  |  |  |  |
| 627 | 81.12 | **Charging** |  | 289d | 2001-08-06 A | 2002-09-12 A |  | 100% |  | 2001-08-06 | 2002-06-28 | 235d |  |  |  | S5 | 4624h | 4624h | OAM-CH |  | Karl-Heinz NENNER (T-Mobile) | Rel5 |  | 32.2xy | karl-heinz.nenner@t-mobile.de | TSG |  |
| 628 | 81.12.1 | Charging Implications of IMS architecture |  | 75d | 2001-08-06 A | 2001-11-16 A |  | 100% |  | 2001-08-06 | 2001-11-16 | 75d |  |  | finish no earlier than 2001-11-16 | S2 | 600h | 600h |  |  |  |  |  |  |  |  |  |
| 629 | 81.12.2 | Charging management for IMS (off-line & on-line) |  | 214d | 2001-11-19 A | 2002-09-12 A | 628 | 100% |  | 2001-11-19 | 2002-06-28 | 160d |  |  | finish no earlier than 2002-09-12 | S5 | 1712h | 1712h | OAM-CH |  |  | Rel5 |  |  |  | TSG |  |
| 630 | 81.13 | **Other IETF depencies** |  | 401d | 2000-11-24 A | 2002-06-07 |  | 70% | 120.3d | 2000-11-24 | 2002-06-07 | 401d | 427d |  |  | NP | 9624h | 6736.8h |  |  |  | Rel5 |  |  |  |  |  |
| 631 | 81.13.1 | IETF: draft-ietf-aaa-diameter - should be CN4 |  | 401d | 2000-11-24 A | 2002-06-07 |  | 90% | 40.1d | 2000-11-24 | 2002-06-07 | 401d | 427d |  | finish no earlier than 2002-06-07 | NP | 3208h | 2887.2h |  |  |  |  |  |  |  |  |  |
| 632 | 81.13.2 | IETF: draft-johansson-aaa-diameter-mm-app - should be CN4 |  | 401d | 2000-11-24 A | 2002-06-07 |  | 50% | 200.5d | 2000-11-24 | 2002-06-07 | 401d | 427d |  | finish no earlier than 2002-06-07 | NP | 3208h | 1604h |  |  |  |  |  |  |  |  |  |
| 633 | 81.14 | Start Testing | milestone | 0d | 2002-03-18 | 2002-03-18 |  |  |  | 2002-03-18 | 2002-03-18 | 0d | 282d | 0d | start no earlier than 2002-03-18 | MLST |  |  |  |  |  | Rel5 | 1913 |  |  |  |  |
| 634 | 81.15 | Conformance Test Aspects - Provisioning of IMS |  | 205d | 2002-03-18 | 2002-12-27 | 633 |  |  | 2002-03-18 | 2002-12-27 | 205d | 282d |  | finish no earlier than 2002-12-27 | T1 | 1640h |  | IMS-TEST |  |  |  | 1844 |  |  |  |  |
| 635 | 81.16 | Testing of support for IMS - prose |  | 139d | 2002-09-18 | 2003-03-31 |  |  |  |  |  |  | 216d |  | finish no earlier than 2003-03-31 | T1 | 1112h |  |  |  | Dan Fox, Anritsu | Rel5 |  | 34.108, 34.123 | dan.fox@eu.anritsu.com | TSG |  |
| 636 | 81.17 | Testing of support for IMS - TTCN |  | 270d | 2002-09-18 | 2003-09-30 |  |  |  |  |  |  | 85d |  | finish no earlier than 2003-09-30 | T1 | 2160h |  |  |  | Dan Fox, Anritsu | Rel5 |  | 34.108, 34.123 | dan.fox@eu.anritsu.com | TSG |  |
| 637 | 82 | **Extended Transparent End-to-End PS Streaming Service** |  | 313d? | 2002-01-03 A | 2003-03-17 |  | 86% | 44.84d? | 2001-06-21 | 2002-12-06 | 382d | 226d |  |  | S4 | 6224h | 4687.31h | PSS-E |  | O. Franceschi, Ericsson | Rel5 |  | 26.233, 26.234 | olle.franceschi@nrj.ericsson.se | TSG | Paolo |
| 638 | 82.1 | **Stage 1** |  | 86d? | 2002-11-18 A | 2003-03-17 |  | 65% | 30.1d? | 2001-06-21 | 2001-09-27 | 71d | 226d |  |  | S1 | 1376h | 1015.2h |  |  | Stephen Wolak, VODAFONE Group Plc |  |  | 22.233 | stephen.wolak@vodafone.com | TSG |  |
| 639 | 87.1.1 | Interaction with other services |  | 86d? | 2002-11-18 A | 2003-03-17 |  | 65% | 30.1d? |  |  |  | 226d |  | finish no earlier than 2003-03-17 | S1 | 688h | 447.2h |  |  | Stephen Wolak, VODAFONE Group Plc |  |  | 22.233 | stephen.wolak@vodafone.com | TSG |  |
| 640 | 82.2 | Stage 2 (version Rel5 of TS 26.234) |  | 51d | 2002-01-03 A | 2002-03-14 A |  | 100% |  | 2002-01-03 | 2002-03-14 | 51d |  |  | finish no earlier than 2002-03-26 | S4 | 408h | 408h |  |  |  |  |  | 26.234 |  | TSG |  |
| 641 | 82.3 | RTP usage model |  | 242d | 2002-01-03 A | 2002-12-06 |  | 90% | 24.2d | 2002-01-03 | 2002-12-06 | 242d | 297d |  | finish no earlier than 2002-12-06 | S4 | 1936h | 1742.4h |  |  |  |  |  | 26.937 |  |  |  |
| 642 | 83 | **Rel-5 OSA enhancements** |  | 504d | 2000-07-11 A | 2002-06-14 |  | 95% | 25.55d | 2000-07-11 | 2002-12-13 | 634d | 422d |  |  | S1 | 46736h | 41443.5h | OSA1 |  | Jörg Swetina, SIEMENS AG | NA |  | 22.127, 23.127, 29.198-x, 29.998-x |  | TSG | Adrian Z |
| 643 | 83.1 | General Stage 2 for Rel5 |  | 194d | 2001-09-11 A | 2002-06-07 |  | 47% | 103d | 2001-09-11 | 2002-06-07 | 194d | 427d |  |  | S2 | 1232h | 408h |  |  |  |  | 2116 |  |  |  |  |

Notes:
- 620: SA16: Part of Rel5 only if Si completed in September 02
- 621: DAB 12.12.01 split into cn4 and cn2 parts
- 622: DAB 12.12.01 split into cn4 and cn2 parts
- 623: DAB 12.12.01 split into cn4 and cn2 parts
- 624: [DAB 08-03-02] - UID 12004 is MASTER of UID 14998 / 17 May need to be recearch possible impact on 23.008 & 23.016, changes to 29.002 are done.
- 625: [DAB 08-03-02] - No activity on this in CN4
- 627: Changed Rapp email
- 630: Was introduced at SA#13 by Ileana Leuca (exact position in the WP and related WG have to be defined)
- 634: The task is a building block, individual work items are being considered but are constrained by lack of supporting companies
- 638: 2nd resp SA4
- 639: 2nd resp SA4
- 640: 2nd resp SA2

| ID | WBS | Task | Duration | Start | Finish | Predecessors | Complete | Remaining | Baseline start | Baseline finish | Baseline duration | Total slack | Constraint | Resources | Work | Actual work | Text1 | Text6 | Text7 | Text2 | Text3 | Text4 | Text5 | Text8 | Text9 |
| --- | --- | --- | --- | --- | --- | --- | --- | --- | --- | --- | --- | --- | --- | --- | --- | --- | --- | --- | --- | --- | --- | --- | --- | --- | --- |
| 644 | 83.2 | **OSA APIs for Multimedia Call Control** | 499d | 2000-07-11 A | 2002-06-07 A |  | 100% |  | 2000-07-11 | 2002-06-07 | 499d |  |  | S2 | 5960h | 5960h | OSA1-CSCF | Rel5 | TSG |  |  |  |  |  |  |
| 645 | 83.2.1 | Stage 1 | 438d | 2000-07-11 A | 2002-03-14 A |  | 100% |  | 2000-07-11 | 2002-03-14 | 438d |  | finish no earlier than 2002-03-14 | S1 | 3504h | 3504h |  |  | TSG | Ser | 22.127 | Manfred Leitgeb, SIEMENS AG | Manfred.leitgeb@siemens.at | Michael Clayton | 1430 |
| 646 | 83.2.2 | (Multimedia) Call Control - Stages 2 and 3 | 194d | 2001-09-11 A | 2002-06-07 A |  | 100% |  | 2001-09-11 | 2002-06-07 | 194d |  | finish no earlier than 2002-06-07 | N5 | 1552h | 1552h |  |  | TSG |  | 29.198-04 |  |  |  |  |
| 647 | 83.3 | Generic user interaction - Stage 3 | 194d | 2001-09-11 A | 2002-06-07 A |  | 100% |  | 2001-09-11 | 2002-06-07 | 194d |  | finish no earlier than 2002-06-07 | N5 | 1552h | 1552h |  | Rel5 | TSG |  | 29.198-05 |  |  |  |  |
| 648 | 83.4 | Charging - Stage 3 | 194d | 2001-09-11 A | 2002-06-07 A |  | 100% |  | 2001-09-11 | 2002-06-07 | 194d |  | finish no earlier than 2002-06-07 | N5 | 1552h | 1552h |  | Rel5 | TSG |  | 29.198-12 |  |  |  |  |
| 649 | 83.5 | Call Control Service Mapping; Multiparty Call Control SIP - Stage 3 | 194d | 2001-09-11 A | 2002-06-07 A |  | 100% |  | 2001-09-11 | 2002-06-07 | 194d |  | finish no earlier than 2002-06-07 | N5 | 1552h | 1552h |  | Rel5 | TSG |  | 29.998-04-4 |  |  |  |  |
| 650 | 83.6 | WSDL APIs for SOAP/HTTP - Stage 3 | 455d | 2000-09-11 A | 2002-06-07 A |  | 100% |  | 2000-09-11 | 2002-06-07 | 455d |  | finish no earlier than 2002-06-07 | N5 | 3640h | 3640h |  | Rel5 | TSG |  | 29.198, 29.998 |  |  |  |  |
| 651 | 83.7 | **OSA security** | 504d | 2000-07-11 A | 2002-06-14 |  | 92% | 41.92d | 2000-07-11 | 2002-06-14 | 504d | 422d |  | S3 | 12304h | 11280.6h | OSA1-SEC | Rel5 | TSG | Ser |  | Colin Blanchard, BT | colin.blanchard@bt.com |  | 1419 |
| 652 | 83.7.1 | Stage 1 | 349d | 2000-07-11 A | 2001-11-09 A |  | 100% |  | 2000-07-11 | 2001-11-09 | 349d |  | finish no earlier than 2001-11-09 | S1 | 2792h | 2792h |  |  | TSG |  | 22.127 | Manfred Leitgeb, SIEMENS AG | Manfred.leitgeb@siemens.at | Michael Clayton | 2121 |
| 653 | 83.7.2 | Stage 3 | 430d | 2000-10-23 A | 2002-06-14 |  | 80% | 86d | 2000-10-23 | 2002-06-14 | 430d | 422d | finish no earlier than 2002-06-14 | S3 | 3440h | 2752h |  |  | TSG | Ser | ??? |  |  |  | 1421 |
| 654 | 83.7.3 | security related SCF(s) definition | 186d | 2001-09-21 A | 2002-06-07 A |  | 100% |  | 2001-09-21 | 2002-06-07 | 186d |  | finish no earlier than 2002-06-07 | N5 | 1488h | 1488h |  |  | TSG | Ser | 29.198, 29.998 | Ard-Jan MOERDIJK (Ericsson) | Ard.Jan.Moerdijk@eln.ericsson.se |  | 1422 |
| 655 | 83.7.4 | (possibly) changes required from supporting platforms, e.g. gsmSCF, HLR | 69d | 2000-09-11 A | 2000-12-14 A |  | 100% |  | 2000-09-11 | 2000-12-14 | 69d |  | finish no earlier than 2000-12-14 | S3 | 552h | 552h |  |  | TSG | Ser | ??? |  |  |  | 1423 |
| 656 | 83.8 | **Interactions OSA - e-commerce** | 499d | 2000-07-11 A | 2002-06-07 |  | 96% | 17.51d | 2000-07-11 | 2002-06-07 | 499d | 427d |  | S2 | 6152h | 5976.8h | OSA1-ECOM | Rel5 | TSG |  |  |  |  |  | 1424 |
| 657 | 83.8.1 | Stage 1 | 438d | 2000-07-11 A | 2002-03-14 |  | 95% | 21.9d | 2000-07-11 | 2002-03-14 | 438d | 488d | finish no earlier than 2000-12-28 | S1 | 3504h | 3328.8h |  |  | TSG |  | 22.127 | Jörg Swetina, SIEMENS AG |  |  | 1425 |
| 658 | 83.8.2 | Stages 2 and 3 | 186d | 2001-09-21 A | 2002-06-07 A |  | 100% |  | 2001-09-21 | 2002-06-07 | 186d |  | finish no earlier than 2002-06-07 | N5 | 1488h | 1488h |  |  | TSG |  | 29.198, 29.998 | Ard-Jan MOERDIJK (Ericsson) | Ard.Jan.Moerdijk@eln.ericsson.se |  | 1529 |
| 659 | 83.9 | Policy Management - Stage 3 | 194d | 2001-09-11 A | 2002-06-07 A |  | 100% |  | 2001-09-11 | 2002-06-07 | 194d |  | finish no earlier than 2002-06-07 | N5 | 1552h | 1552h |  | Rel5 | TSG |  | 29.198-13 |  |  |  |  |
| 660 | 83.10 | Presence and Availability Management (PAM) - Stage 3 | 194d | 2001-09-11 A | 2002-06-07 A |  | 100% |  | 2001-09-11 | 2002-06-07 | 194d |  | finish no earlier than 2002-06-07 | N5 | 1552h | 1552h |  | Rel5 | TSG |  | 29.198-14 |  |  |  |  |
| 661 | 83.11 | **CHECK STATUS - LCS - OSA interfaces** | 455d | 2000-09-11 A | 2002-06-07 |  | 99% | 0d | 2000-09-11 | 2002-06-07 | 455d | 0d |  | S1 | 5656h | 2590.4h | OSA1-LCSI | Rel5 | TSG | Ser |  | Jörg Swetina, SIEMENS AG |  |  | 1786 |
| 662 | 83.11.1 | Stage 1 | 65d | 2000-09-11 A | 2000-12-08 A |  | 100% |  | 2000-09-11 | 2000-12-08 | 65d |  | finish no earlier than 2000-12-08 | S1 | 520h | 520h |  |  | TSG | Ser | 22.127 | Jörg Swetina, SIEMENS AG |  |  | 1787 |
| 663 | 83.11.2 | Stage 2 | 1d | 2000-12-11 A | 2000-12-11 A | 662 | 100% |  | 2000-12-11 | 2000-12-11 | 1d |  | finish no earlier than 2000-12-11 | S2 | 8h | 8h |  |  | TSG |  | 23.127 | Christophe GOURRAUD, Ericsson Canada |  |  | 2124 |
| 664 | 83.11.3 | Stage 3 | 186d | 2001-09-21 A | 2002-06-07 A | 663 | 100% |  | 2001-09-21 | 2002-06-07 | 186d |  | finish no earlier than 2002-06-07 | N5 | 1488h | 1488h |  |  | TSG | Ser | 29.198, 29.998 | Ard-Jan MOERDIJK (Ericsson) | Ard.Jan.Moerdijk@eln.ericsson.se |  | 1788 |
| 665 | 84 | **CAMEL phase 4** | 625d | 2000-04-17 A | 2002-09-06 |  | 99% | 0d | 2000-04-17 | 2002-06-14 | 565d | 0d |  | S1 | 41104h | 36244h | CAMEL4 | Rel5 | WG |  |  | Keijo Palviainen, Nokia | keijo.palviainen@nokia.com | Andrijana | 1638 |
| 666 | 84.1 | Service requirements | 565d | 2000-04-17 A | 2002-06-14 A |  | 100% |  | 2000-04-17 | 2002-06-14 | 565d |  | finish no earlier than 2002-06-14 | S1 | 4520h | 4520h |  |  | WG | Ser |  |  |  |  | 1461 |
| 667 | 84.2 | Call Party Handling | 500d | 2000-07-10 A | 2002-06-07 A |  | 100% |  | 2000-07-10 | 2002-06-07 | 500d |  | finish no earlier than 2002-06-07 | N2 | 4000h | 4000h | CAMEL4-CPH |  | WG | Ser |  |  |  |  | 2012 |
| 668 | 84.3 | Mid call procedure for MO and MT calls | 495d | 2000-07-17 A | 2002-06-07 A |  | 100% |  | 2000-07-17 | 2002-06-07 | 495d |  | finish no earlier than 2002-06-07 | N2 | 3960h | 3960h | CAMEL4-MCP |  | WG | Ser |  |  |  |  | 2013 |
| 669 | 84.4 | Interactions with Optimal Routing | 430d | 2000-07-17 A | 2002-03-08 A |  | 100% |  | 2000-07-17 | 2002-03-08 | 430d |  | finish no earlier than 2002-03-08 | N2 | 3440h | 3440h | CAMEL4-IOR |  | WG | Ser |  |  |  |  | 2014 |
| 670 | 84.5 | Inclusion of flexible tone injection | 430d | 2000-07-17 A | 2002-03-08 A |  | 100% |  | 2000-07-17 | 2002-03-08 | 430d |  | finish no earlier than 2002-03-08 | N2 | 3440h | 3440h | CAMEL4-IFTI |  | WG | Ser |  |  |  |  | 2015 |
| 671 | 84.6 | CSE control over MT SMS | 430d | 2000-07-17 A | 2002-03-08 A |  | 100% |  | 2000-07-17 | 2002-03-08 | 430d |  | finish no earlier than 2002-03-08 | N2 | 3440h | 3440h | CAMEL4-CCSMS |  | WG | Ser |  |  |  |  | 2016 |
| 672 | 84.7 | Notification of GPRS mobility management to CSE | 331d | 2001-03-02 A | 2002-06-07 A |  | 100% |  | 2001-03-02 | 2002-06-07 | 331d |  | finish no earlier than 2002-06-07 | N2 | 2648h | 2648h | CAMEL4-NMM |  | WG |  |  |  |  |  | 2460 |
| 673 | 84.8 | Provision of location information of called subscriber | 266d | 2001-03-02 A | 2002-03-08 A |  | 100% |  | 2001-03-02 | 2002-03-08 | 266d |  | finish no earlier than 2002-03-08 | N2 | 2128h | 2128h | CAMEL4-LOCB |  | WG |  |  |  |  |  | 2458 |
| 674 | 84.9 | Inclusion of ODB data in the CSE_HLR interface | 175d | 2001-07-09 A | 2002-03-08 A |  | 100% |  | 2001-07-09 | 2002-03-08 | 175d |  | finish no earlier than 2002-03-08 | N2 | 1400h | 1400h | CAMEL4-ODB |  | WG |  |  |  |  |  |  |
| 675 | 84.10 | Location information during an ongoing call (Handover DP) | 280d | 2001-05-14 A | 2002-06-07 A |  | 100% |  | 2001-05-14 | 2002-06-07 | 280d |  | finish no earlier than 2002-06-07 | N2 | 2240h | 2240h | CAMEL4-HODP |  | WG |  |  |  |  |  |  |
| 676 | 84.11 | GPRS Any Time Interrogation | 240d | 2001-07-09 A | 2002-06-07 A |  | 100% |  | 2001-07-09 | 2002-06-07 | 240d |  | finish no earlier than 2002-06-07 | N2 | 1920h | 1920h | CAMEL4-ATI |  | WG |  |  |  |  |  |  |
| 677 | 84.12 | Transfer of IMEI (with SW version) to CSE | 240d | 2001-07-09 A | 2002-06-07 A |  | 100% |  | 2001-07-09 | 2002-06-07 | 240d |  | finish no earlier than 2002-06-07 | N2 | 1920h | 1920h | CAMEL4-ATI |  | WG |  |  |  |  |  |  |
| 678 | 84.13 | Handling of partial implementations of CAMEL4 | 131d | 2002-03-08 A | 2002-09-06 A |  | 100% |  | 2002-03-08 | 2002-06-07 | 66d |  | finish no earlier than 2002-06-07 | N2 | 1048h | 1048h | CAMEL4-SUB |  | WG |  |  |  |  |  |  |

Notes:
- 644: For Rel5 even if completed by March
- 651: CR to correct security specifications in 29.198 scheduled for approval at CN#15
- 653: ??
- 661: az: CN#13 - changed to Rel5
- 663: az 24/05/01: Rel4 completion 90->100%.
- 674: Added on May 29, 2001
- 678: stage2 and stage3 CRs for approval at CN#17

| ID | WBS | Task | Type | Duration | Start | Finish | Predecessors | Complete | Remaining | Baseline start | Baseline finish | Baseline duration | Total slack | Constraint | Resources | Work | Actual work | Text1 | Text2 | Text6 | Text7 | Text8 | Text9 | Text3 | Text4 | Text5 |
| --- | --- | --- | --- | --- | --- | --- | --- | --- | --- | --- | --- | --- | --- | --- | --- | --- | --- | --- | --- | --- | --- | --- | --- | --- | --- | --- |
| 679 | 85 | **Rel-5 MExE enhancements** |  | 250d | 2001-03-26 A | 2002-03-08 A |  | 100% |  | 2001-02-21 | 2002-06-20 | 347d |  |  | T2 | 2880h | 2880h | MEXE5 | Ter | Rel5 | TSG | Friedhelm | 2464 |  |  |  |
| 680 | 85.1 | MExE Rel-5 Improvements and Investigations |  | 110d | 2001-03-26 A | 2002-03-08 A |  | 100% |  | 2001-03-26 | 2002-03-08 | 110d |  | finish no earlier than 2001-12-17 | T2 | 880h | 880h | MEXE5-ENHANC | Ter |  | TSG |  | 2466 | 22.057, 23.057 | Mark CATALDO, Motorola | mcatald1@MOTOROLA.COM |
| 681 | 86 | **Wideband Telephony Service - AMR** |  | 761d | 2000-01-01 A | 2002-12-02 |  | 87% | 101.88d | 2000-01-01 | 2002-12-02 | 761d | 301d |  | S4 | 77416h | 64394.9h | AMRWB |  | Rel5 | TSG | Paolo |  |  | Imre Varga, Siemens AG | Imre.Varga@mch.siemens.de |
| 682 | 86.1 | **Specification** |  | 704d | 2000-01-01 A | 2002-09-12 |  | 99% | 0.4d | 2000-01-01 | 2002-06-28 | 650d | 358d |  | S4 | 22512h | 22481.9h |  |  |  |  |  |  |  |  |  |
| 683 | 86.1.1 | Stage 1 |  | 125d | 2001-10-01 A | 2002-03-22 A |  | 100% |  | 2001-10-01 | 2002-03-22 | 125d |  | finish no earlier than 2002-03-22 | S1 | 1000h | 1000h |  |  |  |  |  |  |  |  |  |
| 684 | 86.1.2 | **Stage 2** |  | 76d | 2000-01-03 A | 2000-04-17 A |  | 100% |  | 2000-01-03 | 2000-04-17 | 76d |  |  | S4 | 1224h | 1224h |  |  |  |  |  |  |  |  |  |
| 685 | 86.1.2.1 | Design Constraints |  | 26d | 2000-01-03 A | 2000-02-07 A |  | 100% |  | 2000-01-03 | 2000-02-07 | 26d |  |  | S4 | 208h | 208h |  | Cod |  |  |  | 1459 |  |  |  |
| 686 | 86.1.2.2 | General Description |  | 51d | 2000-02-07 A | 2000-04-17 A | 685 | 100% |  | 2000-02-07 | 2000-04-17 | 51d |  | start no earlier than 2000-09-25 | S4 | 408h | 408h |  | Cod |  |  |  | 1460 |  |  |  |
| 687 | 86.1.3 | Feasibility Study |  | 26d | 2000-04-28 A | 2000-06-02 A | 686 | 100% |  | 2000-04-28 | 2000-06-02 | 26d |  | finish no earlier than 2000-06-02 | S4 | 208h | 208h |  | Cod |  | TSG |  | 1626 | TR 26.901 |  |  |
| 688 | 86.1.4 | N1 Aspects |  | 66d | 2001-09-21 A | 2001-12-21 A |  | 100% |  | 2001-09-21 | 2001-12-21 | 66d |  | finish no earlier than 2001-12-21 | N1 | 528h | 528h |  |  |  | TSG |  | 1656 |  |  |  |
| 689 | 86.1.5 | N4 work |  | 83d | 2002-02-13 A | 2002-06-07 A |  | 100% |  | 2002-02-13 | 2002-06-07 | 83d |  | finish no earlier than 2002-06-07 | N4 | 664h | 664h |  |  |  | TSG |  | 1656 |  |  |  |
| 690 | 86.1.6 | **Codec issues** |  | 704d | 2000-01-03 A | 2002-09-12 |  | 99% | 0.54d | 2000-01-03 | 2002-06-28 | 650d | 358d |  | S4 | 11504h | 11496h |  |  |  |  |  |  |  |  |  |
| 691 | 86.1.6.1 | Codec qualification |  | 86d | 2000-02-01 A | 2000-05-30 A |  | 100% |  | 2000-02-01 | 2000-05-30 | 86d |  | finish no earlier than 2000-05-31 | S4 | 688h | 688h |  | Cod |  | TSG |  | 1627 |  |  |  |
| 692 | 86.1.6.2 | Codec selection tests |  | 102d | 2000-06-01 A | 2000-10-20 A | 691 | 100% |  | 2000-06-01 | 2000-10-20 | 102d |  | finish no earlier than 2000-10-20 | S4 | 816h | 816h |  | Cod |  |  |  | 74 |  |  |  |
| 693 | 86.1.6.3 | Codec selection |  | 5d | 2000-10-23 A | 2000-10-27 A | 692 | 100% |  | 2000-10-23 | 2000-10-27 | 5d |  | finish no earlier than 2000-10-27 | S4 | 40h | 40h |  | Cod |  |  |  | 891 |  |  |  |
| 694 | 86.1.6.4 | TFO AMR-WB |  | 63d | 2001-12-18 A | 2002-03-14 A |  | 100% |  | 2001-12-18 | 2002-03-14 | 63d |  | finish no earlier than 2002-03-14 | S4 | 504h | 504h | AMRWB-TFO |  |  |  |  |  |  |  |  |
| 695 | 86.1.6.5 | Other codec issues (verif., caracterisation) |  | 441d | 2000-09-29 A | 2002-06-07 A |  | 100% |  | 2000-09-29 | 2002-06-07 | 441d |  | finish no earlier than 2002-06-07 | S4 | 3528h | 3528h |  | Cod |  |  |  | 890 | TR 26.976 |  |  |
| 696 | 86.1.6.6 | AMR-WB and narrrowband interworking |  | 121d | 2001-09-27 A | 2002-03-14 A |  | 100% |  | 2001-09-27 | 2002-03-14 | 121d |  | finish no earlier than 2002-03-14 | S4 | 968h | 968h | AMRWB-IWG |  |  |  |  |  |  |  |  |
| 697 | 86.1.6.7 | Interworking with fixed broadband networks |  | 121d | 2001-09-27 A | 2002-03-14 A |  | 100% |  | 2001-09-27 | 2002-03-14 | 121d |  | finish no earlier than 2002-03-14 | S4 | 968h | 968h |  |  |  |  |  |  |  |  |  |
| 698 | 86.1.6.8 | Tones and announcements |  | 121d | 2001-09-27 A | 2002-03-14 A |  | 100% |  | 2001-09-27 | 2002-03-14 | 121d |  | finish no earlier than 2002-03-14 | S4 | 968h | 968h |  |  |  |  |  |  |  |  |  |
| 699 | 86.1.6.9 | WB Conferencing and WB Voice Group calls |  | 1d | 2000-01-03 | 2000-01-03 |  |  |  | 2000-01-03 | 2000-01-03 | 1d | 1061d | finish no earlier than 2000-01-03 | S1 | 8h |  |  |  |  |  |  |  |  |  |  |
| 700 | 86.1.6.10 | Billing, accounting and call detail record aspects |  | 251d | 2001-09-27 A | 2002-09-12 A |  | 100% |  | 2001-09-27 | 2002-06-28 | 197d |  | finish no earlier than 2002-09-12 | S5 | 2008h | 2008h |  |  | Rel5 |  |  |  | 32.2xy | Karl-Heinz NENNER (T-Mobile) | Karl-Heinz.Nenner@T-MOBILE.DE |
| 701 | 86.1.7 | Start Testing | milestone | 0d | 2002-02-25 | 2002-02-25 |  |  |  | 2002-02-25 | 2002-02-25 | 0d | 502d | start no earlier than 2002-02-25 | MLST |  |  |  |  |  |  |  | 1989 |  |  |  |
| 702 | 86.1.8 | **Conformance tests (CRs to 34 series)** |  | 73d | 2000-01-01 A | 2000-04-12 A | 701 | 100% |  | 2000-01-01 | 2000-04-12 | 73d |  |  | T1 | 1752h | 1752h |  | Cod |  |  |  | 1855 |  |  |  |
| 703 | 86.1.8.1 | **Terminal Acoustic Characteristics** |  | 73d | 2000-01-01 A | 2000-04-12 A |  | 100% |  | 2000-01-01 | 2000-04-12 | 73d |  |  | S4 | 1168h | 1168h |  | Cod |  |  |  | 76 |  |  |  |
| 704 | 86.1.8.1.1 | Definition |  | 21d | 2000-01-01 A | 2000-01-31 A |  | 100% |  | 2000-01-01 | 2000-01-31 | 21d |  | finish no earlier than 2000-01-28 | S4 | 168h | 168h |  | Cod |  | TSG |  | 1628 | 26.131 |  |  |
| 705 | 86.1.8.1.2 | Test specification |  | 52d | 2000-02-01 A | 2000-04-12 A | 704 | 100% |  | 2000-02-01 | 2000-04-12 | 52d |  | finish no earlier than 2000-03-13 | S4 | 416h | 416h |  | Cod |  | TSG |  | 1629 | 26.132 |  |  |
| 706 | 86.2 | Floating-point ANSI-C code for the AMR-WB speech codec |  | 123d | 2001-09-25 A | 2002-03-14 A |  | 100% |  | 2001-09-25 | 2002-03-14 | 123d |  | finish no earlier than 2002-03-14 | S4 | 984h | 984h | AMRWB-FP |  |  | TSG |  |  | TS 26.204 | J. Vainio (Nokia) | janne.m.vainio@nokia.com |

Notes:
- 687: S4,TD SP-000024: TR 26.901 v.4.0.0
- 688: Some of N1 tasks: Indication of supported codecs by the MS, Bearer cap negociation, codec indication to MS... / One common set of codec negotiation procedures will be specified as in ID1657.
- 689: CN4#11 30/11/01: No inputs to CN4 at this meeting / 14/02/02 work started 50% reached / 17 May work is done 100%
- 695: ANSI C-Code , Test Sequences, Speech Transcoding Functions, Error Concealment of lost frames, Source Controlled Bit-Rate Operation, Voice Activity Detector, Frame Structure

| ID | WBS | Task | Duration | Start | Finish | Complete | Remaining | Baseline start | Baseline finish | Baseline duration | Total slack | Constraint | Resources | Work | Actual work | Text1 | Text2 | Text7 | Text8 | Text9 | Text3 | Text4 | Text5 | Text6 |
| --- | --- | --- | --- | --- | --- | --- | --- | --- | --- | --- | --- | --- | --- | --- | --- | --- | --- | --- | --- | --- | --- | --- | --- | --- |
| 707 | 86.3 | **Support of AMR-WB in GERAN: GMSK and 8PSK WB FR / HR** | 650d | 2000-01-03 A | 2002-06-28 A | 100% |  | 2000-01-03 | 2002-06-28 | 650d |  |  | GP | 23480h | 23480h | GAMRWB | Cod | TSG | Paolo | 80 |  |  |  |  |
| 708 | 86.3.1 | Channel coding in 45.003 | 590d | 2000-01-03 A | 2002-04-05 A | 100% |  | 2000-01-03 | 2002-04-05 | 590d |  |  | GP | 4720h | 4720h |  |  | TSG |  | 2265 |  |  |  |  |
| 709 | 86.3.2 | Signalling for the A interface | 390d | 2000-01-03 A | 2001-06-29 A | 100% |  | 2000-01-03 | 2001-06-29 | 390d |  | finish no earlier than 2001-06-29 | GP | 3120h | 3120h |  |  | TSG |  | 2266 |  |  |  |  |
| 710 | 86.3.3 | Signalling for Iu | 650d | 2000-01-03 A | 2002-06-28 A | 100% |  | 2000-01-03 | 2002-06-28 | 650d |  | finish no earlier than 2002-06-28 | GP | 5200h | 5200h |  |  | TSG |  | 2267 |  |  |  |  |
| 711 | 86.3.4 | Receiver performance in TS 45.005 | 325d | 2001-04-02 A | 2002-06-28 A | 100% |  | 2001-04-02 | 2002-06-28 | 325d |  | finish no earlier than 2002-06-28 | GP | 2600h | 2600h |  |  | TSG |  | 2268 |  |  |  |  |
| 712 | 86.3.5 | Link Adaptation in 45.009 | 330d | 2001-03-26 A | 2002-06-28 A | 100% |  | 2001-03-26 | 2002-06-28 | 330d |  | finish no earlier than 2002-06-28 | GP | 2640h | 2640h |  |  |  |  |  |  |  |  |  |
| 713 | 86.4 | **GERAN MS conformance test for AMR-WB** | 761d | 2000-01-03 | 2002-12-02 |  |  | 2000-01-03 | 2002-12-02 | 761d | 301d |  | GP | 12176h |  |  |  | TSG | Paolo | 2269 |  |  |  |  |
| 714 | 86.4.1 | MS test | 761d | 2000-01-03 | 2002-12-02 |  |  | 2000-01-03 | 2002-12-02 | 761d | 301d | finish no earlier than 2002-12-02 | GP | 6088h |  |  |  | TSG |  | 2270 |  |  |  |  |
| 715 | 86.5 | **GERAN BTS conformance test for AMR-WB** | 761d | 2000-01-03 A | 2002-12-02 A | 100% |  | 2000-01-03 | 2002-12-02 | 761d |  |  | GP | 12176h | 12176h |  |  | TSG | Paolo | 2271 |  |  |  |  |
| 716 | 86.5.1 | BTS test | 761d | 2000-01-03 A | 2002-12-02 A | 100% |  | 2000-01-03 | 2002-12-02 | 761d |  | finish no earlier than 2002-12-02 | GP | 6088h | 6088h |  |  | TSG |  | 2272 |  |  |  |  |
| 717 | 87 | Terminal local model enhancements | 223d | 2001-05-14 A | 2002-03-20 A | 100% |  | 2001-05-14 | 2002-03-20 | 223d |  | finish no earlier than 2002-03-20 | T2 | 1784h | 1784h | TLM5 | Ter | TSG |  | 1832 | 23.227 | Olga Tomé, Ericsson | Olga.Tome@ECS.ERICSSON.SE | Rel5 |
| 718 | 88 | **Rel-5 Location Services enhancements** | 716d | 2000-04-03 A | 2002-12-30 | 82% | 126.7d | 2000-04-03 | 2003-06-30 | 846d | 281d |  | S2 | 162303h | 140289h | LCS1 |  | TSG | Alain |  |  | Jan Kall, Nokia |  | Rel5 |
| 719 | 88.1 | **UE positioning** | 315d | 2001-01-15 A | 2002-03-29 | 99% | 0d | 2000-08-28 | 2003-06-30 | 741d | 0d |  | RP | 5560h | 5368.13h | LCS1-UEpos |  | TSG |  | 1600 |  |  |  | NA |
| 720 | 88.1.1 | UE positioning enhancements for 1.28 Mcps TDD | 255d | 2001-04-09 A | 2002-03-29 A | 100% |  | 2001-04-09 | 2002-03-29 | 255d |  | finish no earlier than 2002-03-29 | R2 | 2040h | 2040h | LCS-128Pos |  | TSG |  | 2474 |  | Xiaohua Mei, CATT |  | Rel5 |
| 721 | 88.1.2 | Open SMLC-SRNC Interface within the UTRAN to support A-GPS Positioning | 195d | 2001-01-15 A | 2001-10-12 A | 100% |  | 2001-01-15 | 2001-10-12 | 195d |  |  | R2 | 1560h | 1560h | LCS-INTF |  | TSG |  | 2125 |  | Kirk Burroughs, Qualcomm |  | Rel5 |
| 722 | 88.2 | **Event based and Periodic LCS** | 535d | 2000-05-22 A | 2002-06-07 | 88% | 62.67d | 2000-05-22 | 2002-06-07 | 535d | 427d |  | S1 | 6288h | 5551.48h | LCS1-EBP | Loc |  |  | 1171 |  |  |  | Rel5 |
| 723 | 88.2.1 | Stage 1 | 130d | 2000-05-22 A | 2000-11-17 A | 100% |  | 2000-05-22 | 2000-11-17 | 130d |  | finish no earlier than 2000-07-21 | S1 | 1040h | 1040h |  | Loc |  |  | 1641 | 22.071 | Randolph Wohlert, Pacific Bell Wireless | rwohlert@tri.sbc.com |  |
| 724 | 88.2.2 | Stage 2 specification | 60d | 2000-11-06 A | 2001-01-26 | 51% | 29.4d | 2000-11-06 | 2001-01-26 | 60d | 782d | finish no earlier than 2001-01-26 | S2 | 480h | 244.8h |  | Loc |  |  | 1538 |  |  |  |  |
| 725 | 88.2.3 | Impact on MAP | 61d | 2002-03-15 A | 2002-06-07 A | 100% |  | 2002-03-15 | 2002-06-07 | 61d |  | finish no earlier than 2002-06-07 | N4 | 488h | 488h |  | Loc |  |  | 1179 |  |  |  |  |
| 726 | 88.3 | **Location Services for GERAN in A/Gb Mode** | 485d | 2000-04-03 A | 2002-02-08 A | 100% |  | 2000-04-03 | 2002-02-08 | 485d |  |  | GP | 24032h | 24032h | LCS-GERAN |  | TSG | Paolo | 2436 |  |  |  | Rel5 |
| 727 | 88.3.1 | GERAN LCS Stage 2 (first release) | 485d | 2000-04-03 A | 2002-02-08 A | 100% |  | 2000-04-03 | 2002-02-08 | 485d |  | finish no earlier than 2002-02-08 | GP; S2; G1; G2 | 13152h | 13152h |  |  | TSG |  | 2437 |  |  |  |  |
| 728 | 88.3.2 | Gb interface support for LCS | 370d | 2000-04-03 A | 2001-08-31 A | 100% |  | 2000-04-03 | 2001-08-31 | 370d |  | finish no earlier than 2001-08-31 | GP | 2960h | 2960h |  |  | TSG |  | 2438 |  |  |  |  |
| 729 | 88.3.3 | L3 protocol support for LCS | 305d | 2000-04-03 A | 2001-06-01 A | 100% |  | 2000-04-03 | 2001-06-01 | 305d |  | finish no earlier than 2001-06-01 | GP | 2440h | 2440h |  |  | TSG |  | 2440 |  |  |  |  |
| 730 | 88.3.4 | Stage 3 specifications | 305d | 2000-04-03 A | 2001-06-01 A | 100% |  | 2000-04-03 | 2001-06-01 | 305d |  | finish no earlier than 2001-06-01 | GP | 2440h | 2440h |  |  | TSG |  | 2441 |  |  |  |  |

Notes:
- 713: Not started
- 715: Not started
- 721: Finished at RAN#13
- 723: Evaluate Event based and Periodic LCS to be included in R00, corresponding Stage 1 description
- 725: Possible impact on UTRAN of LCS quality level request / 17 May No stage 2 for event-based & periodic LCS. Work 100% completefor current stage 2

| ID | WBS | Task | Duration | Start | Finish | Complete | Remaining | Baseline start | Baseline finish | Baseline duration | Total slack | Constraint | Resources | Work | Actual work | Text6 | Text7 | Text8 | Text9 | Text1 | Text2 | Text3 | Text5 |
| --- | --- | --- | --- | --- | --- | --- | --- | --- | --- | --- | --- | --- | --- | --- | --- | --- | --- | --- | --- | --- | --- | --- | --- |
| 731 | 88.4 | **Location Services for GERAN in Iu Mode** | 585d | 2000-04-03 A | 2002-06-28 A | 100% |  | 2000-04-03 | 2002-06-28 | 585d |  |  | GP | 78498.6h | 78498.6h | Rel5 | TSG | Paolo |  |  |  |  |  |
| 732 | 88.4.1 | GERAN LCS Stage 2 | 585d | 2000-04-03 A | 2002-06-28 A | 100% |  | 2000-04-03 | 2002-06-28 | 585d |  | finish no earlier than 2002-06-28 | GP; R2; R3; S2; G1; G2 | 22880.9h | 22880.9h |  | TSG |  | 2443 |  |  |  |  |
| 733 | 88.4.2 | Iu-ps interface support for LCS | 585d | 2000-04-03 A | 2002-06-28 A | 100% |  | 2000-04-03 | 2002-06-28 | 585d |  | finish no earlier than 2002-06-28 | GP; R2; R3; S2; G1; G2 | 19000.9h | 19000.9h |  | TSG |  |  |  |  |  |  |
| 734 | 88.4.3 | Iu-cs interface support for LCS | 585d | 2000-04-03 A | 2002-06-28 A | 100% |  | 2000-04-03 | 2002-06-28 | 585d |  | finish no earlier than 2002-06-28 | GP; R2; R3; S2; G1; G2 | 19000.9h | 19000.9h |  | TSG |  | 2445 |  |  |  |  |
| 735 | 88.4.4 | Iur-g interface support for LCS | 62.5d | 2002-01-23 A | 2002-04-19 A | 100% |  | 2002-01-23 | 2002-04-19 | 62.5d |  | finish no earlier than 2002-04-19 | GP; R2; R3; S2; G1; G2 | 3000h | 3000h |  | TSG |  | 2446 |  |  |  |  |
| 736 | 88.4.5 | RRC protocol support for LCS | 75d | 2001-08-20 A | 2001-11-30 A | 100% |  | 2001-08-20 | 2001-11-30 | 75d |  | finish no earlier than 2001-11-30 | GP; R2; R3; S2; G1; G2 | 3600h | 3600h |  | TSG |  | 2447 |  |  |  |  |
| 737 | 88.4.6 | Additional impacts on Broadcast of LCS data on packet channels | 77.5d | 2001-08-20 A | 2001-12-05 A | 100% |  | 2001-08-20 | 2001-12-05 | 77.5d |  | finish no earlier than 2001-12-05 | GP; R2; R3; S2; G1; G2 | 3000h | 3000h |  | TSG |  | 2448 |  |  |  |  |
| 738 | 88.4.7 | Stage 3 specifications | 69.5d | 2002-03-25 A | 2002-06-28 A | 100% |  | 2002-03-25 | 2002-06-28 | 69.5d |  | finish no earlier than 2002-06-28 | GP; R2; R3; S2; G1; G2 | 3336h | 3336h |  | TSG |  | 2449 |  |  |  |  |
| 739 | 88.5 | **GERAN MS Conformance test for LCS** | 131d | 2002-06-03 | 2002-12-02 |  |  | 2001-11-30 | 2002-12-02 | 262d | 301d |  | GP | 5240h |  |  |  |  |  | LCS-GERAN-MSconf |  |  |  |
| 740 | 88.5.1 | Develop LCS MS test case work plan (Release 98/99/4) | 131d | 2002-06-03 | 2002-12-02 |  |  | 2001-11-30 | 2002-12-02 | 262d | 301d | finish no earlier than 2002-12-02 | G4; G5 | 2096h |  |  |  |  |  |  |  |  |  |
| 741 | 88.5.2 | Develop LCS MS test cases | 131d | 2002-06-03 | 2002-12-02 |  |  | 2001-11-30 | 2002-12-02 | 262d | 301d | finish no earlier than 2002-12-02 | G4; G5 | 2096h |  |  |  |  |  |  |  |  |  |
| 742 | 88.6 | **GERAN BTS Conformance test for LCS** | 131d | 2002-06-03 | 2002-12-02 |  |  | 2001-11-30 | 2002-12-02 | 262d | 301d |  | GP | 5240h |  |  |  |  |  | LCS-GERAN-BTSconf |  |  |  |
| 743 | 88.6.1 | Develop LCS BTS test case work plan (Release 98/99/4) | 131d | 2002-06-03 | 2002-12-02 |  |  | 2001-11-30 | 2002-12-02 | 262d | 301d | finish no earlier than 2002-12-02 | G4; G5 | 2096h |  |  |  |  |  |  |  |  |  |
| 744 | 88.6.2 | Develop LCS BTS test cases | 131d | 2002-06-03 | 2002-12-02 |  |  | 2001-11-30 | 2002-12-02 | 262d | 301d | finish no earlier than 2002-12-02 | G4; G5 | 2096h |  |  |  |  |  |  |  |  |  |
| 745 | 88.7 | LCS interoperation stage 2 aspects | 480d | 2000-08-28 A | 2002-06-28 | 17% | 400.8d | 2000-08-28 | 2002-06-28 | 480d | 412d |  | S2 | 3840h | 633.6h |  |  |  | 544 |  | Loc |  |  |
| 746 | 88.8 | **LCS interoperability aspects to GERAN** | 480d | 2000-08-28 A | 2002-06-28 A | 100% |  | 2000-08-28 | 2002-06-28 | 480d |  |  | GP | 19632h | 19632h | Rel5 | TSG | Paolo | 2434 | LCS-GERAN |  |  |  |
| 747 | 88.8.1 | Co-ordinated development of GSM LCS Phase 2 and UMTS LCS, S2 and GERAN | 480d | 2000-08-28 A | 2002-06-28 A | 100% |  | 2000-08-28 | 2002-06-28 | 480d |  | finish no earlier than 2002-06-28 | GP; S2; S5; R2; R3; G2; G1 | 15792h | 15792h |  | TSG |  | 2435 | LCS-GERAN |  |  |  |
| 748 | 88.9 | FS on LCS support in the IMS | 90d | 2001-02-12 A | 2002-01-18 | 28% | 65d | 2001-02-12 | 2002-01-18 | 90d | 527d | start no earlier than 2001-02-12 | S1 | 720h | 200h |  |  |  | 1183 |  | Loc |  |  |
| 749 | 88.10 | Charging and OAM&P for LCS enhancements | 201d | 2001-09-21 A | 2002-06-28 A | 100% |  | 2001-09-21 | 2002-06-28 | 201d |  | finish no earlier than 2002-06-28 | S5 | 1608h | 1608h | Rel5 | TSG |  | 519 | LCS1-OAM |  | 32-series | Albert.Yuhan@voicestream.com; Michael.Truss@MOTOROLA.COM |
| 750 | 88.11 | New security aspects of LCS (not identified) | 446d | 2000-04-14 A | 2001-12-28 A | 100% |  | 2000-04-14 | 2001-12-28 | 446d |  | finish no earlier than 2001-12-28 | S3 | 3568h | 3568h | Rel5 |  |  | 521 | LCS1-SEC | Loc |  | valtteri.niemi@nokia.com |
| 751 | 88.12 | Specification for the Le Interface | 45d | 2002-01-14 A | 2002-03-15 A | 100% |  | 2002-01-14 | 2002-03-15 | 45d |  | start no earlier than 2002-01-14 | S2 | 360h | 360h | Rel5 | TSG |  |  | LCS1-Le |  |  |  |
| 752 | 88.13 | CHECK STATUS - Inter-GMLC interface | 153d | 2002-05-30 | 2002-12-30 |  |  | 2002-05-30 | 2002-12-30 | 153d | 281d | finish no earlier than 2002-12-30 | S2 | 1224h |  |  |  |  |  |  |  |  |  |
| 753 | 89 | **Rel-5 Security enhancements** | 615d | 2000-02-21 A | 2002-06-28 | 99% | 4.24d | 2000-01-03 | 2002-12-06 | 765d | 412d |  | S3 | 29974.9h | 28337.4h | NA | TSG | Maurice |  | SEC1 |  |  | Peter.Howard@vodafone.com |
| 754 | 89.1 | **Network domain security** | 615d | 2000-02-21 A | 2002-06-28 | 99% | 4.24d | 2000-02-21 | 2002-06-28 | 615d | 412d |  | S3 | 25054.9h | 23451.3h | Rel5 | TSG |  | 1576 | SEC1-NDS | Sec |  | Geir-myrdahl.koien@telenor.com |
| 755 | 89.1.1 | **Control plane protection in core network (e.g., GTP, CAP, MAP/IP, provided by IPsec)** | 541d | 2000-05-12 A | 2002-06-07 | 99% | 0d | 2000-05-12 | 2002-06-07 | 541d | 0d |  | S3 | 7118.9h | 5722.99h |  |  |  | 1577 |  | Sec |  |  |
| 756 | 89.1.1.1 | Main aspects | 290d | 2000-05-12 A | 2001-06-21 A | 100% |  | 2000-05-12 | 2001-06-21 | 290d |  | finish no earlier than 2001-06-21 | S3 | 2320h | 2320h |  |  |  | 1578 |  | Sec |  |  |
| 757 | 89.1.1.2 | Integration of GTP signalling security architecture | 191d | 2001-09-14 A | 2002-06-07 A | 100% |  | 2001-09-14 | 2002-06-07 | 191d |  | finish no earlier than 2002-06-07 | N4 | 1528h | 1528h |  |  |  | 1579 |  | Sec |  |  |

Notes:
- 735: FFS
- 742: Not started
- 749: Text4: Albert YUHAN (VoiceStream Wireless), Michael TRUSS (Motorola)
- 750: 14/09/00: End date 28/12/01 WI may need to be split to improve on this date. S3#17 15% complete. No progress since S3#17 / Text4: Valtteri Niemi, Nokia
- 753: Added BB UE authentication and rapporteur added. TO BE DELETED / Text4: Peter Howard, Vodafone
- 754: S3#17: All due in Rel5. (WI Update at S3#18). Replaced by NDS-IP and NDS-MAP. TO BE DELETED OR MOVED TO HISTORY FILE / Text4: Geir M. Køien, Telenor
- 756: TO BE DELETED
- 757: Waiting for input from SA3! / 14/02/2002 requirements are not clear/not received / 17 May 100% complete

| ID | WBS | Task | Duration | Start | Finish | Predecessors | Complete | Remaining | Baseline start | Baseline finish | Baseline duration | Total slack | Constraint | Resources | Work | Actual work | Text2 | Text9 | Text1 | Text3 | Text5 | Text7 | Text6 | Text8 |
| --- | --- | --- | --- | --- | --- | --- | --- | --- | --- | --- | --- | --- | --- | --- | --- | --- | --- | --- | --- | --- | --- | --- | --- | --- |
| 758 | 89.1.2 | **User plane protection in core network (e.g., provided by IPsec)** | 615d | 2000-02-21 A | 2002-06-28 |  | 98% | 11.41d | 2000-02-21 | 2002-06-28 | 615d | 412d |  | S3 | 9360h | 9186.29h | Sec | 1580 |  |  |  |  |  |  |
| 759 | 89.1.2.1 | Main aspects | 349d | 2000-02-21 A | 2001-06-21 A |  | 100% |  | 2000-02-21 | 2001-06-21 | 349d |  | finish no earlier than 2001-06-21 | S3 | 2792h | 2792h | Sec | 1581 |  |  |  |  |  |  |
| 760 | 89.1.2.2 | Integration of GTP signalling security architecture | 206d | 2001-09-14 A | 2002-06-28 |  | 95% | 10.3d | 2001-09-14 | 2002-06-28 | 206d | 412d | finish no earlier than 2002-06-28 | N4 | 1648h | 1565.6h | Sec | 1582 |  |  |  |  |  |  |
| 761 | 89.1.3 | IP network layer security (NDS/IP) | 457d | 2000-06-15 A | 2002-03-15 A |  | 100% |  | 2000-06-15 | 2002-03-15 | 457d |  | finish no earlier than 2002-03-15 | S3 | 3656h | 3656h |  |  | SEC1-NDS-IP | TS 33.210 | Geir-myrdahl.koien@telenor.com | WG |  |  |
| 762 | 90 | **Intra Domain Connection of RAN Nodes to Multiple CN Nodes** | 455d | 2000-10-02 A | 2002-06-28 A |  | 100% |  | 2000-01-03 | 2002-06-28 | 650d |  |  | S2 | 15136h | 15136h |  |  | IUFLEX | 23.236 |  | TSG | Rel5 | Alain |
| 763 | 90.1 | Overall System Architecture | 188d | 2001-01-03 A | 2001-09-21 A |  | 100% |  | 2001-01-03 | 2001-09-21 | 188d |  | finish no earlier than 2001-06-01 | S2 | 1504h | 1504h |  | 2244 |  |  |  | TSG |  |  |
| 764 | 90.2 | Stage 3: RAN node selecting CN node | 130d | 2001-09-24 A | 2002-03-22 A | 763 | 100% |  | 2001-09-24 | 2002-03-22 | 130d |  | finish no earlier than 2002-03-22 | R3 | 1040h | 1040h |  |  |  |  |  | TSG |  |  |
| 765 | 90.3 | N1 work | 205d | 2001-09-17 A | 2002-06-28 A |  | 100% |  | 2000-01-03 | 2001-03-14 | 313d |  | start no earlier than 2001-09-17 | N1 | 1640h | 1640h |  |  |  | 24.008 and check 29.018 |  | TSG |  |  |
| 766 | 90.4 | N4 work | 375d | 2000-10-02 A | 2002-03-08 A |  | 100% |  | 2000-10-02 | 2002-03-08 | 375d |  | finish no earlier than 2002-03-15 | N4 | 3000h | 3000h |  | 2249 |  |  |  | TSG |  |  |
| 767 | 90.5 | **GERAN work for Intra Domain Connection of RAN Nodes to Multiple CN Nodes** | 101d | 2002-02-08 A | 2002-06-28 A |  | 100% |  | 2002-02-08 | 2002-06-28 | 101d |  |  | GP | 4848h | 4848h |  |  | IDCRAN-GERAN |  | ingemar.backlund@era.ericsson.se |  | Rel5 |  |
| 768 | 90.5.1 | Stage 2 (changes to ) | 101d | 2002-02-08 A | 2002-06-28 A |  | 100% |  | 2002-02-08 | 2002-06-28 | 101d |  | finish no earlier than 2002-06-28 | G1 | 808h | 808h |  |  |  |  |  |  |  |  |
| 769 | 90.5.2 | 43.051 Introduction of support for IDNNS in GERAN Iu mode | 101d | 2002-02-08 A | 2002-06-28 A |  | 100% |  | 2002-02-08 | 2002-06-28 | 101d |  | finish no earlier than 2002-06-28 | G1 | 808h | 808h |  |  |  |  |  |  |  |  |
| 770 | 90.5.3 | Stage 3 (changes to ) | 101d | 2002-02-08 A | 2002-06-28 A |  | 100% |  | 2002-02-08 | 2002-06-28 | 101d |  | finish no earlier than 2002-06-28 | G2 | 808h | 808h |  |  |  |  |  |  |  |  |
| 771 | 90.5.4 | 48.016 Use of Gb interface concepts when a network applies IDNNS | 101d | 2002-02-08 A | 2002-06-28 A |  | 100% |  | 2002-02-08 | 2002-06-28 | 101d |  | finish no earlier than 2002-06-28 | G2 | 808h | 808h |  |  |  |  |  |  |  |  |
| 772 | 90.5.5 | 48.018 Include MSC/VLR identity in CS IMSI paging | 101d | 2002-02-08 A | 2002-06-28 A |  | 100% |  | 2002-02-08 | 2002-06-28 | 101d |  | finish no earlier than 2002-06-28 | G2 | 808h | 808h |  |  |  |  |  |  |  |  |
| 773 | 91 | **GERAN improvements 3 (new transport layer on interface A)** | 446d | 2001-04-06 | 2002-12-20 |  |  |  | 2001-04-06 | 2002-06-28 | 321d | 287d |  | GP | 14272h |  |  | 2320 | GEIMP3 |  |  | TSG | Rel5 | Paolo |
| 774 | 91.1 | **Evolution of the transport for A** | 446d | 2001-04-06 | 2002-12-20 |  |  |  | 2001-04-06 | 2002-06-28 | 321d | 287d |  | GP | 10704h |  |  | 2321 | GEIMP3-EtA |  |  | TSG |  | Paolo |
| 775 | 91.1.1 | Definition of a new A/Ater interface Transport Layer option based on the Iu Interface Transport Layer | 446d | 2001-04-06 | 2002-12-20 |  |  |  | 2001-04-06 | 2002-06-28 | 321d | 287d | finish no earlier than 2002-12-20 | GP | 3568h |  |  | 2322 |  |  |  | TSG |  |  |
| 776 | 91.1.2 | Adaptation of the Layer 3 BSSMAP procedures as required | 446d | 2001-04-06 | 2002-12-20 |  |  |  | 2001-04-06 | 2002-06-28 | 321d | 287d | finish no earlier than 2002-12-20 | GP | 3568h |  |  | 2323 |  |  |  | TSG |  |  |
| 777 | 92 | **Rel-5 Charging and OAM&P** | 264d | 2001-09-10 A | 2002-09-12 A |  | 100% |  | 2001-09-10 | 2002-06-28 | 210d |  |  | S5 | 9976h | 9976h |  |  | OAM | 32-series | Albert.Yuhan@voicestream.com; Michael.Truss@MOTOROLA.COM | TSG | NA | Adrian |
| 778 | 92.1 | Rel5 Principles, high level Requirements and Architecture | 205d | 2001-09-17 A | 2002-06-28 A |  | 100% |  | 2001-09-17 | 2002-06-28 | 205d |  | finish no earlier than 2002-06-28 | S5 | 1640h | 1640h | BCaM | 2089 | OAM-AR/PR | 32.101, 32.102 | Michael.Truss@MOTOROLA.COM | TSG | Rel5 |  |
| 779 | 92.2 | Rel5 Performance Management | 259d | 2001-09-17 A | 2002-09-12 A |  | 100% |  | 2001-09-17 | 2002-06-28 | 205d |  | finish no earlier than 2002-09-12 | S5 | 2072h | 2072h | BCaM | 2088 | OAM-PM | 32.4xy, 52.402 | toche@NORTELNETWORKS.COM | TSG | Rel5 |  |
| 780 | 92.3 | Rel5 Charging Management | 264d | 2001-09-10 A | 2002-09-12 A |  | 100% |  | 2001-09-10 | 2002-06-28 | 210d |  | finish no earlier than 2002-09-12 | S5 | 2112h | 2112h |  | 2083 | OAM-CH | 32.2xy | Karl-Heinz.Nenner@T-MOBILE.DE | TSG | Rel5 |  |
| 781 | 92.4 | Rel5 Network Infrastructure Management | 255d | 2001-09-21 A | 2002-09-12 A |  | 100% |  | 2001-09-21 | 2002-06-28 | 201d |  | finish no earlier than 2002-09-12 | S5 | 2040h | 2040h |  |  | OAM-NIM | 32.6xy, 32.3xy | Thomas.Tovinger@emw.ericsson.se | TSG | Rel5 |  |

Notes:
- 758: TO BE DELETED
- 759: ??
- 760: 14/02/2002 requirements are not clear/not received
- 761: TS 33.210 will be presented for info at SA#14 and is scheduled for approval at SA#15. 2002/12: All IPsec RFCs are stable STD Track RFCs. WID updated SA#17 / Text4: Geir M. Køien, Telenor
- 762: No clear indication on the end date. Put to Rel5 by AS. / Text4: Stephen Terrill, Ericsson
- 764: Not identified / Text4: Brendan McWilliams, Vodafone
- 766: DAB 12.12.01 - % complete to 66% / 14/02/02 Work completed
- 767: Accept changes Gb over IP / Text4: Ingemar Backlund, Ericsson
- 771: Closed, accept changes for Gb over IP
- 773: TERMINATED - NOT STANDARDIZED
- 774: TERMINATED - NOT STANDARDIZED
- 775: TERMINATED - NOT STANDARDIZED
- 776: TERMINATED - NOT STANDARDIZED
- 777: Text4: Albert YUHAN (VoiceStream Wireless), Michael TRUSS (Motorola)
- 778: Text4: Michael TRUSS (Motorola)
- 779: Text4: Christian TOCHE (Nortel Networks)
- 780: Text4: Karl-Heinz NENNER (T-Mobile)
- 781: Text4: Thomas TOVINGER (Ericsson)

| ID | WBS | Task | Duration | Start | Finish | Predecessors | Complete | Remaining | Baseline start | Baseline finish | Baseline duration | Total slack | Constraint | Resources | Work | Actual work | Text6 | Text8 | Text9 | Text1 | Text5 | Text7 | Text2 |
| --- | --- | --- | --- | --- | --- | --- | --- | --- | --- | --- | --- | --- | --- | --- | --- | --- | --- | --- | --- | --- | --- | --- | --- |
| 782 | 93 | **GERAN enhancements for streaming services 1 (RLC enhancements)** | 430d | 2000-11-06 A | 2002-06-28 A |  | 100% |  | 2000-11-06 | 2002-06-28 | 430d |  |  | GP | 8944h | 8944h | Rel5 | Paolo | 2392 |  |  |  |  |
| 783 | 93.1 | Concept | 258d | 2000-11-06 A | 2001-10-31 A |  | 100% |  | 2000-11-06 | 2001-10-31 | 258d |  | finish no earlier than 2001-10-31 | GP | 2064h | 2064h |  |  | 2394 |  |  |  |  |
| 784 | 93.2 | RLC protocol enhancement (SDU Discard) | 430d | 2000-11-06 A | 2002-06-28 A |  | 100% |  | 2000-11-06 | 2002-06-28 | 430d |  | finish no earlier than 2002-06-28 | GP | 3440h | 3440h |  |  | 2395 |  |  |  |  |
| 785 | 94 | **GERAN enhancements for streaming services 2 (usage of ECSD)** | 430d | 2000-11-06 A | 2002-06-28 |  | 99% | 0d | 2000-11-06 | 2002-06-28 | 430d | 0d |  | GP | 19840h | 16400h | Rel5 | Paolo | 2396 |  |  |  |  |
| 786 | 94.1 | Usage of ECSD Concept | 380d | 2000-11-06 A | 2002-04-19 A |  | 100% |  | 2000-11-06 | 2002-04-19 | 380d |  | finish no earlier than 2002-04-19 | GP | 3040h | 3040h |  |  | 2398 |  |  |  |  |
| 787 | 94.2 | Stage 2 | 380d | 2000-11-06 A | 2002-04-19 A |  | 100% |  | 2000-11-06 | 2002-04-19 | 380d |  | finish no earlier than 2002-04-19 | GP | 3040h | 3040h |  |  | 2399 |  |  |  |  |
| 788 | 94.3 | Stage 3 | 430d | 2000-11-06 A | 2002-06-28 A |  | 100% |  | 2000-11-06 | 2002-06-28 | 430d |  | finish no earlier than 2002-06-28 | GP | 3440h | 3440h |  |  | 2400 |  |  |  |  |
| 789 | 94.4 | RLC PDU formats | 430d | 2000-11-06 A | 2002-06-28 A |  | 100% |  | 2000-11-06 | 2002-06-28 | 430d |  | finish no earlier than 2002-06-28 | GP | 3440h | 3440h |  |  | 2401 |  |  |  |  |
| 790 | 94.5 | MAC header | 430d | 2000-11-06 A | 2002-06-28 A |  | 100% |  | 2000-11-06 | 2002-06-28 | 430d |  | finish no earlier than 2002-06-28 | GP | 3440h | 3440h |  |  | 2402 |  |  |  |  |
| 791 | 95 | **GERAN/UTRAN interface evolution 1 (evolution of Iu PS)** | 476d | 2000-09-01 A | 2002-06-28 A |  | 100% |  | 2000-09-01 | 2002-06-28 | 476d |  |  | GP; R3 | 17825.6h | 17825.6h | Rel5 | Paolo | 2412 | GERUEV1 |  |  |  |
| 792 | 95.1 | **Evolution of Iu ps** | 476d | 2000-09-01 A | 2002-06-28 A |  | 100% |  | 2000-09-01 | 2002-06-28 | 476d |  |  | GP; R3 | 12205.6h | 12205.6h |  |  | 2413 | GERUEV1-IuPS |  |  |  |
| 793 | 95.1.1 | Identification of GERAN requirements on Iu ps | 326d | 2000-09-01 A | 2001-11-30 A |  | 100% |  | 2000-09-01 | 2001-11-30 | 326d |  | finish no earlier than 2001-11-30 | GP; R3 | 4185.6h | 4185.6h |  |  | 2414 |  |  |  |  |
| 794 | 95.1.2 | Update of specifications | 150d | 2001-12-03 A | 2002-06-28 A | 793 | 100% |  | 2001-12-03 | 2002-06-28 | 150d |  | finish no earlier than 2002-06-28 | GP; R3 | 2400h | 2400h |  |  | 2415 |  |  |  |  |
| 795 | 96 | **GERAN/UTRAN interface evolution 2 (evolution of Iu CS)** | 476d | 2000-09-01 A | 2002-06-28 A |  | 100% |  | 2000-09-01 | 2002-06-28 | 476d |  |  | GP; R3 | 23025.6h | 23025.6h | Rel5 | Paolo | 2416 | GERUEV2 |  |  |  |
| 796 | 96.1 | **Evolution of Iu cs** | 476d | 2000-09-01 A | 2002-06-28 A |  | 100% |  | 2000-09-01 | 2002-06-28 | 476d |  |  | GP; R3 | 17845.6h | 17845.6h |  | Paolo | 2417 | GERUEV2-IuCS |  |  |  |
| 797 | 96.1.1 | Identification of GERAN requirements on Iu cs | 426d | 2000-09-01 A | 2002-04-19 A |  | 100% |  | 2000-09-01 | 2002-04-19 | 426d |  | finish no earlier than 2002-04-19 | GP; R3 | 5049.6h | 5049.6h |  |  | 2418 |  |  |  |  |
| 798 | 96.1.2 | Update of specifications | 476d | 2000-09-01 A | 2002-06-28 A |  | 100% |  | 2000-09-01 | 2002-06-28 | 476d |  | finish no earlier than 2002-06-28 | GP; R3 | 7616h | 7616h |  |  | 2419 |  |  |  |  |
| 799 | 97 | **End to End QoS for PS Domain including IMS** | 480d | 2000-08-28 A | 2002-06-28 |  | 97% | 13.22d | 2000-08-28 | 2002-06-28 | 480d | 412d |  | S2 | 9856h | 9584.49h | Rel5 | Alain |  | E2EQoS | Johnson.oyama@era.ericcson.se | TSG |  |
| 800 | 97.1 | E2E QoSConcept and Architecture | 178d | 2001-01-03 A | 2001-09-07 A |  | 100% |  | 2001-01-03 | 2001-09-07 | 178d |  | finish no earlier than 2001-09-07 | S2 | 1424h | 1424h |  |  |  |  |  | TSG |  |
| 801 | 97.2 | E2E QoS interworking | 465d | 2000-08-28 A | 2002-06-07 |  | 95% | 23.25d | 2000-08-28 | 2002-06-07 | 465d | 427d | finish no earlier than 2002-06-07 | N3 | 3720h | 3534h |  |  |  | E2EQoS-IW | yokota@lucent.com | WG |  |
| 802 | 97.3 | QoS Management (Provisioning and Monitoring) | 201d | 2001-09-21 A | 2002-06-28 A |  | 100% |  | 2001-09-21 | 2002-06-28 | 201d |  | finish no earlier than 2002-06-28 | S5 | 1608h | 1608h | Rel5 |  |  | E2EQoS-OAM | Albert.Yuhan@voicestream.com; Michael.Truss@MOTOROLA.COM | TSG |  |
| 803 | 98 | **Messaging enhancements Rel-5** | 256d | 2001-06-15 A | 2002-06-07 |  | 75% | 65.08d | 2001-06-15 | 2002-06-07 | 256d | 427d |  | T2 | 13936h | 7742.17h | Rel5 | Friedhelm | 1818 | MESS5 |  | TSG | Mes |
| 804 | 98.1 | **Multimedia Messaging (MMS) enhancements** | 256d | 2001-06-15 A | 2002-06-07 |  | 73% | 69.18d | 2001-06-15 | 2002-06-07 | 256d | 427d |  | T2 | 8312h | 4579.2h |  |  | 1819 | MESS5-MMS | Josef.Laumen@SAL.SIEMENS.DE | TSG | Mes |
| 805 | 98.1.1 | Definition of service requirements | 196d | 2001-06-15 A | 2002-03-15 |  | 90% | 19.6d | 2001-06-15 | 2002-03-15 | 196d | 487d | finish no earlier than 2002-03-15 | S1 | 1568h | 1411.2h | Rel5 |  |  | MESS5-SR | Josef.Laumen@SAL.SIEMENS.DE |  |  |
| 806 | 98.1.2 | Technical realization | 256d | 2001-06-15 A | 2002-06-07 |  | 95% | 12.8d | 2001-06-15 | 2002-06-07 | 256d | 427d | finish no earlier than 2002-06-07 | T2 | 2048h | 1945.6h |  |  |  |  | Josef.Laumen@SAL.SIEMENS.DE |  |  |
| 807 | 98.1.3 | WAP Forum dependency: MM1 stage 3 | 256d | 2001-06-15 A | 2002-06-07 |  | 30% | 179.2d | 2001-06-15 | 2002-06-07 | 256d | 427d | finish no earlier than 2002-06-07 | T2 | 2048h | 614.4h |  |  |  |  |  |  |  |
| 808 | 98.1.4 | MMS formats and codecs | 75d | 2001-12-03 A | 2002-03-15 A |  | 100% |  | 2001-12-03 | 2002-03-15 | 75d |  | finish no earlier than 2002-03-15 | S4 | 600h | 600h |  |  |  |  |  |  |  |

Notes:
- 785: AWS, Nokia, Ericsson, Nortel, Siemens, Motorola, Vodafone / Text4: Frank Muller, Ericsson
- 791: SBC, Motorola, Nokia, Ericsson, Nortel / Text4: Marc Grant , SBC
- 796: Lucent, Ericsson, AWS, Nortel / Text4: Krishna Balachandran, Lucent
- 799: Text4: Johnson Oyama, Ericsson
- 800: Text3: 23.207
- 801: [DAB - 30/07/02] - % complete to 95% (if we exclude Diffserv) / Text3: 29.208, 29.207, 27.060, 29.061, 24.008, 24.228, , 24.229, 29.060, 29.163 / Text4: Daisuke Yokota, Lucent
- 802: Text3: 32-series / Text4: Albert YUHAN (VoiceStream Wireless), Michael TRUSS (Motorola)
- 803: support of UAProf, so this in my opinion is 100% complete
- 804: Text4: Josef Laumen, Siemens
- 805: Text3: 22.140 / Text4: Josef Laumen, Siemens
- 806: stage 3 MM7 is missing / Text3: 23.140 / Text4: Josef Laumen, Siemens
- 808: Text3: 26.140

| ID | WBS | Task | Duration | Start | Finish | Complete | Remaining | Baseline start | Baseline finish | Baseline duration | Total slack | Constraint | Resources | Work | Actual work | Text1 | Text2 | Text3 | Text4 | Text5 | Text7 | Text9 | Text6 | Text8 |
| --- | --- | --- | --- | --- | --- | --- | --- | --- | --- | --- | --- | --- | --- | --- | --- | --- | --- | --- | --- | --- | --- | --- | --- | --- |
| 809 | 98.2 | **Enhanced Messaging Service (EMS) enhancements** | 191d | 2001-06-15 A | 2002-03-08 | 79% | 39.24d | 2001-06-15 | 2002-03-08 | 191d | 492d |  | T2 | 3584h | 1641.6h | MESS5-EMS | Mes | 23.040 | Alan Baldwin, Ericsson | Alan.Baldwin@EML.ERICSSON.SE | TSG | 1820 |  |  |
| 810 | 98.2.1 | Definition of service requirements | 66d | 2001-06-15 A | 2001-09-14 | 20% | 52.8d | 2001-06-15 | 2001-09-14 | 66d | 617d | finish no earlier than 2001-09-14 | S1 | 528h | 105.6h |  |  |  | Alan Baldwin, Ericsson | Alan.Baldwin@EML.ERICSSON.SE |  |  |  |  |
| 811 | 98.2.2 | Technical realization | 191d | 2001-06-15 A | 2002-03-08 A | 100% |  | 2001-06-15 | 2002-03-08 | 191d |  | finish no earlier than 2002-03-08 | T2 | 1528h | 1528h |  |  | 23.040 | Alan Baldwin, Ericsson | Alan.Baldwin@EML.ERICSSON.SE |  |  |  |  |
| 812 | 99 | **GERAN Inter BSC NACC improvements over the Gb Interface** | 215d | 2001-09-03 A | 2002-06-28 A | 100% |  | 2001-09-03 | 2002-06-28 | 215d |  |  | GP | 11184h | 11184h | GERNACC |  |  |  |  |  |  | Rel5 | Paolo |
| 813 | 99.1 | **Modification of core network protocols for GERAN Inter BSC NACC over Gb Interface** | 165d | 2001-09-03 A | 2002-04-19 A | 100% |  | 2001-09-03 | 2002-04-19 | 165d |  |  | N4; S2 | 7048h | 7048h | GERNACC-Cnmod |  |  |  |  |  |  |  |  |
| 814 | 99.1.1 | Stage 2 - Concept | 43d | 2001-09-03 A | 2001-10-31 A | 100% |  | 2001-09-03 | 2001-10-31 | 43d |  | finish no earlier than 2001-10-31 | N4; S2 | 688h | 688h |  |  |  |  |  |  |  |  |  |
| 815 | 99.1.2 | Stage 2 - 23.060 change - Definition of Inter BSC NACC | 165d | 2001-09-03 A | 2002-04-19 A | 100% |  | 2001-09-03 | 2002-04-19 | 165d |  | finish no earlier than 2002-04-19 | N4; S2 | 2640h | 2640h |  |  |  |  |  |  |  |  |  |
| 816 | 99.1.3 | Stage 3 (changes to TS 29.060) | 135d | 2001-09-03 A | 2002-03-08 A | 100% |  | 2001-09-03 | 2002-03-08 | 135d |  | finish no earlier than 2002-03-08 | N4 | 1080h | 1080h |  |  |  |  |  |  |  |  |  |
| 817 | 99.2 | **Modification of Gb protocols for GERAN Inter BSC NACC over Gb Interface** | 151d | 2001-11-30 A | 2002-06-28 A | 100% |  | 2001-11-30 | 2002-06-28 | 151d |  |  | GP | 2416h | 2416h | GERNACC-Gbmod |  |  |  |  |  |  |  |  |
| 818 | 99.2.1 | Stage 3 (changes to TS 48.018) | 151d | 2001-11-30 A | 2002-06-28 A | 100% |  | 2001-11-30 | 2002-06-28 | 151d |  | finish no earlier than 2002-06-28 | GP | 1208h | 1208h |  |  |  |  |  |  |  |  |  |
| 819 | 100 | **Enhanced Power Control** | 280d | 2001-11-26 A | 2002-12-20 | 1% | 277.43d | 2001-11-26 | 2002-06-28 | 155d | 287d |  | GP | 6600h | 60.55h | EPC |  |  |  |  |  |  | Rel5 |  |
| 820 | 100.1 | Realization of Enhanced power control and signaling support | 5d | 2001-11-26 A | 2001-11-30 A | 100% |  | 2001-11-26 | 2001-11-30 | 5d |  | finish no earlier than 2001-11-30 | GP | 40h | 40h |  |  |  |  |  |  |  |  |  |
| 821 | 100.2 | GERAN MS Conformance test for Enhanced Power Control | 270d | 2001-12-10 | 2002-12-20 |  |  | 2001-12-10 | 2002-06-28 | 145d | 287d | finish no earlier than 2002-12-20 | GP | 2160h |  |  |  |  |  |  |  |  |  |  |
| 822 | 100.3 | GERAN BTS Conformance test for Enhanced Power Control | 270d | 2001-12-10 | 2002-12-20 |  |  | 2001-12-10 | 2002-06-28 | 145d | 287d | finish no earlier than 2002-12-20 | GP | 2160h |  |  |  |  |  |  |  |  |  |  |
| 823 | 101 | **8PSK AMR HR** | 270d | 2001-12-10 A | 2002-12-20 | 84% | 42.88d | 2001-12-10 | 2002-06-28 | 145d | 287d |  | GP | 16920h | 14416.9h | 8PSK-AH |  |  |  |  |  |  | Rel5 | Paolo |
| 824 | 101.1 | **Definition of channel coding, performance requirements and signaling support** | 145d | 2001-12-10 A | 2002-06-28 A | 100% |  | 2001-12-10 | 2002-06-28 | 145d |  |  | GP | 10440h | 10440h |  |  |  |  |  |  |  |  |  |
| 825 | 101.1.1 | Concept | 145d | 2001-12-10 A | 2002-06-28 A | 100% |  | 2001-12-10 | 2002-06-28 | 145d |  | finish no earlier than 2002-06-28 | GP | 1160h | 1160h |  |  |  |  |  |  |  |  |  |
| 826 | 101.1.2 | Changes to 44.018 | 145d | 2001-12-10 A | 2002-06-28 A | 100% |  | 2001-12-10 | 2002-06-28 | 145d |  | finish no earlier than 2002-06-28 | G2 | 1160h | 1160h |  |  |  |  |  |  |  |  |  |
| 827 | 101.1.3 | Changes to 45.001 | 145d | 2001-12-10 A | 2002-06-28 A | 100% |  | 2001-12-10 | 2002-06-28 | 145d |  | finish no earlier than 2002-06-28 | G1 | 1160h | 1160h |  |  |  |  |  |  |  |  |  |
| 828 | 101.1.4 | Changes to 45.002 | 145d | 2001-12-10 A | 2002-06-28 A | 100% |  | 2001-12-10 | 2002-06-28 | 145d |  | finish no earlier than 2002-06-28 | G1 | 1160h | 1160h |  |  |  |  |  |  |  |  |  |
| 829 | 101.1.5 | Changes to 45.003 | 145d | 2001-12-10 A | 2002-06-28 A | 100% |  | 2001-12-10 | 2002-06-28 | 145d |  | finish no earlier than 2002-06-28 | G1 | 1160h | 1160h |  |  |  |  |  |  |  |  |  |
| 830 | 101.1.6 | Changes to 45.005 | 145d | 2001-12-10 A | 2002-06-28 A | 100% |  | 2001-12-10 | 2002-06-28 | 145d |  | finish no earlier than 2002-06-28 | G1 | 1160h | 1160h |  |  |  |  |  |  |  |  |  |
| 831 | 101.1.7 | Changes to 24.008 | 145d | 2001-12-10 A | 2002-06-28 A | 100% |  | 2001-12-10 | 2002-06-28 | 145d |  | finish no earlier than 2002-06-28 | G2 | 1160h | 1160h |  |  |  |  |  |  |  |  |  |
| 832 | 101.1.8 | Changes to 48.058 | 145d | 2001-12-10 A | 2002-06-28 A | 100% |  | 2001-12-10 | 2002-06-28 | 145d |  | finish no earlier than 2002-06-28 | G2 | 1160h | 1160h |  |  |  |  |  |  |  |  |  |
| 833 | 101.2 | GERAN MS Conformance test for 8PSK HR | 270d | 2001-12-10 | 2002-12-20 |  |  | 2001-12-10 | 2002-06-28 | 145d | 287d | finish no earlier than 2002-12-20 | GP | 2160h |  |  |  |  |  |  |  |  |  |  |
| 834 | 101.3 | GERAN BTS Conformance test for 8PSK HR | 270d | 2001-12-10 A | 2002-12-20 A | 100% |  | 2001-12-10 | 2002-06-28 | 145d |  | finish no earlier than 2002-12-20 | GP | 2160h | 2160h |  |  |  |  |  |  |  |  |  |
| 835 | 102 | Service Change and UDI Fallback | 175d | 2001-10-08 A | 2002-06-07 A | 100% |  | 2001-10-08 | 2002-06-07 | 175d |  | finish no earlier than 2002-06-07 | N3 | 1400h | 1400h | SCUDIF |  | 29.007, 27.001, 24.008 | Rune Werner Wiik, Ericsson AS | Rune.Werner.Wiik@ericsson.no | WG |  | Rel5 | David |

Notes:
- 816: IP 30/11/01: Input awaited from GERAN2 to CN4 / 17 May Work complete 100%
- 823: Completed for Rel-5
- 835: [DAB - 15/11/02] - NOTE INTERWORKING ISSUES IDENTIFIED THAT NEED CLARIFICATION

| ID | WBS | Task | Duration | Start | Finish | Complete | Remaining | Baseline start | Baseline finish | Baseline duration | Total slack | Constraint | Resources | Work | Actual work | Text1 | Text2 | Text6 | Text8 | Text9 | Text4 | Text3 | Text7 | Text5 |
| --- | --- | --- | --- | --- | --- | --- | --- | --- | --- | --- | --- | --- | --- | --- | --- | --- | --- | --- | --- | --- | --- | --- | --- | --- |
| 836 | 103 | **Rel-5 USIM toolkit enhancements** | 865d | 2000-06-05 A | 2003-09-26 | 51% | 425.77d | 2000-06-05 | 2003-09-26 | 865d | 87d |  | T3 | 24352h | 13591.2h | USAT1 | Ter | NA | MichaelS | 1800 |  |  |  |  |
| 837 | 103.1 | Test specification for USIM toolkit security mechanims | 349d | 2002-05-28 | 2003-09-26 |  |  | 2002-05-28 | 2003-09-26 | 349d | 87d | finish no earlier than 2003-09-26 | T3 | 2792h |  |  |  |  |  |  | Sophie Viallet (Gemplus) |  |  |  |
| 838 | 103.2 | **Protocol Standardisation of a SIM Toolkit Interpreter** | 688d | 2000-06-05 A | 2003-01-22 | 64% | 250.88d | 2000-06-05 | 2003-01-22 | 688d | 264d |  | T3 | 12512h | 7949.4h | USAT1-Interpr | Ter | Rel5 |  | 1801 | Michael Meyer, G & D | 27.103 | TSG |  |
| 839 | 103.2.1 | Stage 1 | 205d | 2000-06-05 A | 2001-03-16 A | 100% |  | 2000-06-05 | 2001-03-16 | 205d |  | finish no earlier than 2001-03-16 | T3 | 1640h | 1640h |  |  |  |  |  |  |  | TSG |  |
| 840 | 103.2.2 | Stage 2 and 3 | 308d | 2001-01-03 A | 2002-03-08 A | 100% |  | 2001-01-03 | 2002-03-08 | 308d |  | finish no earlier than 2002-03-08 | T3 | 2464h | 2464h |  |  |  |  |  |  |  | TSG |  |
| 841 | 103.2.3 | Test specification | 363d | 2001-09-03 A | 2003-01-22 | 12% | 319.44d | 2001-09-03 | 2003-01-22 | 363d | 264d | finish no earlier than 2003-01-22 | T3 | 2904h | 348.48h |  |  |  |  |  | Gérald MAUNIER (Gemplus) |  | TSG |  |
| 842 | 103.4 | **(U)SIM API** | 133d | 2002-03-20 A | 2002-09-20 A | 100% |  | 2000-09-25 | 2002-09-27 | 525d |  |  | T3 | 2128h | 2128h | USAT1-API |  | NA |  |  |  |  |  |  |
| 843 | 103.4.1 | Java API Test specification | 133d | 2002-03-20 A | 2002-09-20 A | 100% |  | 2002-03-20 | 2002-09-20 | 133d |  | finish no earlier than 2002-09-20 | T3 | 1064h | 1064h |  |  |  |  |  | Mario Pérez (Microelectrónica Española) |  |  |  |
| 844 | 104 | small Technical Enhancements and Improvements for Rel5 | 325d | 2000-12-25 A | 2002-03-22 A | 100% |  | 2000-12-25 | 2002-03-22 | 325d |  | start no earlier than 2000-12-25 | Generic | 2600h | 2600h | TEI5 |  | Rel5 |  | 1993 |  |  | TSG |  |
| 845 | 105 | Technical Report on UE Functionality Split | 86d | 2000-01-03 | 2000-05-01 |  |  | 2002-04-22 | 2002-08-19 | 86d | 976d |  | S1 | 688h |  | UESPLIT |  | Rel5 | Michael C |  | Sanjay Gupta, Motorola |  | TSG | sanjay.gupta@motorola.com |
| 846 | 106 | **User Equipment Management** | 267d | 2001-06-21 A | 2002-06-28 | 99% | 0d | 2001-06-21 | 2002-06-28 | 267d | 0d |  | S5 | 3752h | 3752h | UEM |  | NA | Adrian |  | John Mudge (Vodafone) |  | TSG | john.mudge@vf.vodafone.co.uk |
| 847 | 106.1 | FS on User Equipment (UE) Management | 267d | 2001-06-21 A | 2002-06-28 A | 100% |  | 2001-06-21 | 2002-06-28 | 267d |  | finish no earlier than 2002-06-28 | S5 | 2136h | 2136h | OAM-UEM |  | Rel5 | Adrian |  | John Mudge (Vodafone) | 32.802 | TSG | john.mudge@VF.VODAFONE.CO.UK |
| 848 | 107 | **Flow control supporting an MS with multiple data flows with different QoS over the Gb interface** | 50d | 2002-06-24 A | 2002-08-30 A | 100% |  |  |  |  |  |  | GP | 1288h | 1288h | FlowCon |  | Rel5 |  |  | Ingemar Backlund, Ericsson |  | TSG |  |
| 849 | 107.1 | **Update of stage 2 specifications** | 50d | 2002-06-24 A | 2002-08-30 A | 100% |  |  |  |  |  |  | GP | 808h | 808h |  |  |  |  |  |  |  | TSG |  |
| 850 | 107.1.1 | Concept document 23.060 (changes to) | 46d | 2002-06-28 A | 2002-08-30 A | 100% |  |  |  |  |  | finish no earlier than 2002-08-30 | S2 | 368h | 368h |  |  |  |  |  |  |  |  |  |
| 851 | 107.1.2 | Flow Control | 5d | 2002-06-24 A | 2002-06-28 A | 100% |  |  |  |  |  | finish no earlier than 2002-06-28 | GP | 40h | 40h |  |  |  |  |  |  |  |  |  |
| 852 | 107.2 | **Modification of BSSGP protocol** | 5d | 2002-06-24 A | 2002-06-28 A | 100% |  |  |  |  |  |  | GP | 80h | 80h |  |  |  |  |  | Ingemar Backlund, Ericsson |  | TSG |  |
| 853 | 107.2.1 | Stage 3 (changes to 48.018) | 5d | 2002-06-24 A | 2002-06-28 A | 100% |  |  |  |  |  | finish no earlier than 2002-06-28 | G2 | 40h | 40h |  |  |  |  |  |  |  |  |  |
| 854 | 108 | **Multiple TBF in A/Gb mode** | 311d | 2002-04-19 A | 2003-06-27 | 11% | 277.91d | 2002-04-19 | 2002-06-28 | 51d | 152d |  | GP | 11720h | 1096.75h | MULTBF |  | Rel5 |  |  | Gunnar Mildh, Ericsson |  | TSG | gunnar.mildh@era.ericsson.se |
| 855 | 108.1 | **Multiple TBF in A/Gb mode** | 156d | 2002-04-19 A | 2002-11-22 | 17% | 130d | 2002-04-19 | 2002-06-28 | 51d | 307d |  | GP | 4992h | 832h | MULTBF-Agbmode |  |  |  |  |  |  |  |  |
| 856 | 108.1.1 | Multiple TBF Concept paper | 156d | 2002-04-19 A | 2002-11-22 | 50% | 78d | 2002-04-19 | 2002-06-28 | 51d | 307d | finish no earlier than 2002-11-22 | GP | 1248h | 624h |  |  |  |  |  |  |  |  |  |
| 857 | 108.1.2 | Multiple TBF Stage 2 (43.064) CRs | 156d | 2002-04-19 | 2002-11-22 |  |  | 2002-04-19 | 2002-06-28 | 51d | 307d | finish no earlier than 2002-11-22 | G1 | 1248h |  |  |  |  |  |  |  |  |  |  |
| 858 | 108.1.3 | Multiple TBF Stage 3 (44.060) CRs | 156d | 2002-04-19 | 2002-11-22 |  |  | 2002-04-19 | 2002-06-28 | 51d | 307d | finish no earlier than 2002-11-22 | G2 | 1248h |  |  |  |  |  |  |  |  |  |  |
| 859 | 108.2 | **Multiple TBF in A/Gb mode – MS testingGP-022098** | 265d | 2002-06-24 | 2003-06-27 |  |  |  |  |  | 152d |  | GP | 4240h |  |  |  |  |  |  | Ingemar Backlund, Ericsson |  |  |  |
| 860 | 108.2.1 | MS conformance tests | 265d | 2002-06-24 | 2003-06-27 |  |  |  |  |  | 152d | finish no earlier than 2003-06-27 | G4 | 2120h |  |  |  |  |  |  |  |  |  |  |

Notes:
- 838: 28/5/2001: T3-19 proposed that since the stage 2 and 3 will not be presented to TP-12 for approval as expected, the WI will be moved to rel-5, with completion expected at TP-13.
- 839: 5/10/2001: Stage one comepeted at TP-12.
- 840: 5/10/2001: TS 31.112 and 31.113 approved at TP-13. TS 31.114 to be presented to TP-14.
- 841: 5/10/2001: Work started on test specification
- 842: 8/3/2001: test spec is based on R99 core spec, so deleted from Workplan
- 844: "Joker" WI, to be used for a Rel 5 CR not related to any feature and with very limited impact on the system
- 846: az: Rel-5->NA (to cover also Rel-6)

| ID | WBS | Task | Duration | Start | Finish | Complete | Remaining | Baseline start | Baseline finish | Baseline duration | Total slack | Constraint | Resources | Work | Actual work | Text1 | Text4 | Text6 | Text7 | Text8 | Text9 |
| --- | --- | --- | --- | --- | --- | --- | --- | --- | --- | --- | --- | --- | --- | --- | --- | --- | --- | --- | --- | --- | --- |
| 861 | 109 | **Alignment of 3G functional split and Iu** | 652d | 2000-06-08 A | 2002-12-06 | 89% | 69.67d | 2000-06-08 | 2002-12-06 | 652d | 297d |  | GP | 150782h | 123264h | GER3GAL | Frank Muller, Ericsson | Rel5 | TSG | Paolo | 2345 |
| 862 | 109.1 | **GERAN user / control plane** | 540d | 2000-08-07 A | 2002-08-30 | 99% | 0d | 2000-07-19 | 2002-06-28 | 507.5d | 0d |  | GP | 36232h | 32092h | GER3GAL-GUCOPL | Frank Muller, Ericsson |  | TSG | Paolo | 2346 |
| 863 | 109.1.1 | **Alignment with UMTS bearer concept** | 540d | 2000-08-07 A | 2002-08-30 | 99% | 0d | 2000-07-19 | 2002-06-28 | 507.5d | 0d |  | GP | 24952h | 22392h |  |  |  | TSG |  | 2347 |
| 864 | 109.1.1.1 | Enhanced power control | 1d | 2001-08-31 A | 2001-08-31 A | 100% |  | 2001-08-31 | 2001-08-31 | 1d |  | finish no earlier than 2001-08-31 | GP | 8h | 8h |  |  |  | TSG |  |  |
| 865 | 109.1.1.2 | Stage 2 | 235d | 2000-08-07 A | 2001-06-29 A | 100% |  | 2000-08-07 | 2001-06-29 | 235d |  | finish no earlier than 2001-06-29 | GP | 1880h | 1880h |  |  |  | TSG |  | 2423 |
| 866 | 109.1.1.3 | Adoption of the UTRAN PDCP | 295d | 2000-11-06 A | 2001-12-21 A | 100% |  | 2000-11-06 | 2001-12-21 | 295d |  | finish no earlier than 2001-12-21 | GP | 2360h | 2360h |  |  |  | TSG |  | 2348 |
| 867 | 109.1.1.4 | Development of RLC / MAC | 261d | 2001-08-31 A | 2002-08-30 A | 100% |  | 2001-08-31 | 2002-06-28 | 216d |  | finish no earlier than 2002-08-30 | GP | 2088h | 2088h |  |  |  | TSG |  |  |
| 868 | 109.1.1.5 | Development of GERAN RRC | 266d | 2001-06-22 A | 2002-06-28 A | 100% |  | 2001-06-22 | 2002-06-28 | 266d |  | finish no earlier than 2002-06-28 | GP | 2128h | 2128h |  |  |  | TSG |  |  |
| 869 | 109.1.1.6 | Ciphering and integrity protection concept paper | 166d | 2001-08-31 A | 2002-04-19 A | 100% |  | 2001-08-31 | 2002-04-19 | 166d |  | finish no earlier than 2002-04-19 | GP | 1328h | 1328h |  |  |  | TSG |  |  |
| 870 | 109.1.1.7 | Multiple TBF or equivalent Concept paper | 116d | 2001-08-31 A | 2002-02-08 A | 100% |  | 2001-08-31 | 2002-02-08 | 116d |  | finish no earlier than 2002-02-08 | GP | 928h | 928h |  |  |  | TSG |  |  |
| 871 | 109.1.1.8 | Paging concept | 166d | 2001-08-31 A | 2002-04-19 A | 100% |  | 2001-08-31 | 2002-04-19 | 166d |  | finish no earlier than 2002-04-19 | GP | 1328h | 1328h |  |  |  | TSG |  |  |
| 872 | 109.1.1.9 | Dedicated Physical subchannels, includes traffic and control channels | 66d | 2001-08-31 A | 2001-11-30 A | 100% |  | 2001-08-31 | 2001-11-30 | 66d |  | finish no earlier than 2001-11-30 | GP | 528h | 528h |  |  |  | TSG |  |  |
| 873 | 109.1.1.10 | Iu support and broadcast concept | 166d | 2001-08-31 A | 2002-04-19 A | 100% |  | 2001-08-31 | 2002-04-19 | 166d |  | finish no earlier than 2002-04-19 | GP | 1328h | 1328h |  |  |  | TSG |  |  |
| 874 | 109.1.1.11 | Impact of using RLC instead of LAPDm concept | 116d | 2001-08-31 A | 2002-02-08 A | 100% |  | 2001-08-31 | 2002-02-08 | 116d |  | finish no earlier than 2002-02-08 | GP | 928h | 928h |  |  |  | TSG |  |  |
| 875 | 109.1.1.12 | Contention resolution, mobile station identity, and access concept | 66d | 2001-08-31 A | 2001-11-30 A | 100% |  | 2001-08-31 | 2001-11-30 | 66d |  | finish no earlier than 2001-11-30 | GP | 528h | 528h |  |  |  | TSG |  |  |
| 876 | 109.1.1.13 | PDCP concept | 166d | 2001-08-31 A | 2002-04-19 A | 100% |  | 2001-08-31 | 2002-04-19 | 166d |  | finish no earlier than 2002-04-19 | GP | 1328h | 1328h |  |  |  | TSG |  |  |
| 877 | 109.1.1.14 | Downlink delayed TBF release | 261d | 2001-08-31 A | 2002-08-30 A | 100% |  | 2001-08-31 | 2001-11-30 | 66d |  | finish no earlier than 2002-08-30 | GP | 2088h | 2088h |  |  |  | TSG |  |  |
| 878 | 109.1.1.15 | Add transparent RLC Concept | 116d | 2001-08-31 A | 2002-02-08 A | 100% |  | 2001-08-31 | 2002-02-08 | 116d |  | finish no earlier than 2002-02-08 | GP | 928h | 928h |  |  |  | TSG |  |  |
| 879 | 109.1.1.16 | Handover concept | 116d | 2001-08-31 A | 2002-02-08 A | 100% |  | 2001-08-31 | 2002-02-08 | 116d |  | finish no earlier than 2002-02-08 | GP | 928h | 928h |  |  |  |  |  |  |
| 880 | 109.1.2 | **Physical layer alignment with UMTS bearer concept** | 280d | 2000-11-06 A | 2001-11-30 | 99% | 0d | 2000-11-06 | 2001-11-30 | 280d | 0d |  | GP | 6960h | 5380h |  |  |  | TSG |  | 2424 |
| 881 | 109.1.2.1 | PDTCH/TCH in 45.003 | 155d | 2000-11-06 A | 2001-06-08 A | 100% |  | 2000-11-06 | 2001-06-08 | 155d |  | finish no earlier than 2001-06-08 | GP | 1240h | 1240h |  |  |  | TSG |  | 2356 |
| 882 | 109.1.2.2 | Control channels in 45.003 | 155d | 2000-11-06 A | 2001-06-08 A | 100% |  | 2000-11-06 | 2001-06-08 | 155d |  | finish no earlier than 2001-06-08 | GP | 1240h | 1240h |  |  |  | TSG |  | 2357 |
| 883 | 109.1.2.3 | Receiver performance in 45.005 for PDTCH/TCH and control channels | 280d | 2000-11-06 A | 2001-11-30 A | 100% |  | 2000-11-06 | 2001-11-30 | 280d |  | finish no earlier than 2001-11-30 | GP | 2240h | 2240h |  |  |  | TSG |  | 2358 |
| 884 | 109.2 | **Iu rg interface** | 430d | 2000-11-06 A | 2002-06-28 A | 100% |  | 2000-11-06 | 2002-06-28 | 430d |  |  | GP; RP | 59660h | 56220h | GER3GAL-Iurg | Frank Muller, Ericsson |  | TSG | Paolo | 2359 |
| 885 | 109.2.1 | **Inter BSS interface** | 430d | 2000-11-06 A | 2002-06-28 A | 100% |  | 2000-11-06 | 2002-06-28 | 430d |  |  | GP; RP | 24080h | 24080h |  |  |  |  |  | 2425 |
| 886 | 109.2.1.1 | Identification of requirements | 430d | 2000-11-06 A | 2002-06-28 A | 100% |  | 2000-11-06 | 2002-06-28 | 430d |  | finish no earlier than 2002-06-28 | GP | 3440h | 3440h |  |  |  |  |  | 2360 |
| 887 | 109.2.1.2 | Stage 2 | 430d | 2000-11-06 A | 2002-06-28 A | 100% |  | 2000-11-06 | 2002-06-28 | 430d |  | finish no earlier than 2002-06-28 | GP | 3440h | 3440h |  |  |  |  |  | 2361 |
| 888 | 109.2.1.3 | Adoption of relevant parts from Iur | 430d | 2000-11-06 A | 2002-06-28 A | 100% |  | 2000-11-06 | 2002-06-28 | 430d |  | finish no earlier than 2002-06-28 | GP | 3440h | 3440h |  |  |  |  |  | 2362 |
| 889 | 109.2.1.4 | Complementation with GERAN specifics | 430d | 2000-11-06 A | 2002-06-28 A | 100% |  | 2000-11-06 | 2002-06-28 | 430d |  | finish no earlier than 2002-06-28 | GP | 3440h | 3440h |  |  |  |  |  | 2363 |
| 890 | 109.2.1.5 | New stage 3 | 430d | 2000-11-06 A | 2002-06-28 A | 100% |  | 2000-11-06 | 2002-06-28 | 430d |  | finish no earlier than 2002-06-28 | GP | 3440h | 3440h |  |  |  |  |  | 2364 |

Notes:
- 861: AWS, Nokia, Ericsson, Nortel, Siemens, Vodafone
- 862: AWS, Nokia, Ericsson, Nortel, Siemens, Vodafone
- 866: Responsible is GERAN; RAN WG2 help may be needed.
- 884: AWS, Nokia, Ericsson, Nortel, Siemens, Vodafone

| ID | WBS | Task | Duration | Start | Finish | Complete | Remaining | Baseline start | Baseline finish | Baseline duration | Total slack | Constraint | Resources | Work | Actual work | Text9 | Text8 | Text1 | Text4 | Text6 | Text7 |
| --- | --- | --- | --- | --- | --- | --- | --- | --- | --- | --- | --- | --- | --- | --- | --- | --- | --- | --- | --- | --- | --- |
| 891 | 109.2.2 | **Inter BSS-RNS interface** | 430d | 2000-11-06 A | 2002-06-28 A | 100% |  | 2000-11-06 | 2002-06-28 | 430d |  |  | GP; RP | 28700h | 28700h | 2426 |  |  |  |  |  |
| 892 | 109.2.2.1 | Identification of requirements | 430d | 2000-11-06 A | 2002-06-28 A | 100% |  | 2000-11-06 | 2002-06-28 | 430d |  | start no earlier than 2000-11-06 | GP; R3 | 6880h | 6880h | 2365 |  |  |  |  |  |
| 893 | 109.2.2.2 | Stage 2 | 430d | 2000-11-06 A | 2002-06-28 A | 100% |  | 2000-11-06 | 2002-06-28 | 430d |  | finish no earlier than 2002-06-28 | GP; R3 | 5744.8h | 5744.8h | 2366 |  |  |  |  |  |
| 894 | 109.2.2.3 | Adoption of relevant parts from Iur | 430d | 2000-11-06 A | 2002-06-28 A | 100% |  | 2000-11-06 | 2002-06-28 | 430d |  | finish no earlier than 2002-06-28 | GP; R3 | 6880h | 6880h | 2367 |  |  |  |  |  |
| 895 | 109.2.2.4 | Complementation with GERAN specifics | 107.5d | 2002-01-30 A | 2002-06-28 A | 100% |  | 2002-01-30 | 2002-06-28 | 107.5d |  | finish no earlier than 2002-06-28 | GP; R3 | 1720h | 1720h | 2368 |  |  |  |  |  |
| 896 | 109.2.2.5 | New stage 3 | 107.5d | 2002-01-30 A | 2002-06-28 A | 100% |  | 2002-01-30 | 2002-06-28 | 107.5d |  | finish no earlier than 2002-06-28 | GP; R3 | 1720h | 1720h | 2369 |  |  |  |  |  |
| 897 | 109.3 | **Voice over GERAN PS and CS concept** | 430d | 2000-11-06 A | 2002-06-28 A | 100% |  | 2000-11-06 | 2002-06-28 | 430d |  |  | GP; R3 | 33338.4h | 33338.4h | 2370 | Paolo |  |  |  |  |
| 898 | 109.3.1 | Architecture for A, Iu cs and Iu ps | 430d | 2000-11-06 A | 2002-06-28 A | 100% |  | 2000-11-06 | 2002-06-28 | 430d |  | finish no earlier than 2002-06-28 | GP; R3 | 6412.8h | 6412.8h | 2371 |  |  |  |  |  |
| 899 | 109.3.2 | Transcoder position/operation | 115d | 2000-11-06 A | 2001-04-13 A | 100% |  | 2000-11-06 | 2001-04-13 | 115d |  | finish no earlier than 2001-04-13 | GP | 920h | 920h | 2372 |  |  |  |  |  |
| 900 | 109.3.3 | Handover | 430d | 2000-11-06 A | 2002-06-28 A | 100% |  | 2000-11-06 | 2002-06-28 | 430d |  | finish no earlier than 2002-06-28 | GP; R3 | 6412.8h | 6412.8h | 2373 |  |  |  |  |  |
| 901 | 109.3.4 | RTP payload | 430d | 2000-11-06 A | 2002-06-28 A | 100% |  | 2000-11-06 | 2002-06-28 | 430d |  | finish no earlier than 2002-06-28 | GP; R3 | 6412.8h | 6412.8h | 2374 |  |  |  |  |  |
| 902 | 109.3.5 | Codec renegotiation concept | 365d | 2000-11-06 A | 2002-03-29 A | 100% |  |  |  |  |  | finish no earlier than 2002-03-29 | GP; R3 | 5840h | 5840h |  |  |  |  |  |  |
| 903 | 109.3.6 | LA | 115d | 2000-11-06 A | 2001-04-13 A | 100% |  |  |  |  |  | finish no earlier than 2001-04-13 | GP | 920h | 920h |  |  |  |  |  |  |
| 904 | 109.4 | **GERAN MS Conformance test for GERAN interface evolution** | 390d | 2001-06-11 | 2002-12-06 |  |  | 2001-06-11 | 2002-12-06 | 390d | 297d |  | GP | 6240h |  | 2388 | Paolo |  |  |  |  |
| 905 | 109.4.1 | MS test | 390d | 2001-06-11 | 2002-12-06 |  |  | 2001-06-11 | 2002-12-06 | 390d | 297d | finish no earlier than 2002-12-06 | GP | 3120h |  | 2389 |  |  |  |  |  |
| 906 | 109.5 | **GERAN MS Conformance test for GERAN interface evolution** | 652d | 2000-06-08 | 2002-12-06 |  |  | 2000-06-08 | 2002-12-06 | 652d | 297d |  | GP | 10432h |  | 2390 | Paolo |  |  |  |  |
| 907 | 109.5.1 | BSS test | 652d | 2000-06-08 | 2002-12-06 |  |  | 2000-06-08 | 2002-12-06 | 652d | 297d | finish no earlier than 2002-12-06 | GP | 5216h |  | 2391 |  |  |  |  |  |
| 908 | 110 | **GERAN support for IMS** | 690d | 2000-05-01 A | 2002-12-20 | 59% | 286.24d | 2000-05-01 | 2002-12-20 | 690d | 287d |  | GP | 66591.8h | 29961h |  | Paolo | GERIMS | Shkumbin Hamiti, Nokia | Rel5 | TSG |
| 909 | 110.1 | **GERAN Header adaptation** | 690d | 2000-05-01 A | 2002-12-20 A | 100% |  | 2000-05-01 | 2002-12-20 | 690d |  |  | GP; S2; RP | 27325.8h | 18525.8h |  | Paolo | GERIMS-HEADAPT | Shkumbin Hamiti, Nokia |  | TSG |
| 910 | 110.1.1 | Definition of compression and removal modes for PDCP protocol | 22.1d | 2000-05-01 A | 2000-11-10 A | 100% |  | 2000-05-01 | 2000-11-10 | 22.1d |  | finish no earlier than 2000-09-01 | GP; S2; RP | 248.4h | 248.4h | 2332 |  |  |  |  | TSG |
| 911 | 110.1.2 | Conceptual description in stage 2 | 393d | 2000-05-01 A | 2001-10-31 A | 100% |  | 2000-05-01 | 2001-10-31 | 393d |  | finish no earlier than 2001-10-31 | GP; S2; RP | 5989.92h | 5989.92h | 2333 |  |  |  |  | TSG |
| 912 | 110.1.3 | Necessary changes on stage 3 regarding header removal | 439.8d | 2000-11-06 A | 2002-12-20 A | 100% |  | 2000-11-06 | 2002-12-20 | 439.8d |  | finish no earlier than 2002-12-20 | GP; S2; RP | 6767.47h | 6767.47h |  |  |  |  |  | TSG |
| 913 | 110.2 | **GERAN Radio access bearer design for IMS** | 430d | 2000-11-06 A | 2002-06-28 | 89% | 46.49d | 2000-11-06 | 2002-06-28 | 430d | 412d |  | GP; S2; RP | 21658h | 8621.71h | 2335 | Paolo | GERIMS-RABDES | Shkumbin Hamiti, Nokia |  | TSG |
| 914 | 110.2.1 | **MuM control signalling for conversational multimedia services** | 430d | 2000-11-06 A | 2002-06-28 | 89% | 46.49d | 2000-11-06 | 2002-06-28 | 430d | 412d |  | GP; S2; RP | 12458h | 5553.6h | 2422 |  |  |  |  | TSG |
| 915 | 110.2.1.1 | Identification of requirements | 330d | 2000-11-06 A | 2002-02-08 A | 100% |  | 2000-11-06 | 2002-02-08 | 330d |  | finish no earlier than 2002-02-08 | GP; S2; RP | 5545.6h | 5545.6h | 2431 |  |  |  |  | TSG |
| 916 | 110.2.1.2 | Necessary modifications due to SIP | 40d | 2002-05-06 | 2002-06-28 |  |  | 2002-05-06 | 2002-06-28 | 40d | 412d | finish no earlier than 2002-06-28 | GP; S2; RP | 960h |  | 2337 |  |  |  |  | TSG |

Notes:
- 904: Not started
- 905: Not started
- 906: Not started
- 907: Not started
- 908: AWS, Nokia, Ericsson, Nortel, Siemens, Motorola
- 909: AWS, Nokia, Ericsson, Nortel, Siemens, Motorola
- 913: TERMINATED - NOT STANDARDIZED
- 914: TERMINATED - NOT STANDARDIZED
- 915: TERMINATED - NOT STANDARDIZED
- 916: TERMINATED - NOT STANDARDIZED

| ID | WBS | Task | Duration | Start | Finish | Complete | Baseline start | Baseline finish | Baseline duration | Total slack | Constraint | Resources | Work | Actual work | Text1 | Text4 | Text7 | Text8 | Text9 | Text6 |
| --- | --- | --- | --- | --- | --- | --- | --- | --- | --- | --- | --- | --- | --- | --- | --- | --- | --- | --- | --- | --- |
| 917 | 110.3 | **GERAN MS Conformance test for support of IMS** | 400d | 2001-06-11 | 2002-12-20 |  | 2001-06-11 | 2002-12-20 | 400d | 287d |  | GP | 6400h |  | GERIMS-MSconf | Shkumbin Hamiti, Nokia | TSG | Paolo | 2341 |  |
| 918 | 110.3.1 | MS test | 400d | 2001-06-11 | 2002-12-20 |  | 2001-06-11 | 2002-12-20 | 400d | 287d | finish no earlier than 2002-12-20 | G4 | 3200h |  |  |  | TSG |  | 2342 |  |
| 919 | 110.4 | **GERAN BTS Conformance test for support of IMS** | 400d | 2001-06-11 | 2002-12-20 |  | 2001-06-11 | 2002-12-20 | 400d | 287d |  | GP | 6400h |  | GERIMS-BTSconf | Shkumbin Hamiti, Nokia | TSG | Paolo | 2343 |  |
| 920 | 110.4.1 | BTS test | 400d | 2001-06-11 | 2002-12-20 |  | 2001-06-11 | 2002-12-20 | 400d | 287d | finish no earlier than 2002-12-20 | G3 | 3200h |  |  |  | TSG |  | 2344 |  |
| 921 | 116 | MS Conformance Testing of Dual Transfer Mode | 65d? | 2002-11-11 A | 2003-02-07 A | 100% |  |  |  |  | finish no earlier than 2003-02-07 | G4; G5 | 1040h | 1040h | MSCTDTM | Dave Fox, Vodafone |  |  |  | NA |

Notes:
- 917: TERMINATED - NOT STANDARDIZED
- 918: TERMINATED - NOT STANDARDIZED
- 919: TERMINATED - NOT STANDARDIZED
- 920: TERMINATED - NOT STANDARDIZED
- 921: Needed to complete DTM (R99)
